# Imager and IFS PD Phase v1_2

How a schedule from MS Project changed from version to version. A marks actual dates.

## Version 1 (saved 2009-06-25, file Imager_and_IFS_PD_Phase_v1_2_tracked_May09.mpp)

| ID | WBS | Task | Duration | Start | Finish | Predecessors | Complete | Total float | Constraint |
| --- | --- | --- | --- | --- | --- | --- | --- | --- | --- |
| 1 | 0 | **Milestones** | 303.1d? | 2009-05-01 | 2010-06-30 |  |  | 0d |  |
| 2 |  | Project Start | 0d? | 2009-05-01 | 2009-05-01 |  |  | 0d |  |
| 3 |  | Imager Preliminary Design Review | 0d? | 2010-06-30 | 2010-06-30 | 65FS-1d |  | 129.15d |  |
| 4 |  | IFS System Design Review | 0d | 2010-02-24 | 2010-02-24 | 121FS-1d |  | 218.87d |  |
| 5 | 1 | **Near-IR Imager and IFS** | 432.25d? | 2009-05-01 A | 2010-12-28 |  | 2% | 0d |  |
| 6 | 1.1 | **Management** | 379.5d? | 2009-06-02 | 2010-11-15 |  |  | 30.75d |  |
| 7 | 1.1.1 | **Monthly Reports** | 371d | 2009-06-05 | 2010-11-05 |  |  | 36.25d |  |
| 8 |  | Monthly Reports 1 | 1d | 2009-06-05 | 2009-06-05 |  |  | 406.25d | start no earlier than 2009-06-05 |
| 9 |  | Monthly Reports 2 | 1d | 2009-07-06 | 2009-07-06 |  |  | 385.25d | start no earlier than 2009-07-05 |
| 10 |  | Monthly Reports 3 | 1d | 2009-08-05 | 2009-08-05 |  |  | 363.25d | start no earlier than 2009-08-05 |
| 11 |  | Monthly Reports 4 | 1d | 2009-09-07 | 2009-09-07 |  |  | 340.25d | start no earlier than 2009-09-05 |
| 12 |  | Monthly Reports 5 | 1d | 2009-10-05 | 2009-10-05 |  |  | 320.25d | start no earlier than 2009-10-05 |
| 13 |  | Monthly Reports 6 | 1d | 2009-11-05 | 2009-11-05 |  |  | 297.25d | start no earlier than 2009-11-05 |
| 14 |  | Monthly Reports 7 | 1d | 2009-12-07 | 2009-12-07 |  |  | 275.25d | start no earlier than 2009-12-05 |
| 15 |  | Monthly Reports 8 | 1d | 2010-01-05 | 2010-01-05 |  |  | 254.25d | start no earlier than 2010-01-05 |
| 16 |  | Monthly Reports 9 | 1d | 2010-02-05 | 2010-02-05 |  |  | 231.25d | start no earlier than 2010-02-05 |
| 17 |  | Monthly Reports 10 | 1d | 2010-03-05 | 2010-03-05 |  |  | 211.25d | start no earlier than 2010-03-05 |
| 18 |  | Monthly Reports 11 | 1d | 2010-04-05 | 2010-04-05 |  |  | 190.25d | start no earlier than 2010-04-05 |
| 19 |  | Monthly Reports 12 | 1d | 2010-05-05 | 2010-05-05 |  |  | 168.25d | start no earlier than 2010-05-05 |
| 20 |  | Monthly Reports 13 | 1d | 2010-06-07 | 2010-06-07 |  |  | 145.25d | start no earlier than 2010-06-05 |
| 21 |  | Monthly Reports 14 | 1d | 2010-07-05 | 2010-07-05 |  |  | 125.25d | start no earlier than 2010-07-05 |
| 22 |  | Monthly Reports 15 | 1d | 2010-08-05 | 2010-08-05 |  |  | 102.25d | start no earlier than 2010-08-05 |
| 23 |  | Monthly Reports 16 | 1d | 2010-09-06 | 2010-09-06 |  |  | 80.25d | start no earlier than 2010-09-05 |
| 24 |  | Monthly Reports 17 | 1d | 2010-10-05 | 2010-10-05 |  |  | 59.25d | start no earlier than 2010-10-05 |
| 25 |  | Monthly Reports 18 | 1d | 2010-11-05 | 2010-11-05 |  |  | 36.25d | start no earlier than 2010-11-05 |
| 26 | 1.1.2 | **Project Meetings** | 370.5d | 2009-06-15 | 2010-11-15 |  |  | 30.75d |  |
| 27 |  | Project Meetings 1 | 4h | 2009-06-15 | 2009-06-15 |  |  | 400.75d | start no earlier than 2009-06-15 |
| 28 |  | Project Meetings 2 | 4h | 2009-07-15 | 2009-07-15 |  |  | 378.75d | start no earlier than 2009-07-15 |
| 29 |  | Project Meetings 3 | 4h | 2009-08-17 | 2009-08-17 |  |  | 355.75d | start no earlier than 2009-08-15 |
| 30 |  | Project Meetings 4 | 4h | 2009-09-15 | 2009-09-15 |  |  | 334.75d | start no earlier than 2009-09-15 |
| 31 |  | Project Meetings 5 | 4h | 2009-10-15 | 2009-10-15 |  |  | 312.75d | start no earlier than 2009-10-15 |
| 32 |  | Project Meetings 6 | 4h | 2009-11-16 | 2009-11-16 |  |  | 290.75d | start no earlier than 2009-11-15 |
| 33 |  | Project Meetings 7 | 4h | 2009-12-15 | 2009-12-15 |  |  | 269.75d | start no earlier than 2009-12-15 |
| 34 |  | Project Meetings 8 | 4h | 2010-01-15 | 2010-01-15 |  |  | 246.75d | start no earlier than 2010-01-15 |
| 35 |  | Project Meetings 9 | 4h | 2010-02-15 | 2010-02-15 |  |  | 225.75d | start no earlier than 2010-02-15 |
| 36 |  | Project Meetings 10 | 4h | 2010-03-15 | 2010-03-15 |  |  | 205.75d | start no earlier than 2010-03-15 |
| 37 |  | Project Meetings 11 | 4h | 2010-04-15 | 2010-04-15 |  |  | 182.75d | start no earlier than 2010-04-15 |
| 38 |  | Project Meetings 12 | 4h | 2010-05-17 | 2010-05-17 |  |  | 160.75d | start no earlier than 2010-05-15 |
| 39 |  | Project Meetings 13 | 4h | 2010-06-15 | 2010-06-15 |  |  | 139.75d | start no earlier than 2010-06-15 |
| 40 |  | Project Meetings 14 | 4h | 2010-07-15 | 2010-07-15 |  |  | 117.75d | start no earlier than 2010-07-15 |
| 41 |  | Project Meetings 15 | 4h | 2010-08-16 | 2010-08-16 |  |  | 95.75d | start no earlier than 2010-08-15 |
| 42 |  | Project Meetings 16 | 4h | 2010-09-15 | 2010-09-15 |  |  | 73.75d | start no earlier than 2010-09-15 |
| 43 |  | Project Meetings 17 | 4h | 2010-10-15 | 2010-10-15 |  |  | 51.75d | start no earlier than 2010-10-15 |
| 44 |  | Project Meetings 18 | 4h | 2010-11-15 | 2010-11-15 |  |  | 30.75d | start no earlier than 2010-11-15 |
| 45 |  | System Engineering Management Plan | 12.5d | 2009-06-02 | 2009-06-22 | 2FS+20d |  | 395.69d |  |
| 46 |  | Proposals to Fund Future Phases (ATI, MRI would be early 2010) | 43d? | 2009-09-02 | 2009-10-30 |  |  | 301.25d | start no earlier than 2009-09-02 |
| 47 |  | Cost Review | 25d? | 2010-02-18 | 2010-04-05 | 156 |  | 190.54d |  |
| 48 | 1.1.6 | **Project Plan Maintenance** | 328d | 2009-06-04 | 2010-09-06 |  |  | 80.25d |  |
| 49 |  | Project Plan Maintenance 1 | 1d | 2009-06-04 | 2009-06-04 |  |  | 377.18d | start no earlier than 2009-06-04 |
| 50 |  | Project Plan Maintenance 2 | 1d | 2009-09-04 | 2009-09-04 |  |  | 311.18d | start no earlier than 2009-09-04 |
| 51 |  | Project Plan Maintenance 3 | 1d | 2009-12-04 | 2009-12-04 |  |  | 246.18d | start no earlier than 2009-12-04 |
| 52 |  | Project Plan Maintenance 4 | 1d | 2010-03-04 | 2010-03-04 |  |  | 182.18d | start no earlier than 2010-03-04 |
| 53 |  | Project Plan Maintenance 5 | 1d | 2010-06-04 | 2010-06-04 |  |  | 116.18d | start no earlier than 2010-06-04 |
| 54 |  | Project Plan Maintenance 6 | 1d | 2010-09-06 | 2010-09-06 |  |  | 50.18d | start no earlier than 2010-09-04 |
| 55 | 1.1.7 | **Budget Maintenance** | 348d | 2009-06-04 | 2010-10-04 |  |  | 60.25d |  |
| 56 |  | Budget Maintenance 1 | 1d | 2009-06-04 | 2009-06-04 |  |  | 377.18d | start no earlier than 2009-06-04 |
| 57 |  | Budget Maintenance 2 | 1d | 2009-08-04 | 2009-08-04 |  |  | 334.18d | start no earlier than 2009-08-04 |
| 58 |  | Budget Maintenance 3 | 1d | 2009-10-05 | 2009-10-05 |  |  | 290.18d | start no earlier than 2009-10-04 |
| 59 |  | Budget Maintenance 4 | 1d | 2009-12-04 | 2009-12-04 |  |  | 246.18d | start no earlier than 2009-12-04 |
| 60 |  | Budget Maintenance 5 | 1d | 2010-02-04 | 2010-02-04 |  |  | 202.18d | start no earlier than 2010-02-04 |
| 61 |  | Budget Maintenance 6 | 1d | 2010-04-05 | 2010-04-05 |  |  | 160.18d | start no earlier than 2010-04-04 |
| 62 |  | Budget Maintenance 7 | 1d | 2010-06-04 | 2010-06-04 |  |  | 116.18d | start no earlier than 2010-06-04 |
| 63 |  | Budget Maintenance 8 | 1d | 2010-08-04 | 2010-08-04 |  |  | 73.18d | start no earlier than 2010-08-04 |
| 64 |  | Budget Maintenance 9 | 1d | 2010-10-04 | 2010-10-04 |  |  | 30.18d | start no earlier than 2010-10-04 |
| 65 |  | Preliminary Design Review | 28.18d | 2010-04-29 | 2010-07-01 | 72, 200, 210, 222, 156 |  | 128.15d |  |
| 66 | 1.2 | **Science** | 206.76d? | 2009-06-26 | 2010-04-12 |  |  | 185.5d |  |
| 67 | 1.2.1 | **Science Team Meetings** | 136.5d? | 2009-06-26 | 2010-01-04 |  |  | 255.75d |  |
| 68 |  | Meeting 1 | 1.5d? | 2009-06-26 | 2009-06-29 | 2FS+2mo |  | 390.75d |  |
| 69 |  | Meeting 2 | 2d? | 2009-12-11 | 2010-01-04 | 2FS+8mo |  | 255.75d |  |
| 70 | 1.2.2 | **Common Observing Operations Concept Document** | 186.76d? | 2009-07-24 | 2010-04-12 |  |  | 128.15d |  |

| ID | WBS | Task | Duration | Start | Finish | Predecessors | Complete | Total float |
| --- | --- | --- | --- | --- | --- | --- | --- | --- |
| 71 |  | Initial Draft | 19.75d? | 2009-07-24 | 2009-08-20 | 2FS+3mo |  | 247.35d |
| 72 |  | Final Version | 31.09d? | 2010-02-26 | 2010-04-12 | 190, 209 |  | 128.15d |
| 73 | 1.3 | **Instrument Design and Fabrication** | 432.25d? | 2009-05-01 A | 2010-12-28 |  | 2% | 0d |
| 74 | 1.3.1 | **AO System to Instrument Interface Definitions** | 34d? | 2009-05-01 | 2009-06-17 |  |  | 0d |
| 75 |  | Optical | 2.6d? | 2009-05-01 | 2009-06-02 | 2 |  | 0d |
| 76 |  | Mechanical | 3.5d? | 2009-06-02 | 2009-06-09 | 75 |  | 0d |
| 77 |  | Electronic/Electrical | 1.5d? | 2009-06-10 | 2009-06-11 | 76 |  | 0d |
| 78 |  | Software | 2.5d? | 2009-06-11 | 2009-06-15 | 77 |  | 0d |
| 79 |  | Alignment and Calibration Concept for Instrument on AO System | 2d? | 2009-06-16 | 2009-06-17 | 78 |  | 0d |
| 80 | 1.3.2 | **Shared Facilities** | 96.11d? | 2009-05-01 A | 2009-09-14 |  | 12% | 336.15d |
| 81 | 1.3.2.1 | **AO System** | 96.11d? | 2009-05-01 A | 2009-09-14 |  | 15% | 336.15d |
| 82 | 1.3.2.1.1 | **High Order AO Relay** | 40.5d? | 2009-06-18 A | 2009-08-13 |  | 46% | 357.75d |
| 83 |  | Design Liason | 20d? | 2009-06-18 A | 2009-07-21 | 79 | 75% | 336.06d |
| 84 |  | RTC and Control Liason | 12.5d? | 2009-07-28 | 2009-08-13 | 83 |  | 357.75d |
| 85 | 1.3.2.1.2 | **ADC** | 35d? | 2009-07-27 | 2009-09-14 |  |  | 336.15d |
| 86 |  | Requirements Liason | 20d? | 2009-07-27 | 2009-08-24 | 83 |  | 336.15d |
| 87 |  | Design Liason | 15d? | 2009-08-24 | 2009-09-14 | 86 |  | 336.15d |
| 88 | 1.3.2.1.3 | **Calibration Faciltiy** | 50d? | 2009-05-01 | 2009-07-09 |  |  | 352.77d |
| 89 |  | Requirements Liason | 15.5d? | 2009-05-01 | 2009-06-11 |  |  | 352.77d |
| 90 |  | Design Liason | 20d? | 2009-06-12 | 2009-07-09 | 89 |  | 352.77d |
| 91 | 1.3.2.2 | **Nasmyth Enclosure** | 29.48d? | 2009-07-10 | 2009-08-20 |  |  | 352.77d |
| 92 |  | Requirements Liason | 12.5d? | 2009-07-10 | 2009-08-03 | 90 |  | 352.77d |
| 93 |  | Design Liason | 12.5d? | 2009-08-03 | 2009-08-20 | 92 |  | 352.77d |
| 94 | 1.3.3 | **Instrument** | 432.25d? | 2009-05-01 A | 2010-12-28 |  |  | 0d |
| 95 | 1.3.3.1 | **IFS System Design Phase** | 193.39d? | 2009-06-01 | 2010-02-25 |  |  | 0.54d |
| 96 | 1.3.3.1.1 | **IFS Performance Budgets** | 56.34d | 2009-06-01 | 2009-08-18 |  |  | 0.54d |
| 97 |  | Throughput | 6.67d | 2009-06-01 | 2009-06-09 | 2FS+21d |  | 0.54d |
| 98 |  | Background | 5d | 2009-06-09 | 2009-06-25 | 97 |  | 0.54d |
| 99 |  | Wavefront error | 6.67d | 2009-06-25 | 2009-07-03 | 98 |  | 0.54d |
| 100 |  | Spectroscopic performance | 14.27d | 2009-07-03 | 2009-08-11 | 99 |  | 0.54d |
| 101 |  | Size and mass | 5.21d | 2009-08-11 | 2009-08-18 | 100 |  | 354.91d |
| 102 | 1.3.3.1.2 | **Trade Studies** | 106.33d | 2009-08-11 | 2010-01-06 |  |  | 253.79d |
| 103 |  | FOV and spatial sampling | 14.31d | 2009-08-11 | 2009-09-10 | 100 |  | 266.17d |
| 104 |  | Wavelength coverage and spatial sampling | 13.19d | 2009-09-10 | 2009-10-13 | 100, 103 |  | 266.17d |
| 105 |  | Optimization of image slicing formats and spectrograph formats | 20.25d | 2009-10-13 | 2009-11-20 | 100, 104 |  | 266.17d |
| 106 |  | Separate or combined capability above and below 1 micron | 8.78d | 2009-11-20 | 2009-12-03 | 105 |  | 266.17d |
| 107 |  | Wavefront error allocations | 7.17d | 2009-12-03 | 2009-12-14 | 106 |  | 266.17d |
| 108 |  | Trade study report | 6.68d | 2009-12-14 | 2010-01-06 | 107 |  | 253.79d |
| 109 | 1.3.3.1.3 | **Conceptual Designs** | 106.64d? | 2009-09-22 | 2010-02-17 |  |  | 0.54d |
| 110 |  | Development of design options | 46.07d | 2009-09-22 | 2009-11-25 | 100FS+6w |  | 0.54d |
| 111 |  | Evaluation of design options | 9.74d? | 2009-11-25 | 2009-12-09 | 110 |  | 0.54d |
| 112 |  | Calibration and alignment issues | 5.58d? | 2009-12-09 | 2009-12-17 | 111 |  | 0.54d |
| 113 |  | Downselect of conceptual design | 10d? | 2009-12-17 | 2010-01-08 | 112 |  | 0d |
| 114 |  | Revised performance budgets | 4d? | 2010-01-11 | 2010-01-14 | 113 |  | 243.5d |
| 115 |  | Performance budget report | 3.75d? | 2010-01-15 | 2010-01-20 | 114 |  | 243.5d |
| 116 |  | Performance estimates | 4.38d? | 2010-01-11 | 2010-01-22 | 113 |  | 0d |
| 117 |  | System requirements document | 4.38d? | 2010-01-22 | 2010-01-28 | 116 |  | 0d |
| 118 |  | System design manual | 7.28d? | 2010-01-28 | 2010-02-17 | 117 |  | 0d |
| 119 | 1.3.3.1.4 | **System Design Review** | 5.61d? | 2010-02-17 | 2010-02-25 | 116 |  | 0d |
| 120 |  | System design report | 4.38d? | 2010-02-17 | 2010-02-24 | 118 |  | 0d |
| 121 |  | System design review meeting | 1.23d? | 2010-02-24 | 2010-02-25 | 120 |  | 0d |
| 122 | 1.3.3.2 | **IFS Preliminary Design Phase** | 217.87d? | 2010-02-25 | 2010-12-28 |  |  | 0d |
| 123 |  | Initial AO system to instrument interface definitions | 5.39d? | 2010-02-25 | 2010-03-08 | 121 |  | 0d |
| 124 |  | Alignment and calibration concept | 8.19d? | 2010-03-08 | 2010-03-18 | 123 |  | 0d |
| 125 |  | Optical design | 91.7d? | 2010-03-18 | 2010-07-26 | 124 |  | 0d |
| 126 |  | Mechanical design | 160.82d? | 2010-05-03 | 2010-12-14 | 125FS-60d |  | 0d |
| 127 |  | Electronic design | 30d? | 2010-10-18 | 2010-11-29 | 125FS+60d |  | 10.82d |
| 128 |  | Software design | 23.53d? | 2010-10-18 | 2010-11-18 | 127SS |  | 17.29d |
| 129 |  | Preliminary design report | 8.89d? | 2010-12-14 | 2010-12-24 | 123, 126, 127, 128 |  | 0d |
| 130 |  | Preliminary design review meeting | 1.27d? | 2010-12-24 | 2010-12-28 | 129 |  | 0d |
| 131 | 1.3.3.3 | **Near-IR Imager and IFS Preliminary Design** | 259.5d? | 2009-05-01 A | 2010-04-29 |  | 1% | 172.75d |
| 132 | 1.3.3.3.1 | **Imager Trade Studies** | 39.4d? | 2009-06-02 A | 2009-07-27 |  | 15% | 0d |
| 133 |  | Imager Wavefront Error | 4.75d? | 2009-06-02 | 2009-06-30 | 75 |  | 0d |
| 134 |  | Imager Pixel Scale | 7.1d? | 2009-06-30 A | 2009-07-23 | 133 | 30% | 0d |
| 135 |  | Imager Short Wavelength Cut-off | 2d? | 2009-07-23 | 2009-07-27 | 134 |  | 0d |
| 136 | 1.3.3.3.2 | **Imager Performance Budgets** | 76d? | 2009-05-01 A | 2009-08-14 |  | 1% | 356.25d |
| 137 |  | Imager Sensitivity | 1d? | 2009-07-28 A | 2009-07-28 | 135 | 20% | 356.25d |
| 138 |  | Imager Background | 4.5d? | 2009-07-29 | 2009-08-04 | 137 |  | 356.25d |
| 139 |  | Imager Companion Sensitivity | 4.5d? | 2009-08-04 | 2009-08-14 | 138 |  | 356.25d |
| 140 |  | Imager Wavefront Error | 12d? | 2009-06-30 | 2009-07-16 | 133 |  | 128.15d |

| ID | WBS | Task | Duration | Start | Finish | Predecessors | Total float |
| --- | --- | --- | --- | --- | --- | --- | --- |
| 141 |  | Imager Size and Mass | 5.2d? | 2009-05-01 | 2009-05-18 |  | 420.85d |
| 142 | 1.3.3.3.3 | **Optical Design** | 45.65d? | 2009-07-16 | 2009-09-17 |  | 128.15d |
| 143 |  | Initial Optical Design | 6.25d? | 2009-07-28 | 2009-08-05 | 135 | 364d |
| 144 | 1.3.3.3.3.2 | **Optical Modeling** | 40.65d? | 2009-07-16 | 2009-09-10 |  | 128.15d |
| 145 |  | Fore Optics | 6d? | 2009-07-16 | 2009-07-28 | 140 | 128.15d |
| 146 |  | Lyot Stop | 2d? | 2009-07-29 | 2009-07-30 | 145 | 128.15d |
| 147 |  | Coronagraph | 1.5d? | 2009-07-31 | 2009-08-12 | 146 | 128.15d |
| 148 |  | Imager Camera | 20d? | 2009-08-12 | 2009-09-09 | 147 | 128.15d |
| 149 |  | IFS Fold Mirror | 1.25d? | 2009-09-09 | 2009-09-10 | 148 | 332.5d |
| 150 |  | Preliminary Design Performance Analysis | 5d? | 2009-09-10 | 2009-09-17 | 149 | 332.5d |
| 151 | 1.3.3.3.4 | **Dewar** | 147.95d? | 2009-07-29 | 2010-02-19 |  | 158.65d |
| 152 | 1.3.3.3.4.1 | **Cold Assemblies** | 146.45d? | 2009-07-29 | 2010-02-18 |  | 158.65d |
| 153 | 1.3.3.3.4.1.1 | **Dewar Internal Structure** | 49.5d? | 2009-12-10 | 2010-02-18 |  | 128.15d |
| 154 |  | Interface Specification | 1d? | 2009-12-10 | 2009-12-11 | 186 | 128.15d |
| 155 |  | Mechanical Model | 10d? | 2009-12-11 | 2009-12-25 | 154 | 128.15d |
| 156 |  | FEA | 7.5d? | 2010-02-08 | 2010-02-18 | 155, 190 | 178.21d |
| 157 |  | Thermal Analysis | 5d? | 2009-12-25 | 2010-01-01 | 155 | 154.15d |
| 158 | 1.3.3.3.4.1.2 | **Fore Optics** | 112.95d? | 2009-07-29 | 2010-01-01 |  | 234.6d |
| 159 | 1.3.3.3.4.1.2.1 | **Input Baffle & Coronagraph** | 102.45d? | 2009-08-12 | 2010-01-01 |  | 128.15d |
| 160 |  | Interface Specification | 1.5d? | 2009-08-12 | 2009-08-13 | 147 | 224.1d |
| 161 |  | Mechanical Model | 5d? | 2009-12-25 | 2010-01-01 | 160, 155 | 128.15d |
| 162 | 1.3.3.3.4.1.2.2 | **Re-imager** | 6.5d? | 2009-07-29 | 2009-08-06 |  | 362.75d |
| 163 |  | Interface Specification | 1.5d? | 2009-07-29 | 2009-07-30 | 145 | 362.75d |
| 164 |  | Mechanical Model | 5d? | 2009-07-30 | 2009-08-06 | 163 | 362.75d |
| 165 | 1.3.3.3.4.1.2.3 | **Adjustable Lyot Stop** | 9d? | 2009-07-31 | 2009-08-12 |  | 256.1d |
| 166 |  | Interface Specification | 1.5d? | 2009-07-31 | 2009-08-03 | 146 | 256.1d |
| 167 |  | Mechanical Model | 7.5d? | 2009-08-03 | 2009-08-12 | 166 | 256.1d |
| 168 | 1.3.3.3.4.1.3 | **Filter Wheels** | 19.76d? | 2009-09-09 | 2009-10-07 |  | 216.84d |
| 169 | 1.3.3.3.4.1.3.1 | **Mechanism** | 19.76d? | 2009-09-09 | 2009-10-07 |  | 216.84d |
| 170 |  | Interface Specification | 1.67d? | 2009-09-09 | 2009-09-11 | 148 | 216.84d |
| 171 |  | Mechanical Model | 16.67d? | 2009-09-14 | 2009-10-07 | 172 | 216.84d |
| 172 |  | Filter Specifications | 1.43d? | 2009-09-11 | 2009-09-14 | 170 | 216.84d |
| 173 | 1.3.3.3.4.1.4 | **Imager** | 61.45d? | 2009-09-09 | 2009-12-03 |  | 128.15d |
| 174 | 1.3.3.3.4.1.4.1 | **Camera** | 9d? | 2009-09-09 | 2009-09-22 |  | 128.15d |
| 175 |  | Interface Specification | 1.5d? | 2009-09-09 | 2009-09-10 | 148 | 128.15d |
| 176 |  | Mechanical Model | 7.5d? | 2009-09-11 | 2009-09-22 | 175 | 128.15d |
| 177 | 1.3.3.3.4.1.4.2 | **Detector Head** | 52.45d? | 2009-09-22 | 2009-12-03 |  | 128.15d |
| 178 | 1.3.3.3.4.1.4.2.1 | **Mount** | 6d? | 2009-09-22 | 2009-09-30 |  | 128.15d |
| 179 |  | Interface Specification | 1d? | 2009-09-22 | 2009-09-23 | 176 | 128.15d |
| 180 |  | Mechanical Model | 5d? | 2009-09-23 | 2009-09-30 | 179 | 128.15d |
| 181 | 1.3.3.3.4.1.4.2.2 | **Focus Mechanism** | 42.45d? | 2009-09-30 | 2009-11-27 |  | 128.15d |
| 182 |  | Interface Specification | 2.5d? | 2009-09-30 | 2009-10-27 | 180 | 128.15d |
| 183 |  | Mechanical Model | 10d? | 2009-10-27 | 2009-11-27 | 182 | 128.15d |
| 184 | 1.3.3.3.4.1.4.2.3 | **Cooling Interface** | 4d? | 2009-11-27 | 2009-12-03 |  | 128.15d |
| 185 |  | Interface Specification | 1d? | 2009-11-27 | 2009-11-30 | 183 | 128.15d |
| 186 |  | Mechanical Model | 3d? | 2009-11-30 | 2009-12-03 | 185 | 128.15d |
| 187 | 1.3.3.3.4.2 | **Warm Assemblies** | 35d? | 2010-01-01 | 2010-02-19 |  | 128.15d |
| 188 | 1.3.3.3.4.2.1 | **Dewar Shell** | 35d? | 2010-01-01 | 2010-02-19 |  | 128.15d |
| 189 |  | Interface Specification | 2.78d? | 2010-01-04 | 2010-01-07 | 191 | 128.15d |
| 190 |  | Mechanical Model | 22.22d? | 2010-01-07 | 2010-02-08 | 189 | 128.15d |
| 191 |  | Window Specifications | 1d? | 2010-01-01 | 2010-01-04 | 161 | 128.15d |
| 192 |  | External Connections | 2.5d? | 2010-02-17 | 2010-02-19 | 193 | 221.31d |
| 193 |  | Vacuum System Requirements | 1.5d? | 2010-02-15 | 2010-02-17 | 194 | 128.15d |
| 194 |  | Cryogenic System Requirements | 5d? | 2010-02-08 | 2010-02-15 | 190, 157 | 128.15d |
| 195 | 1.3.3.3.5 | **Electronics** | 11.25d? | 2009-11-27 | 2009-12-15 |  | 226.71d |
| 196 | 1.3.3.3.5.1 | **Motion Control** | 7.5d? | 2009-11-27 | 2009-12-09 |  | 226.71d |
| 197 |  | Requirements | 5d? | 2009-11-27 | 2009-12-04 | 167, 171, 183 | 226.71d |
| 198 |  | Initial Design | 2.5d? | 2009-12-04 | 2009-12-09 | 197 | 226.71d |
| 199 |  | Power Control | 1.25d? | 2009-12-09 | 2009-12-10 | 198 | 226.71d |
| 200 |  | Pressure Monitoring | 1.25d? | 2009-12-10 | 2009-12-11 | 199 | 226.71d |
| 201 |  | Temperature Monitoring and Control | 1.25d? | 2009-12-11 | 2009-12-15 | 200 | 257.11d |
| 202 | 1.3.3.3.6 | **Software** | 179.75d? | 2009-08-20 | 2010-04-29 |  | 128.15d |
| 203 |  | Detector Control | 3d? | 2009-12-02 | 2009-12-07 | 204, 205 | 179.15d |
| 204 |  | Global Server | 3d? | 2009-08-20 | 2009-08-25 | 71 | 247.35d |
| 205 |  | Motion Control | 2.5d? | 2009-11-27 | 2009-12-02 | 167, 171, 183, 204 | 179.15d |
| 206 |  | Power Control | 1d? | 2009-12-07 | 2009-12-08 | 204, 203, 205 | 179.15d |
| 207 |  | Pressure Monitoring | 1d? | 2010-02-17 | 2010-02-18 | 193, 206 | 128.15d |
| 208 |  | Temperature Monitoring and Control | 2.5d? | 2010-02-18 | 2010-02-22 | 157, 207 | 128.15d |
| 209 |  | User Interface Requirements | 3.33d? | 2010-02-22 | 2010-02-26 | 208 | 128.15d |
| 210 |  | Data Reduction Tools | 5d? | 2010-04-12 | 2010-04-29 | 72 | 128.15d |

| ID | WBS | Task | Duration | Start | Finish | Predecessors | Total float |
| --- | --- | --- | --- | --- | --- | --- | --- |
| 211 | 1.3.3.3.7 | **Interfaces** | 66.03d? | 2009-12-15 | 2010-03-17 |  | 204.02d |
| 212 |  | Mechanical Interface Requirements | 2.5d? | 2010-01-15 | 2010-01-19 | 157 | 234.31d |
| 213 |  | Electronic Interface Requirements | 2.5d? | 2009-12-15 | 2009-12-17 | 201 | 257.11d |
| 214 |  | Software Interface Requirements | 2.5d? | 2010-02-26 | 2010-03-02 | 209 | 204.02d |
| 215 |  | Interface Control Document | 3.06d? | 2010-03-02 | 2010-03-17 | 212, 213, 214 | 204.02d |
| 216 | 1.3.3.3.8 | **Accessories** | 13d? | 2010-01-15 | 2010-02-02 |  | 196.15d |
| 217 | 1.3.3.3.8.1 | **Alignment Tooling** | 6.5d? | 2010-01-25 | 2010-02-02 |  | 234.25d |
| 218 |  | Initial Specifications | 1.5d? | 2010-01-25 | 2010-01-26 | 157, 222 | 234.25d |
| 219 |  | Mechanical Model | 5d? | 2010-01-27 | 2010-02-02 | 218 | 234.25d |
| 220 | 1.3.3.3.8.2 | **Assembly Tooling** | 6.5d? | 2010-01-15 | 2010-01-25 |  | 196.15d |
| 221 |  | Initial Specifications | 1.5d? | 2010-01-15 | 2010-01-18 | 157 | 196.15d |
| 222 |  | Mechanical Model | 5d? | 2010-01-18 | 2010-01-25 | 221 | 196.15d |

## Version 2 (saved 2009-08-27, file Imager_and_IFS_PD_Phase_v1_2_tracked_July09.mpp)

Last finish 2010-12-28 → 2011-02-04 (+38d). Complete tasks 0 → 6.

Removed: 42 Project Meetings 16; 43 Project Meetings 17; 44 Project Meetings 18

Changed:

| ID | Task | Start | Finish | Duration | Complete | Total float | Predecessors | Other |
| --- | --- | --- | --- | --- | --- | --- | --- | --- |
| 1 | **Milestones** |  | 2010-06-30 → 2010-06-16 (-14d) | 303.1d? → 293.76d? |  | 0d → 166.65d |  |  |
| 3 | Imager Preliminary Design Review | 2010-06-30 → 2010-06-16 (-14d) | 2010-06-30 → 2010-06-16 (-14d) |  |  | 129.15d → 166.65d |  |  |
| 4 | IFS System Design Review | 2010-02-24 → 2010-04-05 (+40d) | 2010-02-24 → 2010-04-05 (+40d) |  |  |  |  |  |
| 5 | **Near-IR Imager and IFS** | 2009-05-01 A → 2009-06-04 A (+34d) | 2010-12-28 → 2011-02-04 (+38d) | 432.25d? → 436.41d? | 2% → 3% |  |  |  |
| 6 | **Management** | 2009-06-02 → 2009-06-04 A (+2d) |  | 379.5d? → 377.5d? | 0% → 4% | 30.75d → 58.91d |  |  |
| 7 | **Monthly Reports** | 2009-06-05 A |  |  | 0% → 17% | 36.25d → 64.41d |  |  |
| 8 | Monthly Reports 1 | 2009-06-05 A | 2009-06-05 A |  | 0% → 100% | 406.25d → none |  |  |
| 9 | Monthly Reports 2 | 2009-07-06 A | 2009-07-06 A |  | 0% → 100% | 385.25d → none |  |  |
| 10 | Monthly Reports 3 | 2009-08-05 A | 2009-08-05 A |  | 0% → 100% | 363.25d → none |  |  |
| 26 | **Project Meetings** | 2009-06-15 → 2009-09-15 (+92d) |  | 370.5d → 304.5d |  | 30.75d → 58.91d |  |  |
| 27 | Project Meetings 1 | 2009-06-15 → 2009-09-15 (+92d) | 2009-06-15 → 2009-09-15 (+92d) |  |  | 400.75d → 362.91d |  | constraint start no earlier than 2009-06-15 → start no earlier than 2009-09-15; resources Sean Adkins [80%]; Instrument Scientist [70%]; OE - Optical Engineer 2 [90%]; ME - Jim Bell [90%]; ME - John Canfield [90%]; Software Engineer [90%]; WMKO Support Astronomer; WMKO Electronics Staff → Sean Adkins [80%]; Instrument Scientist [70%]; OE - Optical Engineer 2 [90%]; ME - Jim Bell [90%]; ME - TBD [90%]; Software Engineer [90%]; WMKO Support Astronomer; WMKO Electronics Staff |
| 28 | Project Meetings 2 | 2009-07-15 → 2009-10-15 (+92d) | 2009-07-15 → 2009-10-15 (+92d) |  |  | 378.75d → 340.91d |  | constraint start no earlier than 2009-07-15 → start no earlier than 2009-10-15; resources Sean Adkins [80%]; Instrument Scientist [70%]; ME - John Canfield [90%]; OE - Optical Engineer 2 [90%]; Software Engineer [90%]; WMKO Support Astronomer; WMKO Electronics Staff; ME - Jim Bell → Sean Adkins [80%]; Instrument Scientist [70%]; ME - TBD [90%]; OE - Optical Engineer 2 [90%]; Software Engineer [90%]; WMKO Support Astronomer; WMKO Electronics Staff; ME - Jim Bell |
| 29 | Project Meetings 3 | 2009-08-17 → 2009-11-16 (+91d) | 2009-08-17 → 2009-11-16 (+91d) |  |  | 355.75d → 318.91d |  | constraint start no earlier than 2009-08-15 → start no earlier than 2009-11-15; resources Sean Adkins [80%]; Instrument Scientist [70%]; ME - John Canfield [90%]; OE - Optical Engineer 2 [90%]; Software Engineer [90%]; WMKO Support Astronomer; WMKO Electronics Staff; ME - Jim Bell → Sean Adkins [80%]; Instrument Scientist [70%]; ME - TBD [90%]; OE - Optical Engineer 2 [90%]; Software Engineer [90%]; WMKO Support Astronomer; WMKO Electronics Staff; ME - Jim Bell |
| 30 | Project Meetings 4 | 2009-09-15 → 2009-12-15 (+91d) | 2009-09-15 → 2010-01-04 (+111d) | 4h → 116h |  | 334.75d → 283.91d |  | constraint start no earlier than 2009-09-15 → start no earlier than 2009-12-15; resources Sean Adkins [80%]; Instrument Scientist [70%]; ME - John Canfield [90%]; OE - Optical Engineer 2 [90%]; Software Engineer [90%]; WMKO Support Astronomer; WMKO Electronics Staff; ME - Jim Bell → Sean Adkins [80%]; Instrument Scientist [70%]; ME - TBD [90%]; OE - Optical Engineer 2 [90%]; Software Engineer [90%]; WMKO Support Astronomer; WMKO Electronics Staff; ME - Jim Bell |
| 31 | Project Meetings 5 | 2009-10-15 → 2010-01-15 (+92d) | 2009-10-15 → 2010-01-15 (+92d) |  |  | 312.75d → 274.91d |  | constraint start no earlier than 2009-10-15 → start no earlier than 2010-01-15; resources Sean Adkins [80%]; Instrument Scientist [70%]; ME - John Canfield [90%]; OE - Optical Engineer 2 [90%]; Software Engineer [90%]; WMKO Support Astronomer; WMKO Electronics Staff; ME - Jim Bell → Sean Adkins [80%]; Instrument Scientist [70%]; ME - TBD [90%]; OE - Optical Engineer 2 [90%]; Software Engineer [90%]; WMKO Support Astronomer; WMKO Electronics Staff; ME - Jim Bell |
| 32 | Project Meetings 6 | 2009-11-16 → 2010-02-15 (+91d) | 2009-11-16 → 2010-02-15 (+91d) |  |  | 290.75d → 253.91d |  | constraint start no earlier than 2009-11-15 → start no earlier than 2010-02-15; resources Sean Adkins [80%]; Instrument Scientist [70%]; ME - John Canfield [90%]; OE - Optical Engineer 2 [90%]; Software Engineer [90%]; WMKO Support Astronomer; WMKO Electronics Staff; ME - Jim Bell → Sean Adkins [80%]; Instrument Scientist [70%]; ME - TBD [90%]; OE - Optical Engineer 2 [90%]; Software Engineer [90%]; WMKO Support Astronomer; WMKO Electronics Staff; ME - Jim Bell |
| 33 | Project Meetings 7 | 2009-12-15 → 2010-03-15 (+90d) | 2009-12-15 → 2010-03-15 (+90d) |  |  | 269.75d → 233.91d |  | constraint start no earlier than 2009-12-15 → start no earlier than 2010-03-15; resources Sean Adkins [80%]; Instrument Scientist [70%]; ME - John Canfield [90%]; OE - Optical Engineer 2 [90%]; Software Engineer [90%]; WMKO Support Astronomer; WMKO Electronics Staff; ME - Jim Bell → Sean Adkins [80%]; Instrument Scientist [70%]; ME - TBD [90%]; OE - Optical Engineer 2 [90%]; Software Engineer [90%]; WMKO Support Astronomer; WMKO Electronics Staff; ME - Jim Bell |
| 34 | Project Meetings 8 | 2010-01-15 → 2010-04-15 (+90d) | 2010-01-15 → 2010-04-15 (+90d) |  |  | 246.75d → 210.91d |  | constraint start no earlier than 2010-01-15 → start no earlier than 2010-04-15; resources Sean Adkins [80%]; Instrument Scientist [70%]; ME - Jim Bell [90%]; ME - John Canfield [90%]; OE - Optical Engineer 2 [90%]; Software Engineer [90%]; WMKO Support Astronomer; WMKO Electronics Staff → Sean Adkins [80%]; Instrument Scientist [70%]; ME - Jim Bell [90%]; ME - TBD [90%]; OE - Optical Engineer 2 [90%]; Software Engineer [90%]; WMKO Support Astronomer; WMKO Electronics Staff |
| 35 | Project Meetings 9 | 2010-02-15 → 2010-05-17 (+91d) | 2010-02-15 → 2010-05-17 (+91d) |  |  | 225.75d → 188.91d |  | constraint start no earlier than 2010-02-15 → start no earlier than 2010-05-15; resources Sean Adkins [80%]; Instrument Scientist [70%]; ME - Jim Bell [90%]; ME - John Canfield [90%]; OE - Optical Engineer 2 [90%]; Software Engineer [90%]; WMKO Support Astronomer; WMKO Electronics Staff → Sean Adkins [80%]; Instrument Scientist [70%]; ME - Jim Bell [90%]; ME - TBD [90%]; OE - Optical Engineer 2 [90%]; Software Engineer [90%]; WMKO Support Astronomer; WMKO Electronics Staff |
| 36 | Project Meetings 10 | 2010-03-15 → 2010-06-15 (+92d) | 2010-03-15 → 2010-06-15 (+92d) |  |  | 205.75d → 167.91d |  | constraint start no earlier than 2010-03-15 → start no earlier than 2010-06-15; resources Sean Adkins [80%]; Instrument Scientist [70%]; ME - Jim Bell [90%]; ME - John Canfield [90%]; OE - Optical Engineer 2 [90%]; Software Engineer [90%]; WMKO Support Astronomer; WMKO Electronics Staff → Sean Adkins [80%]; Instrument Scientist [70%]; ME - Jim Bell [90%]; ME - TBD [90%]; OE - Optical Engineer 2 [90%]; Software Engineer [90%]; WMKO Support Astronomer; WMKO Electronics Staff |
| 37 | Project Meetings 11 | 2010-04-15 → 2010-07-15 (+91d) | 2010-04-15 → 2010-07-15 (+91d) |  |  | 182.75d → 145.91d |  | constraint start no earlier than 2010-04-15 → start no earlier than 2010-07-15; resources Sean Adkins [80%]; Instrument Scientist [70%]; ME - Jim Bell [90%]; ME - John Canfield [90%]; OE - Optical Engineer 2 [90%]; Software Engineer [90%]; WMKO Support Astronomer; WMKO Electronics Staff → Sean Adkins [80%]; Instrument Scientist [70%]; ME - Jim Bell [90%]; ME - TBD [90%]; OE - Optical Engineer 2 [90%]; Software Engineer [90%]; WMKO Support Astronomer; WMKO Electronics Staff |
| 38 | Project Meetings 12 | 2010-05-17 → 2010-08-16 (+91d) | 2010-05-17 → 2010-08-16 (+91d) |  |  | 160.75d → 123.91d |  | constraint start no earlier than 2010-05-15 → start no earlier than 2010-08-15; resources Sean Adkins [80%]; Instrument Scientist [70%]; ME - Jim Bell [90%]; ME - John Canfield [90%]; OE - Optical Engineer 2 [90%]; Software Engineer [90%]; WMKO Support Astronomer; WMKO Electronics Staff → Sean Adkins [80%]; Instrument Scientist [70%]; ME - Jim Bell [90%]; ME - TBD [90%]; OE - Optical Engineer 2 [90%]; Software Engineer [90%]; WMKO Support Astronomer; WMKO Electronics Staff |
| 39 | Project Meetings 13 | 2010-06-15 → 2010-09-15 (+92d) | 2010-06-15 → 2010-09-15 (+92d) |  |  | 139.75d → 101.91d |  | constraint start no earlier than 2010-06-15 → start no earlier than 2010-09-15; resources Sean Adkins [80%]; Instrument Scientist [70%]; ME - Jim Bell [90%]; ME - John Canfield [90%]; OE - Optical Engineer 2 [90%]; Software Engineer [90%]; WMKO Support Astronomer; WMKO Electronics Staff → Sean Adkins [80%]; Instrument Scientist [70%]; ME - Jim Bell [90%]; ME - TBD [90%]; OE - Optical Engineer 2 [90%]; Software Engineer [90%]; WMKO Support Astronomer; WMKO Electronics Staff |
| 40 | Project Meetings 14 | 2010-07-15 → 2010-10-15 (+92d) | 2010-07-15 → 2010-10-15 (+92d) |  |  | 117.75d → 79.91d |  | constraint start no earlier than 2010-07-15 → start no earlier than 2010-10-15; resources Sean Adkins [80%]; Instrument Scientist [70%]; ME - Jim Bell [90%]; ME - John Canfield [90%]; OE - Optical Engineer 2 [90%]; Software Engineer [90%]; WMKO Support Astronomer; WMKO Electronics Staff → Sean Adkins [80%]; Instrument Scientist [70%]; ME - Jim Bell [90%]; ME - TBD [90%]; OE - Optical Engineer 2 [90%]; Software Engineer [90%]; WMKO Support Astronomer; WMKO Electronics Staff |
| 41 | Project Meetings 15 | 2010-08-16 → 2010-11-15 (+91d) | 2010-08-16 → 2010-11-15 (+91d) |  |  | 95.75d → 58.91d |  | constraint start no earlier than 2010-08-15 → start no earlier than 2010-11-15; resources Sean Adkins [80%]; Instrument Scientist [70%]; ME - Jim Bell [90%]; ME - John Canfield [90%]; OE - Optical Engineer 2 [90%]; Software Engineer [90%]; WMKO Support Astronomer; WMKO Electronics Staff → Sean Adkins [80%]; Instrument Scientist [70%]; ME - Jim Bell [90%]; ME - TBD [90%]; OE - Optical Engineer 2 [90%]; Software Engineer [90%]; WMKO Support Astronomer; WMKO Electronics Staff |
| 42 | System Engineering Management Plan | 2009-06-02 → 2010-02-15 (+258d) | 2009-06-22 → 2010-03-03 (+254d) |  |  | 395.69d → 241.84d | 2FS+20d → none | constraint none → start no earlier than 2010-02-14 |
| 43 | Proposals to Fund Future Phases (ATI, MRI would be early 2010) | 2009-09-02 → 2010-05-03 (+243d) | 2009-10-30 → 2010-06-30 (+243d) |  |  | 301.25d → 156.41d |  | constraint start no earlier than 2009-09-02 → start no earlier than 2010-05-02 |
| 44 | Cost Review | 2010-02-18 → 2010-03-12 (+22d) | 2010-04-05 → 2010-04-27 (+22d) |  |  | 190.54d → 202.79d |  |  |
| 45 | **Project Plan Maintenance** | 2009-06-04 A |  |  | 0% → 33% | 80.25d → 108.41d |  |  |
| 46 | Project Plan Maintenance 1 | 2009-06-04 A | 2009-06-04 A |  | 0% → 100% | 377.18d → none |  |  |
| 47 | Project Plan Maintenance 2 | 2009-09-04 A | 2009-09-04 A |  | 0% → 100% | 311.18d → none |  |  |
| 52 | **Budget Maintenance** | 2009-06-04 A |  |  | 0% → 11% | 60.25d → 88.41d |  |  |
| 53 | Budget Maintenance 1 | 2009-06-04 A | 2009-06-04 A |  | 0% → 100% | 377.18d → none |  |  |
| 62 | Preliminary Design Review | 2010-04-29 → 2010-04-16 (-13d) | 2010-07-01 → 2010-06-17 (-14d) |  |  | 128.15d → 165.65d | 69, 197, 207, 219, 153 → 69, 197, 219, 153FS-2w | resources Sean Adkins; Instrument Scientist; ME - Jim Bell; ME - John Canfield; Software Engineer; Electronics Engineer; WMKO Support Astronomer; WMKO Software Staff; WMKO Instrument Staff; WMKO Electronics Staff; OE - Optical Engineer 2 → Sean Adkins; Instrument Scientist; ME - Jim Bell; ME - TBD; Software Engineer; Electronics Engineer; WMKO Support Astronomer; WMKO Software Staff; WMKO Instrument Staff; WMKO Electronics Staff; OE - Optical Engineer 2 |
| 63 | **Science** | 2009-06-26 → 2009-09-18 (+84d) | 2010-04-12 → 2010-04-16 (+4d) | 206.76d? → 150.16d? |  | 185.5d → 210.25d |  |  |
| 64 | **Science Team Meetings** | 2009-06-26 → 2009-09-18 (+84d) |  | 136.5d? → 76.5d? |  | 255.75d → 283.91d |  |  |
| 65 | Meeting 1 | 2009-06-26 → 2009-09-18 (+84d) | 2009-06-29 → 2009-09-21 (+84d) |  |  | 390.75d → 358.91d | 2FS+2mo → 2FS+5mo |  |
| 67 | **Common Observing Operations Concept Document** | 2009-07-24 → 2009-09-18 (+56d) | 2010-04-12 → 2010-04-16 (+4d) | 186.76d? → 150.16d? |  | 128.15d → 210.25d |  |  |
| 68 | Initial Draft | 2009-07-24 → 2009-09-18 (+56d) | 2009-08-20 → 2009-10-15 (+56d) |  |  | 247.35d → 340.66d | 2FS+3mo → 2FS+5mo |  |
| 69 | Final Version | 2010-02-26 → 2010-03-03 (+5d) | 2010-04-12 → 2010-04-16 (+4d) |  |  | 128.15d → 165.65d | 187, 206 → 187, 206FS-2w |  |
| 70 | **Instrument Design and Fabrication** | 2009-05-01 A → 2009-06-18 A (+48d) | 2010-12-28 → 2011-02-04 (+38d) | 432.25d? → 426.41d? | 2% → 4% |  |  |  |
| 71 | **AO System to Instrument Interface Definitions** | 2009-05-01 → 2009-09-14 (+136d) | 2009-06-17 → 2009-10-02 (+107d) | 34d? → 14d? |  | 0d → 350.4d |  |  |
| 72 | Optical | 2009-05-01 → 2009-09-14 (+136d) | 2009-06-02 → 2009-09-16 (+106d) |  |  | 0d → 350.4d | 2 → 80 |  |
| 73 | Mechanical | 2009-06-02 → 2009-09-16 (+106d) | 2009-06-09 → 2009-09-24 (+107d) |  |  | 0d → 350.4d |  |  |
| 74 | Electronic/Electrical | 2009-06-10 → 2009-09-24 (+106d) | 2009-06-11 → 2009-09-25 (+106d) |  |  | 0d → 350.4d |  |  |
| 75 | Software | 2009-06-11 → 2009-09-25 (+106d) | 2009-06-15 → 2009-09-30 (+107d) |  |  | 0d → 350.4d |  |  |
| 76 | Alignment and Calibration Concept for Instrument on AO System | 2009-06-16 → 2009-09-30 (+106d) | 2009-06-17 → 2009-10-02 (+107d) |  |  | 0d → 350.4d |  |  |
| 77 | **Shared Facilities** | 2009-05-01 A → 2009-06-18 A (+48d) | 2009-09-14 → 2009-12-04 (+81d) | 96.11d? → 121.49d? | 12% → 16% | 336.15d → 304.92d |  |  |
| 78 | **AO System** | 2009-05-01 A → 2009-06-18 A (+48d) | 2009-09-14 → 2009-12-04 (+81d) | 96.11d? → 121.49d? | 15% → 20% | 336.15d → 304.92d |  |  |
| 79 | **High Order AO Relay** |  | 2009-08-13 → 2009-10-07 (+55d) | 40.5d? → 79.5d? | 46% → 45% | 357.75d → 346.91d |  |  |
| 80 | Design Liason |  | 2009-07-21 → 2009-09-14 (+55d) | 20d? → 38.47d? | 75% → 60% | 336.06d → 304.92d | 76 → none | constraint none → start no earlier than 2009-06-18; resources Sean Adkins [20%] → Sean Adkins [16.1%] |
| 81 | RTC and Control Liason | 2009-07-28 → 2009-09-21 (+55d) | 2009-08-13 → 2009-10-07 (+55d) |  |  | 357.75d → 346.91d |  |  |
| 82 | **ADC** | 2009-07-27 → 2009-09-21 (+56d) | 2009-09-14 → 2009-11-06 (+53d) |  |  | 336.15d → 324.41d |  |  |
| 83 | Requirements Liason | 2009-07-27 → 2009-09-21 (+56d) | 2009-08-24 → 2009-10-16 (+53d) |  |  | 336.15d → 324.41d |  |  |
| 84 | Design Liason | 2009-08-24 → 2009-10-19 (+56d) | 2009-09-14 → 2009-11-06 (+53d) |  |  | 336.15d → 324.41d |  |  |
| 85 | **Calibration Faciltiy** | 2009-05-01 → 2009-10-23 (+175d) | 2009-07-09 → 2009-12-04 (+148d) | 50d? → 30d? |  | 352.77d → 304.92d |  |  |
| 86 | Requirements Liason | 2009-05-01 → 2009-10-23 (+175d) | 2009-06-11 → 2009-11-06 (+148d) | 15.5d? → 10d? |  | 352.77d → 304.92d | none → 90 |  |
| 87 | Design Liason | 2009-06-12 → 2009-11-06 (+147d) | 2009-07-09 → 2009-12-04 (+148d) |  |  | 352.77d → 304.92d |  |  |
| 88 | **Nasmyth Enclosure** | 2009-07-10 → 2009-09-14 (+66d) | 2009-08-20 → 2009-10-23 (+64d) |  |  | 352.77d → 304.92d |  |  |
| 89 | Requirements Liason | 2009-07-10 → 2009-09-14 (+66d) | 2009-08-03 → 2009-10-06 (+64d) |  |  | 352.77d → 304.92d | 87 → 80 |  |
| 90 | Design Liason | 2009-08-03 → 2009-10-06 (+64d) | 2009-08-20 → 2009-10-23 (+64d) |  |  | 352.77d → 304.92d |  |  |
| 91 | **Instrument** | 2009-05-01 A → 2009-06-30 A (+60d) | 2010-12-28 → 2011-02-04 (+38d) | 432.25d? → 418.41d? | 0% → 1% |  |  |  |
| 92 | **IFS System Design Phase** | 2009-06-01 → 2009-09-07 (+98d) | 2010-02-25 → 2010-04-06 (+40d) | 193.39d? → 151.54d? |  | 0.54d → 0d |  |  |
| 93 | **IFS Performance Budgets** | 2009-06-01 → 2009-09-07 (+98d) | 2009-08-18 → 2009-11-24 (+98d) |  |  | 0.54d → 0d |  |  |
| 94 | Throughput | 2009-06-01 → 2009-09-07 (+98d) | 2009-06-09 → 2009-09-15 (+98d) |  |  | 0.54d → 0d | 2FS+21d → 140 |  |
| 95 | Background | 2009-06-09 → 2009-09-15 (+98d) | 2009-06-25 → 2009-10-01 (+98d) |  |  | 0.54d → 0d |  |  |
| 96 | Wavefront error | 2009-06-25 → 2009-10-01 (+98d) | 2009-07-03 → 2009-10-09 (+98d) |  |  | 0.54d → 0d |  |  |
| 97 | Spectroscopic performance | 2009-07-03 → 2009-10-09 (+98d) | 2009-08-11 → 2009-11-17 (+98d) |  |  | 0.54d → 0d |  |  |
| 98 | Size and mass | 2009-08-11 → 2009-11-17 (+98d) | 2009-08-18 → 2009-11-24 (+98d) |  |  | 354.91d → 313.06d |  |  |
| 99 | **Trade Studies** | 2009-08-11 → 2009-11-17 (+98d) | 2010-01-06 → 2010-03-29 (+82d) | 106.33d → 93.95d |  | 253.79d → 224.32d |  |  |

| ID | Task | Start | Finish | Duration | Complete | Total float | Predecessors | Other |
| --- | --- | --- | --- | --- | --- | --- | --- | --- |
| 100 | FOV and spatial sampling | 2009-08-11 → 2009-11-17 (+98d) | 2009-09-10 → 2009-12-17 (+98d) |  |  | 266.17d → 224.32d |  |  |
| 101 | Wavelength coverage and spatial sampling | 2009-09-10 → 2009-12-17 (+98d) | 2009-10-13 → 2010-01-19 (+98d) | 13.19d → 15.39d |  | 266.17d → 224.32d |  |  |
| 102 | Optimization of image slicing formats and spectrograph formats | 2009-10-13 → 2010-01-19 (+98d) | 2009-11-20 → 2010-02-26 (+98d) |  |  | 266.17d → 224.32d |  | resources Sean Adkins [33.3%]; Instrument Scientist [50%]; OE - Sergey Panteleev [33%]; ME - John Canfield [50%] → Sean Adkins [33.3%]; Instrument Scientist [50%]; OE - Sergey Panteleev [33%]; ME - TBD [50%] |
| 103 | Separate or combined capability above and below 1 micron | 2009-11-20 → 2010-02-26 (+98d) | 2009-12-03 → 2010-03-11 (+98d) |  |  | 266.17d → 224.32d |  |  |
| 104 | Wavefront error allocations | 2009-12-03 → 2010-03-11 (+98d) | 2009-12-14 → 2010-03-22 (+98d) |  |  | 266.17d → 224.32d |  |  |
| 105 | Trade study report | 2009-12-14 → 2010-03-22 (+98d) | 2010-01-06 → 2010-03-29 (+82d) | 6.68d → 4.21d |  | 253.79d → 224.32d |  |  |
| 106 | **Conceptual Designs** | 2009-09-22 → 2009-11-17 (+56d) | 2010-02-17 → 2010-03-29 (+40d) | 106.64d? → 94.79d? |  | 0.54d → 0d |  |  |
| 107 | Development of design options | 2009-09-22 → 2009-11-17 (+56d) | 2009-11-25 → 2010-01-20 (+56d) |  |  | 0.54d → 0d | 97FS+6w → 97 | resources Sean Adkins [50%]; Instrument Scientist [50%]; OE - Sergey Panteleev [17%]; ME - John Canfield [50%] → Sean Adkins [50%]; Instrument Scientist [50%]; OE - Sergey Panteleev [17%]; ME - TBD [50%] |
| 108 | Evaluation of design options | 2009-11-25 → 2010-01-20 (+56d) | 2009-12-09 → 2010-02-03 (+56d) |  |  | 0.54d → 0d |  | resources Sean Adkins [50%]; Instrument Scientist [50%]; OE - Sergey Panteleev [50%]; ME - John Canfield [50%] → Sean Adkins [50%]; Instrument Scientist [50%]; OE - Sergey Panteleev [50%]; ME - TBD [50%] |
| 109 | Calibration and alignment issues | 2009-12-09 → 2010-02-03 (+56d) | 2009-12-17 → 2010-02-11 (+56d) |  |  | 0.54d → 0d |  | resources Sean Adkins [50%]; Instrument Scientist [50%]; OE - Sergey Panteleev [50%]; ME - John Canfield [50%] → Sean Adkins [50%]; Instrument Scientist [50%]; OE - Sergey Panteleev [50%]; ME - TBD [50%] |
| 110 | Downselect of conceptual design | 2009-12-17 → 2010-02-11 (+56d) | 2010-01-08 → 2010-02-18 (+41d) | 10d? → 5d? |  |  |  | resources Sean Adkins [50%]; Instrument Scientist [50%]; OE - Sergey Panteleev [50%]; ME - John Canfield [50%] → Sean Adkins [50%]; Instrument Scientist [50%]; OE - Sergey Panteleev [50%]; ME - TBD [50%] |
| 111 | Revised performance budgets | 2010-01-11 → 2010-02-18 (+38d) | 2010-01-14 → 2010-02-24 (+41d) |  |  |  |  |  |
| 112 | Performance budget report | 2010-01-15 → 2010-02-24 (+40d) | 2010-01-20 → 2010-03-01 (+40d) |  |  |  |  |  |
| 113 | Performance estimates | 2010-01-11 → 2010-02-18 (+38d) | 2010-01-22 → 2010-03-03 (+40d) |  |  |  |  | resources Sean Adkins [50%]; Instrument Scientist [50%]; OE - Sergey Panteleev [50%]; ME - John Canfield [50%] → Sean Adkins [50%]; Instrument Scientist [50%]; OE - Sergey Panteleev [50%]; ME - TBD [50%] |
| 114 | System requirements document | 2010-01-22 → 2010-03-03 (+40d) | 2010-01-28 → 2010-03-09 (+40d) |  |  |  |  | resources Sean Adkins [50%]; Instrument Scientist [50%]; OE - Sergey Panteleev [50%]; ME - John Canfield [50%] → Sean Adkins [50%]; Instrument Scientist [50%]; OE - Sergey Panteleev [50%]; ME - TBD [50%] |
| 115 | System design manual | 2010-01-28 → 2010-03-09 (+40d) | 2010-02-17 → 2010-03-29 (+40d) |  |  |  |  | resources Sean Adkins [75%]; Instrument Scientist [75%]; OE - Sergey Panteleev [75%]; ME - John Canfield [75%] → Sean Adkins [75%]; Instrument Scientist [75%]; OE - Sergey Panteleev [75%]; ME - TBD [75%] |
| 116 | **System Design Review** | 2010-02-17 → 2010-03-29 (+40d) | 2010-02-25 → 2010-04-06 (+40d) |  |  |  |  |  |
| 117 | System design report | 2010-02-17 → 2010-03-29 (+40d) | 2010-02-24 → 2010-04-05 (+40d) |  |  |  |  | resources Sean Adkins [50%]; Instrument Scientist [50%]; OE - Sergey Panteleev [50%]; ME - John Canfield [50%] → Sean Adkins [50%]; Instrument Scientist [50%]; OE - Sergey Panteleev [50%]; ME - TBD [50%] |
| 118 | System design review meeting | 2010-02-24 → 2010-04-05 (+40d) | 2010-02-25 → 2010-04-06 (+40d) |  |  |  |  | resources Sean Adkins [80%]; Instrument Scientist [80%]; OE - Sergey Panteleev [90%]; ME - John Canfield [90%] → Sean Adkins [80%]; Instrument Scientist [80%]; OE - Sergey Panteleev [90%]; ME - TBD [90%] |
| 119 | **IFS Preliminary Design Phase** | 2010-02-25 → 2010-04-06 (+40d) | 2010-12-28 → 2011-02-04 (+38d) |  |  |  |  |  |
| 120 | Initial AO system to instrument interface definitions | 2010-02-25 → 2010-04-06 (+40d) | 2010-03-08 → 2010-04-15 (+38d) |  |  |  |  |  |
| 121 | Alignment and calibration concept | 2010-03-08 → 2010-04-15 (+38d) | 2010-03-18 → 2010-04-27 (+40d) |  |  |  |  |  |
| 122 | Optical design | 2010-03-18 → 2010-04-27 (+40d) | 2010-07-26 → 2010-09-02 (+38d) |  |  |  |  |  |
| 123 | Mechanical design | 2010-05-03 → 2010-06-10 (+38d) | 2010-12-14 → 2011-01-21 (+38d) |  |  |  |  |  |
| 124 | Electronic design | 2010-10-18 → 2010-11-25 (+38d) | 2010-11-29 → 2011-01-06 (+38d) |  |  |  |  |  |
| 125 | Software design | 2010-10-18 → 2010-11-25 (+38d) | 2010-11-18 → 2010-12-28 (+40d) |  |  |  |  |  |
| 126 | Preliminary design report | 2010-12-14 → 2011-01-21 (+38d) | 2010-12-24 → 2011-02-03 (+41d) |  |  |  |  |  |
| 127 | Preliminary design review meeting | 2010-12-24 → 2011-02-03 (+41d) | 2010-12-28 → 2011-02-04 (+38d) |  |  |  |  |  |
| 128 | **Near-IR Imager and IFS Preliminary Design** | 2009-05-01 A → 2009-06-30 A (+60d) | 2010-04-29 → 2010-04-20 (-9d) | 259.5d? → 210.9d? | 1% → 4% | 172.75d → 207.5d |  |  |
| 129 | **Imager Trade Studies** | 2009-06-02 A → 2009-06-30 A (+28d) | 2009-07-27 → 2009-10-02 (+67d) | 39.4d? → 68.5d? |  | 0d → 349.91d |  |  |
| 130 | Imager Wavefront Error | 2009-06-02 → 2009-09-07 (+97d) | 2009-06-30 → 2009-10-02 (+94d) |  |  | 0d → 337.91d | 72 → 140 |  |
| 131 | Imager Pixel Scale |  | 2009-07-23 → 2009-09-15 (+54d) |  |  | 0d → 362.77d | 130 → none | constraint none → start no earlier than 2009-06-30 |
| 132 | Imager Short Wavelength Cut-off | 2009-07-23 → 2009-09-07 (+46d) | 2009-07-27 → 2009-09-09 (+44d) |  |  | 0d → 353.34d | 131 → 140 |  |
| 133 | **Imager Performance Budgets** | 2009-05-01 A → 2009-07-28 A (+88d) | 2009-08-14 → 2010-03-19 (+217d) | 76d? → 168.15d? |  | 356.25d → 230.25d |  |  |
| 134 | Imager Sensitivity |  | 2009-07-28 → 2009-09-10 (+44d) |  |  | 356.25d → 353.14d |  |  |
| 135 | Imager Background | 2009-07-29 → 2009-09-10 (+43d) | 2009-08-04 → 2009-09-16 (+43d) |  |  | 356.25d → 353.14d |  |  |
| 136 | Imager Companion Sensitivity | 2009-08-04 → 2009-09-16 (+43d) | 2009-08-14 → 2009-09-29 (+46d) |  |  | 356.25d → 353.14d |  |  |
| 137 | Imager Wavefront Error | 2009-06-30 → 2009-10-02 (+94d) | 2009-07-16 → 2009-10-20 (+96d) |  |  | 128.15d → 337.91d |  |  |
| 138 | Imager Size and Mass | 2009-05-01 → 2010-03-12 (+315d) | 2009-05-18 → 2010-03-19 (+305d) | 5.2d? → 4.8d? |  | 420.85d → 230.25d | none → 153 |  |
| 139 | **Optical Design** | 2009-07-16 → 2009-07-28 A (+12d) | 2009-09-17 → 2009-11-23 (+67d) | 45.65d? → 84.65d? | 0% → 17% | 128.15d → 313.75d |  |  |
| 140 | Initial Optical Design | 2009-07-28 A | 2009-08-05 → 2009-09-04 (+30d) | 6.25d? → 18.1d? | 0% → 50% | 364d → 0d | 132 → none | resources Sean Adkins [80%]; OE - Optical Engineer 2 [90%] → Sean Adkins [31.1%]; OE - Optical Engineer 2 [90%] |
| 141 | **Optical Modeling** | 2009-07-16 → 2009-09-21 (+67d) | 2009-09-10 → 2009-11-16 (+67d) |  |  | 128.15d → 165.65d |  |  |
| 142 | Fore Optics | 2009-07-16 → 2009-09-21 (+67d) | 2009-07-28 → 2009-10-01 (+65d) |  |  | 128.15d → 165.65d | 137 → 140FS+2w |  |
| 143 | Lyot Stop | 2009-07-29 → 2009-10-01 (+64d) | 2009-07-30 → 2009-10-05 (+67d) |  |  | 128.15d → 165.65d |  |  |
| 144 | Coronagraph | 2009-07-31 → 2009-10-05 (+66d) | 2009-08-12 → 2009-10-16 (+65d) |  |  | 128.15d → 165.65d |  |  |
| 145 | Imager Camera | 2009-08-12 → 2009-10-16 (+65d) | 2009-09-09 → 2009-11-13 (+65d) |  |  | 128.15d → 165.65d |  |  |
| 146 | IFS Fold Mirror | 2009-09-09 → 2009-11-13 (+65d) | 2009-09-10 → 2009-11-16 (+67d) |  |  | 332.5d → 313.75d |  |  |
| 147 | Preliminary Design Performance Analysis | 2009-09-10 → 2009-11-16 (+67d) | 2009-09-17 → 2009-11-23 (+67d) |  |  | 332.5d → 313.75d |  |  |
| 148 | **Dewar** | 2009-07-29 → 2009-10-01 (+64d) | 2010-02-19 → 2010-03-22 (+31d) | 147.95d? → 121.95d? |  | 158.65d → 196.15d |  |  |
| 149 | **Cold Assemblies** | 2009-07-29 → 2009-10-01 (+64d) | 2010-02-18 → 2010-03-12 (+22d) | 146.45d? → 115.45d? |  | 158.65d → 196.15d |  |  |
| 150 | **Dewar Internal Structure** | 2009-12-10 → 2010-02-15 (+67d) | 2010-02-18 → 2010-03-12 (+22d) | 49.5d? → 18.5d? |  | 128.15d → 165.65d |  |  |
| 151 | Interface Specification | 2009-12-10 → 2010-02-15 (+67d) | 2009-12-11 → 2010-02-16 (+67d) |  |  | 128.15d → 165.65d |  |  |
| 152 | Mechanical Model | 2009-12-11 → 2010-02-16 (+67d) | 2009-12-25 → 2010-03-02 (+67d) |  |  | 128.15d → 165.65d |  |  |
| 153 | FEA | 2010-02-08 → 2010-03-02 (+22d) | 2010-02-18 → 2010-03-12 (+22d) |  |  | 178.21d → 200.45d |  |  |
| 154 | Thermal Analysis | 2009-12-25 → 2010-03-02 (+67d) | 2010-01-01 → 2010-03-09 (+67d) |  |  | 154.15d → 165.65d |  |  |
| 155 | **Fore Optics** | 2009-07-29 → 2009-10-01 (+64d) | 2010-01-01 → 2009-11-23 (-39d) | 112.95d? → 37d? |  | 234.6d → 241.93d |  |  |
| 156 | **Input Baffle & Coronagraph** | 2009-08-12 → 2009-10-16 (+65d) | 2010-01-01 → 2009-11-23 (-39d) | 102.45d? → 26.5d? |  | 128.15d → 211.43d |  |  |
| 157 | Interface Specification | 2009-08-12 → 2009-10-16 (+65d) | 2009-08-13 → 2009-10-19 (+67d) |  |  | 224.1d → 231.43d |  |  |
| 158 | Mechanical Model | 2009-12-25 → 2009-11-16 (-39d) | 2010-01-01 → 2009-11-23 (-39d) |  |  | 128.15d → 211.43d | 157, 152 → 157, 172 |  |
| 159 | **Re-imager** | 2009-07-29 → 2009-10-01 (+64d) | 2009-08-06 → 2009-10-12 (+67d) |  |  | 362.75d → 344d |  |  |
| 160 | Interface Specification | 2009-07-29 → 2009-10-01 (+64d) | 2009-07-30 → 2009-10-05 (+67d) |  |  | 362.75d → 344d |  |  |
| 161 | Mechanical Model | 2009-07-30 → 2009-10-05 (+67d) | 2009-08-06 → 2009-10-12 (+67d) |  |  | 362.75d → 344d |  |  |
| 162 | **Adjustable Lyot Stop** | 2009-07-31 → 2009-10-05 (+66d) | 2009-08-12 → 2009-10-16 (+65d) |  |  | 256.1d → 263.1d |  |  |
| 163 | Interface Specification | 2009-07-31 → 2009-10-05 (+66d) | 2009-08-03 → 2009-10-07 (+65d) |  |  | 256.1d → 263.1d |  |  |
| 164 | Mechanical Model | 2009-08-03 → 2009-10-07 (+65d) | 2009-08-12 → 2009-10-16 (+65d) |  |  | 256.1d → 263.1d |  |  |
| 165 | **Filter Wheels** | 2009-09-09 → 2009-11-13 (+65d) | 2009-10-07 → 2009-12-11 (+65d) |  |  | 216.84d → 223.83d |  |  |
| 166 | **Mechanism** | 2009-09-09 → 2009-11-13 (+65d) | 2009-10-07 → 2009-12-11 (+65d) |  |  | 216.84d → 223.83d |  |  |
| 167 | Interface Specification | 2009-09-09 → 2009-11-13 (+65d) | 2009-09-11 → 2009-11-17 (+67d) |  |  | 216.84d → 223.83d |  |  |
| 168 | Mechanical Model | 2009-09-14 → 2009-11-18 (+65d) | 2009-10-07 → 2009-12-11 (+65d) |  |  | 216.84d → 223.83d |  |  |
| 169 | Filter Specifications | 2009-09-11 → 2009-11-17 (+67d) | 2009-09-14 → 2009-11-18 (+65d) |  |  | 216.84d → 223.83d |  |  |

| ID | Task | Start | Finish | Duration | Total float | Predecessors | Other |
| --- | --- | --- | --- | --- | --- | --- | --- |
| 170 | **Imager** | 2009-09-09 → 2009-11-13 (+65d) | 2009-12-03 → 2010-02-08 (+67d) |  | 128.15d → 165.65d |  |  |
| 171 | **Camera** | 2009-09-09 → 2009-11-13 (+65d) | 2009-09-22 → 2009-11-26 (+65d) |  | 128.15d → 165.65d |  |  |
| 172 | Interface Specification | 2009-09-09 → 2009-11-13 (+65d) | 2009-09-10 → 2009-11-16 (+67d) |  | 128.15d → 165.65d |  |  |
| 173 | Mechanical Model | 2009-09-11 → 2009-11-16 (+66d) | 2009-09-22 → 2009-11-26 (+65d) |  | 128.15d → 165.65d |  |  |
| 174 | **Detector Head** | 2009-09-22 → 2009-11-26 (+65d) | 2009-12-03 → 2010-02-08 (+67d) |  | 128.15d → 165.65d |  |  |
| 175 | **Mount** | 2009-09-22 → 2009-11-26 (+65d) | 2009-09-30 → 2009-12-04 (+65d) |  | 128.15d → 165.65d |  |  |
| 176 | Interface Specification | 2009-09-22 → 2009-11-26 (+65d) | 2009-09-23 → 2009-11-27 (+65d) |  | 128.15d → 165.65d |  | resources ME - John Canfield → ME - TBD |
| 177 | Mechanical Model | 2009-09-23 → 2009-11-27 (+65d) | 2009-09-30 → 2009-12-04 (+65d) |  | 128.15d → 165.65d |  | resources ME - John Canfield → ME - TBD |
| 178 | **Focus Mechanism** | 2009-09-30 → 2009-12-04 (+65d) | 2009-11-27 → 2010-02-02 (+67d) |  | 128.15d → 165.65d |  |  |
| 179 | Interface Specification | 2009-09-30 → 2009-12-04 (+65d) | 2009-10-27 → 2009-12-31 (+65d) |  | 128.15d → 165.65d |  | resources ME - John Canfield → ME - TBD |
| 180 | Mechanical Model | 2009-10-27 → 2009-12-31 (+65d) | 2009-11-27 → 2010-02-02 (+67d) |  | 128.15d → 165.65d |  | resources ME - John Canfield → ME - TBD |
| 181 | **Cooling Interface** | 2009-11-27 → 2010-02-02 (+67d) | 2009-12-03 → 2010-02-08 (+67d) |  | 128.15d → 165.65d |  |  |
| 182 | Interface Specification | 2009-11-27 → 2010-02-02 (+67d) | 2009-11-30 → 2010-02-03 (+65d) |  | 128.15d → 165.65d |  | resources ME - John Canfield → ME - TBD |
| 183 | Mechanical Model | 2009-11-30 → 2010-02-03 (+65d) | 2009-12-03 → 2010-02-08 (+67d) |  | 128.15d → 165.65d |  | resources ME - John Canfield → ME - TBD |
| 184 | **Warm Assemblies** | 2010-01-01 → 2009-11-23 (-39d) | 2010-02-19 → 2010-03-22 (+31d) | 35d? → 84.95d? | 128.15d → 211.43d |  |  |
| 185 | **Dewar Shell** | 2010-01-01 → 2009-11-23 (-39d) | 2010-02-19 → 2010-03-22 (+31d) | 35d? → 84.95d? | 128.15d → 211.43d |  |  |
| 186 | Interface Specification | 2010-01-04 → 2009-11-24 (-41d) | 2010-01-07 → 2009-11-27 (-41d) |  | 128.15d → 211.43d |  |  |
| 187 | Mechanical Model | 2010-01-07 → 2009-11-27 (-41d) | 2010-02-08 → 2009-12-29 (-41d) |  | 128.15d → 211.43d |  |  |
| 188 | Window Specifications | 2010-01-01 → 2009-11-23 (-39d) | 2010-01-04 → 2009-11-24 (-41d) |  | 128.15d → 211.43d |  |  |
| 189 | External Connections | 2010-02-17 → 2010-03-18 (+29d) | 2010-02-19 → 2010-03-22 (+31d) |  | 221.31d → 228.55d |  |  |
| 190 | Vacuum System Requirements | 2010-02-15 → 2010-03-16 (+29d) | 2010-02-17 → 2010-03-18 (+29d) |  | 128.15d → 228.55d |  |  |
| 191 | Cryogenic System Requirements | 2010-02-08 → 2010-03-09 (+29d) | 2010-02-15 → 2010-03-16 (+29d) |  | 128.15d → 228.55d |  |  |
| 192 | **Electronics** | 2009-11-27 → 2010-02-02 (+67d) | 2009-12-15 → 2010-02-18 (+65d) |  | 226.71d → 207.95d |  |  |
| 193 | **Motion Control** | 2009-11-27 → 2010-02-02 (+67d) | 2009-12-09 → 2010-02-12 (+65d) |  | 226.71d → 207.95d |  |  |
| 194 | Requirements | 2009-11-27 → 2010-02-02 (+67d) | 2009-12-04 → 2010-02-09 (+67d) |  | 226.71d → 207.95d |  |  |
| 195 | Initial Design | 2009-12-04 → 2010-02-09 (+67d) | 2009-12-09 → 2010-02-12 (+65d) |  | 226.71d → 207.95d |  |  |
| 196 | Power Control | 2009-12-09 → 2010-02-12 (+65d) | 2009-12-10 → 2010-02-15 (+67d) |  | 226.71d → 207.95d |  |  |
| 197 | Pressure Monitoring | 2009-12-10 → 2010-02-15 (+67d) | 2009-12-11 → 2010-02-16 (+67d) |  | 226.71d → 207.95d |  |  |
| 198 | Temperature Monitoring and Control | 2009-12-11 → 2010-02-16 (+67d) | 2009-12-15 → 2010-02-18 (+65d) |  | 257.11d → 238.36d |  |  |
| 199 | **Software** | 2009-08-20 → 2010-02-02 (+166d) | 2010-04-29 → 2010-04-20 (-9d) | 179.75d? → 55.05d? | 128.15d → 186.15d |  |  |
| 200 | Detector Control | 2009-12-02 → 2010-03-12 (+100d) | 2009-12-07 → 2010-03-17 (+100d) |  | 179.15d → 229.05d | 201, 202 → 205 |  |
| 201 | Global Server | 2009-08-20 → 2010-03-17 (+209d) | 2009-08-25 → 2010-03-22 (+209d) |  | 247.35d → 229.05d | 68 → 200 |  |
| 202 | Motion Control | 2009-11-27 → 2010-02-02 (+67d) | 2009-12-02 → 2010-02-05 (+65d) |  | 179.15d → 186.15d | 164, 168, 180, 201 → 164, 168, 180 |  |
| 203 | Power Control | 2009-12-07 → 2010-02-05 (+60d) | 2009-12-08 → 2010-02-08 (+62d) |  | 179.15d → 186.15d | 201, 200, 202 → 202 |  |
| 204 | Pressure Monitoring | 2010-02-17 → 2010-02-08 (-9d) | 2010-02-18 → 2010-02-09 (-9d) |  | 128.15d → 186.15d | 190, 203 → 203 |  |
| 205 | Temperature Monitoring and Control | 2010-02-18 → 2010-03-09 (+19d) | 2010-02-22 → 2010-03-12 (+18d) |  | 128.15d → 165.65d |  |  |
| 206 | User Interface Requirements | 2010-02-22 → 2010-03-12 (+18d) | 2010-02-26 → 2010-03-17 (+19d) |  | 128.15d → 165.65d |  |  |
| 207 | Data Reduction Tools | 2010-04-12 → 2010-04-02 (-10d) | 2010-04-29 → 2010-04-20 (-9d) |  | 128.15d → 207.5d | 69 → 69FS-2w |  |
| 208 | **Interfaces** | 2009-12-15 → 2010-02-18 (+65d) | 2010-03-17 → 2010-04-08 (+22d) | 66.03d? → 35.85d? | 204.02d → 215.46d |  |  |
| 209 | Mechanical Interface Requirements | 2010-01-15 → 2010-03-23 (+67d) | 2010-01-19 → 2010-03-25 (+65d) |  | 234.31d → 215.46d |  | resources ME - John Canfield → ME - TBD |
| 210 | Electronic Interface Requirements | 2009-12-15 → 2010-02-18 (+65d) | 2009-12-17 → 2010-02-22 (+67d) |  | 257.11d → 238.36d |  |  |
| 211 | Software Interface Requirements | 2010-02-26 → 2010-03-17 (+19d) | 2010-03-02 → 2010-03-22 (+20d) |  | 204.02d → 218.77d |  |  |
| 212 | Interface Control Document | 2010-03-02 → 2010-03-25 (+23d) | 2010-03-17 → 2010-04-08 (+22d) |  | 204.02d → 215.46d |  |  |
| 213 | **Accessories** | 2010-01-15 → 2010-03-23 (+67d) | 2010-02-02 → 2010-04-08 (+65d) |  | 196.15d → 177.31d |  |  |
| 214 | **Alignment Tooling** | 2010-01-25 → 2010-03-31 (+65d) | 2010-02-02 → 2010-04-08 (+65d) |  | 234.25d → 215.41d |  |  |
| 215 | Initial Specifications | 2010-01-25 → 2010-03-31 (+65d) | 2010-01-26 → 2010-04-01 (+65d) |  | 234.25d → 215.41d |  | resources ME - John Canfield → ME - TBD |
| 216 | Mechanical Model | 2010-01-27 → 2010-04-02 (+65d) | 2010-02-02 → 2010-04-08 (+65d) |  | 234.25d → 215.41d |  | resources ME - John Canfield → ME - TBD |
| 217 | **Assembly Tooling** | 2010-01-15 → 2010-03-23 (+67d) | 2010-01-25 → 2010-03-31 (+65d) |  | 196.15d → 177.31d |  |  |
| 218 | Initial Specifications | 2010-01-15 → 2010-03-23 (+67d) | 2010-01-18 → 2010-03-24 (+65d) |  | 196.15d → 177.31d |  | resources ME - John Canfield → ME - TBD |
| 219 | Mechanical Model | 2010-01-18 → 2010-03-24 (+65d) | 2010-01-25 → 2010-03-31 (+65d) |  | 196.15d → 177.31d |  | resources ME - John Canfield → ME - TBD |

## Version 3 (saved 2009-10-14, file Imager_and_IFS_PD_Phase_v1_2_tracked_Sept09.mpp)

Last finish 2011-02-04 → 2011-04-22 (+77d). Complete tasks 6 → 12.

Added:

| ID | Task | Duration | Start | Finish | Predecessors | Resources |
| --- | --- | --- | --- | --- | --- | --- |
| 62 | Preliminary Design Report | 10d | 2010-05-14 | 2010-05-28 | 70, 198, 220, 154 | Sean Adkins; Instrument Scientist; ME - Jim Bell; ME - TBD; Software Engineer; Electronics Engineer; WMKO Support Astronomer; WMKO Software Staff; WMKO Instrument Staff; WMKO Electronics Staff; OE - Optical Engineer 2 |

Changed:

| ID | Task | Start | Finish | Duration | Complete | Total float | Predecessors | Other |
| --- | --- | --- | --- | --- | --- | --- | --- | --- |
| 1 | **Milestones** | 2009-05-01 A | 2010-06-16 → 2010-06-21 (+5d) | 293.76d? → 296.18d? |  | 166.65d → 218.87d |  |  |
| 2 | Project Start | 2009-05-01 A | 2009-05-01 A |  | 0% → 100% | 298.91d → none |  |  |
| 3 | Imager Preliminary Design Review | 2010-06-16 → 2010-06-14 (-2d) | 2010-06-16 → 2010-06-14 (-2d) |  |  | 166.65d → 223.89d |  |  |
| 4 | IFS System Design Review | 2010-04-05 → 2010-06-21 (+77d) | 2010-04-05 → 2010-06-21 (+77d) |  |  |  |  |  |
| 5 | **Near-IR Imager and IFS** |  | 2011-02-04 → 2011-04-22 (+77d) | 436.41d? → 491.05d? | 3% → 6% |  |  |  |
| 6 | **Management** |  |  |  | 4% → 6% | 58.91d → 113.55d |  |  |
| 7 | **Monthly Reports** |  |  |  | 17% → 28% | 64.41d → 119.05d |  |  |
| 11 | Monthly Reports 4 | 2009-09-07 A | 2009-09-07 A |  | 0% → 100% | 368.41d → none |  |  |
| 12 | Monthly Reports 5 | 2009-10-05 A | 2009-10-05 A |  | 0% → 100% | 348.41d → none |  |  |
| 26 | **Project Meetings** | 2009-09-15 → 2009-09-29 (+14d) |  | 304.5d → 294.5d |  | 58.91d → 113.55d |  |  |
| 27 | Project Meetings 1 | 2009-09-15 → 2009-09-29 (+14d) | 2009-09-15 → 2009-09-29 (+14d) |  |  | 362.91d → 407.55d |  | constraint start no earlier than 2009-09-15 → start no earlier than 2009-09-29 |
| 44 | Cost Review | 2010-03-12 → 2010-04-09 (+28d) | 2010-04-27 → 2010-05-25 (+28d) |  |  | 202.79d → 237.43d |  |  |
| 52 | **Budget Maintenance** |  |  |  | 11% → 22% | 88.41d → 143.05d |  |  |
| 54 | Budget Maintenance 2 | 2009-08-04 A | 2009-08-04 A |  | 0% → 100% | 392.41d → none |  |  |
| 63 | Preliminary Design Review | 2010-04-16 → 2010-06-11 (+56d) | 2010-06-17 → 2010-06-15 (-2d) | 28.18d → 1.5d |  | 165.65d → 222.89d | 70, 198, 220, 154FS-2w → 62FS+2w |  |
| 64 | **Science** | 2009-09-18 → 2009-11-13 (+56d) | 2010-04-16 → 2010-05-14 (+28d) | 150.16d? → 130.16d? |  | 210.25d → 244.89d |  |  |
| 65 | **Science Team Meetings** | 2009-09-18 → 2009-11-13 (+56d) |  | 76.5d? → 36.5d? |  | 283.91d → 338.55d |  |  |
| 66 | Meeting 1 | 2009-09-18 → 2009-11-13 (+56d) | 2009-09-21 → 2009-11-16 (+56d) |  |  | 358.91d → 373.55d | 2FS+5mo → 2FS+7mo |  |
| 68 | **Common Observing Operations Concept Document** | 2009-09-18 → 2009-11-13 (+56d) | 2010-04-16 → 2010-05-14 (+28d) | 150.16d? → 130.16d? |  | 210.25d → 244.89d |  |  |
| 69 | Initial Draft | 2009-09-18 → 2009-11-13 (+56d) | 2009-10-15 → 2009-12-10 (+56d) |  |  | 340.66d → 355.3d | 2FS+5mo → 2FS+7mo |  |
| 70 | Final Version | 2010-03-03 → 2010-03-31 (+28d) | 2010-04-16 → 2010-05-14 (+28d) |  |  | 165.65d → 222.89d |  |  |
| 71 | **Instrument Design and Fabrication** |  | 2011-02-04 → 2011-04-22 (+77d) | 426.41d? → 481.05d? | 4% → 6% |  |  |  |
| 78 | **Shared Facilities** |  | 2009-12-04 → 2010-04-27 (+144d) | 121.49d? → 223.85d? | 16% → 27% | 304.92d → 257.2d |  |  |
| 79 | **AO System** |  | 2009-12-04 → 2010-04-27 (+144d) | 121.49d? → 223.85d? | 20% → 33% | 304.92d → 257.2d |  |  |
| 80 | **High Order AO Relay** |  | 2009-10-07 → 2010-04-27 (+202d) | 79.5d? → 223.85d? | 45% → 75% | 346.91d → 257.2d |  |  |
| 81 | Design Liason |  | 2009-09-14 A |  | 60% → 100% | 304.92d → none |  |  |
| 82 | RTC and Control Liason | 2009-09-21 → 2010-04-09 (+200d) | 2009-10-07 → 2010-04-27 (+202d) |  |  | 346.91d → 257.2d | 81 → 207SS |  |
| 83 | **ADC** | 2009-09-21 → 2009-10-05 (+14d) | 2009-11-06 → 2009-11-20 (+14d) |  |  | 324.41d → 369.05d |  |  |
| 84 | Requirements Liason | 2009-09-21 → 2009-10-05 (+14d) | 2009-10-16 → 2009-10-30 (+14d) |  |  | 324.41d → 369.05d | 81 → 81FS+2w |  |
| 85 | Design Liason | 2009-10-19 → 2009-11-02 (+14d) | 2009-11-06 → 2009-11-20 (+14d) |  |  | 324.41d → 369.05d |  |  |
| 86 | **Calibration Faciltiy** | 2009-10-23 → 2010-01-11 (+80d) | 2009-12-04 → 2010-02-22 (+80d) |  |  | 304.92d → 303.4d |  |  |
| 87 | Requirements Liason | 2009-10-23 → 2010-01-11 (+80d) | 2009-11-06 → 2010-01-25 (+80d) |  |  | 304.92d → 303.4d | 91 → 148, 91 |  |
| 88 | Design Liason | 2009-11-06 → 2010-01-25 (+80d) | 2009-12-04 → 2010-02-22 (+80d) |  |  | 304.92d → 303.4d |  |  |
| 89 | **Nasmyth Enclosure** | 2009-09-14 → 2010-03-16 (+183d) | 2009-10-23 → 2010-04-27 (+186d) |  |  | 304.92d → 257.71d |  |  |
| 90 | Requirements Liason | 2009-09-14 → 2010-03-16 (+183d) | 2009-10-06 → 2010-04-08 (+184d) |  |  | 304.92d → 257.71d | 81 → 152, 81FS+7d |  |
| 91 | Design Liason | 2009-10-06 → 2010-04-08 (+184d) | 2009-10-23 → 2010-04-27 (+186d) |  |  | 304.92d → 257.71d |  |  |
| 92 | **Instrument** |  | 2011-02-04 → 2011-04-22 (+77d) | 418.41d? → 473.05d? | 1% → 3% |  |  |  |
| 93 | **IFS System Design Phase** | 2009-09-07 → 2009-11-02 (+56d) | 2010-04-06 → 2010-06-22 (+77d) | 151.54d? → 166.18d? |  |  |  |  |
| 94 | **IFS Performance Budgets** | 2009-09-07 → 2009-11-02 (+56d) | 2009-11-24 → 2010-01-19 (+56d) |  |  |  |  |  |
| 95 | Throughput | 2009-09-07 → 2009-11-02 (+56d) | 2009-09-15 → 2009-11-10 (+56d) |  |  |  | 141 → 141FS+2mo |  |
| 96 | Background | 2009-09-15 → 2009-11-10 (+56d) | 2009-10-01 → 2009-11-26 (+56d) |  |  | 0d → 0.85d |  |  |
| 97 | Wavefront error | 2009-10-01 → 2009-11-26 (+56d) | 2009-10-09 → 2009-12-04 (+56d) |  |  | 0d → 0.85d |  |  |
| 98 | Spectroscopic performance | 2009-10-09 → 2009-12-04 (+56d) | 2009-11-17 → 2010-01-12 (+56d) |  |  | 0d → 0.85d |  |  |
| 99 | Size and mass | 2009-11-17 → 2010-01-12 (+56d) | 2009-11-24 → 2010-01-19 (+56d) |  |  | 313.06d → 327.71d |  |  |
| 100 | **Trade Studies** | 2009-11-17 → 2009-11-10 (-7d) | 2010-03-29 → 2010-03-22 (-7d) |  |  | 224.32d → 0d |  |  |
| 101 | FOV and spatial sampling | 2009-11-17 → 2009-11-10 (-7d) | 2009-12-17 → 2009-12-11 (-6d) |  |  | 224.32d → 0d | 98 → 95 |  |
| 102 | Wavelength coverage and spatial sampling | 2009-12-17 → 2009-12-11 (-6d) | 2010-01-19 → 2010-01-12 (-7d) | 15.39d → 14.47d |  | 224.32d → 0d | 98, 101 → 101, 95 |  |
| 103 | Optimization of image slicing formats and spectrograph formats | 2010-01-19 → 2010-01-12 (-7d) | 2010-02-26 → 2010-02-22 (-4d) |  |  | 224.32d → 0d |  |  |
| 104 | Separate or combined capability above and below 1 micron | 2010-02-26 → 2010-02-22 (-4d) | 2010-03-11 → 2010-03-05 (-6d) |  |  | 224.32d → 283.43d |  |  |
| 105 | Wavefront error allocations | 2010-03-11 → 2010-03-05 (-6d) | 2010-03-22 → 2010-03-16 (-6d) |  |  | 224.32d → 283.43d |  |  |
| 106 | Trade study report | 2010-03-22 → 2010-03-16 (-6d) | 2010-03-29 → 2010-03-22 (-7d) |  |  | 224.32d → 283.43d |  |  |
| 107 | **Conceptual Designs** | 2009-11-17 → 2010-02-22 (+97d) | 2010-03-29 → 2010-06-22 (+85d) | 94.79d? → 85.59d? |  |  |  |  |
| 108 | Development of design options | 2009-11-17 → 2010-02-22 (+97d) | 2010-01-20 → 2010-04-27 (+97d) |  |  |  | 98 → 103 |  |
| 109 | Evaluation of design options | 2010-01-20 → 2010-04-27 (+97d) | 2010-02-03 → 2010-05-11 (+97d) |  |  |  |  |  |
| 110 | Calibration and alignment issues | 2010-02-03 → 2010-05-11 (+97d) | 2010-02-11 → 2010-05-19 (+97d) |  |  |  |  |  |
| 111 | Downselect of conceptual design | 2010-02-11 → 2010-05-19 (+97d) | 2010-02-18 → 2010-05-26 (+97d) |  |  |  |  |  |
| 112 | Revised performance budgets | 2010-02-18 → 2010-05-26 (+97d) | 2010-02-24 → 2010-06-01 (+97d) |  |  | 243.5d → 228.83d |  |  |
| 113 | Performance budget report | 2010-02-24 → 2010-06-01 (+97d) | 2010-03-01 → 2010-06-07 (+98d) |  |  | 243.5d → 228.83d |  |  |
| 114 | Performance estimates | 2010-02-18 → 2010-05-26 (+97d) | 2010-03-03 → 2010-06-08 (+97d) |  |  |  |  |  |
| 115 | System requirements document | 2010-03-03 → 2010-06-08 (+97d) | 2010-03-09 → 2010-06-15 (+98d) |  |  |  |  |  |
| 116 | System design manual | 2010-03-09 → 2010-06-15 (+98d) | 2010-03-29 → 2010-06-22 (+85d) | 7.28d? → 4.85d? |  | 0d → 218d |  |  |
| 117 | **System Design Review** | 2010-03-29 → 2010-06-15 (+78d) | 2010-04-06 → 2010-06-22 (+77d) | 5.61d? → 4.98d? |  |  |  |  |
| 118 | System design report | 2010-03-29 → 2010-06-15 (+78d) | 2010-04-05 → 2010-06-18 (+74d) | 4.38d? → 3.75d? |  |  | 116 → 115 |  |
| 119 | System design review meeting | 2010-04-05 → 2010-06-18 (+74d) | 2010-04-06 → 2010-06-22 (+77d) |  |  |  |  |  |
| 120 | **IFS Preliminary Design Phase** | 2010-04-06 → 2010-06-22 (+77d) | 2011-02-04 → 2011-04-22 (+77d) |  |  |  |  |  |
| 121 | Initial AO system to instrument interface definitions | 2010-04-06 → 2010-06-22 (+77d) | 2010-04-15 → 2010-07-01 (+77d) |  |  |  |  |  |
| 122 | Alignment and calibration concept | 2010-04-15 → 2010-07-01 (+77d) | 2010-04-27 → 2010-07-13 (+77d) |  |  |  |  |  |
| 123 | Optical design | 2010-04-27 → 2010-07-13 (+77d) | 2010-09-02 → 2010-11-18 (+77d) |  |  |  |  |  |
| 124 | Mechanical design | 2010-06-10 → 2010-08-26 (+77d) | 2011-01-21 → 2011-04-07 (+76d) |  |  |  |  |  |
| 125 | Electronic design | 2010-11-25 → 2011-02-10 (+77d) | 2011-01-06 → 2011-03-24 (+77d) |  |  |  |  |  |

| ID | Task | Start | Finish | Duration | Complete | Total float | Predecessors | Other |
| --- | --- | --- | --- | --- | --- | --- | --- | --- |
| 126 | Software design | 2010-11-25 → 2011-02-10 (+77d) | 2010-12-28 → 2011-03-15 (+77d) |  |  |  |  |  |
| 127 | Preliminary design report | 2011-01-21 → 2011-04-07 (+76d) | 2011-02-03 → 2011-04-20 (+76d) |  |  |  |  |  |
| 128 | Preliminary design review meeting | 2011-02-03 → 2011-04-20 (+76d) | 2011-02-04 → 2011-04-22 (+77d) |  |  |  |  |  |
| 129 | **Near-IR Imager and IFS Preliminary Design** |  | 2010-04-20 → 2010-05-18 (+28d) | 210.9d? → 230.9d? | 4% → 8% | 207.5d → 242.15d |  |  |
| 130 | **Imager Trade Studies** |  | 2009-10-02 → 2009-10-30 (+28d) | 68.5d? → 88.5d? | 15% → 38% | 349.91d → 384.55d |  |  |
| 131 | Imager Wavefront Error | 2009-09-07 → 2009-10-05 (+28d) | 2009-10-02 → 2009-10-30 (+28d) |  |  | 337.91d → 372.55d | 141 → 141FS+20d |  |
| 132 | Imager Pixel Scale |  | 2009-09-15 → 2009-10-07 (+22d) |  | 30% → 75% | 362.77d → 401.75d |  |  |
| 133 | Imager Short Wavelength Cut-off | 2009-09-07 → 2009-10-05 (+28d) | 2009-09-09 → 2009-10-07 (+28d) |  |  | 353.34d → 368.28d | 141 → 141FS+1mo |  |
| 134 | **Imager Performance Budgets** |  | 2010-03-19 → 2010-04-16 (+28d) | 168.15d? → 188.15d? | 1% → 2% | 230.25d → 264.9d |  |  |
| 135 | Imager Sensitivity |  | 2009-09-10 → 2009-11-05 (+56d) |  | 20% → 50% | 353.14d → 367.78d | 133 → 133FS+1mo |  |
| 136 | Imager Background | 2009-09-10 → 2009-11-05 (+56d) | 2009-09-16 → 2009-11-11 (+56d) |  |  | 353.14d → 367.78d |  |  |
| 137 | Imager Companion Sensitivity | 2009-09-16 → 2009-11-11 (+56d) | 2009-09-29 → 2009-11-24 (+56d) |  |  | 353.14d → 367.78d |  |  |
| 138 | Imager Wavefront Error | 2009-10-02 → 2009-10-30 (+28d) | 2009-10-20 → 2009-11-17 (+28d) |  |  | 337.91d → 372.55d |  |  |
| 139 | Imager Size and Mass | 2010-03-12 → 2010-04-09 (+28d) | 2010-03-19 → 2010-04-16 (+28d) |  |  | 230.25d → 264.9d |  |  |
| 140 | **Optical Design** |  | 2009-11-23 → 2010-01-11 (+49d) | 84.65d? → 119.65d? | 17% → 33% | 313.75d → 303.4d |  |  |
| 141 | Initial Optical Design |  | 2009-09-04 A |  | 50% → 100% | 0d → none |  | resources Sean Adkins [31.1%]; OE - Optical Engineer 2 [90%] → Sean Adkins [31.1%] |
| 142 | **Optical Modeling** | 2009-09-21 → 2009-10-19 (+28d) | 2009-11-16 → 2010-01-04 (+49d) | 40.65d? → 55.65d? |  | 165.65d → 222.89d |  |  |
| 143 | Fore Optics | 2009-09-21 → 2009-10-19 (+28d) | 2009-10-01 → 2009-10-29 (+28d) |  |  | 165.65d → 222.89d | 141FS+2w → 141FS+6w |  |
| 144 | Lyot Stop | 2009-10-01 → 2009-10-29 (+28d) | 2009-10-05 → 2009-11-02 (+28d) |  |  | 165.65d → 222.89d |  |  |
| 145 | Coronagraph | 2009-10-05 → 2009-11-02 (+28d) | 2009-10-16 → 2009-11-13 (+28d) |  |  | 165.65d → 222.89d |  |  |
| 146 | Imager Camera | 2009-10-16 → 2009-11-13 (+28d) | 2009-11-13 → 2009-12-11 (+28d) |  |  | 165.65d → 222.89d |  |  |
| 147 | IFS Fold Mirror | 2009-11-13 → 2009-12-11 (+28d) | 2009-11-16 → 2010-01-04 (+49d) | 1.25d? → 1.76d? |  | 313.75d → 303.4d |  |  |
| 148 | Preliminary Design Performance Analysis | 2009-11-16 → 2010-01-04 (+49d) | 2009-11-23 → 2010-01-11 (+49d) |  |  | 313.75d → 303.4d |  |  |
| 149 | **Dewar** | 2009-10-01 → 2009-10-29 (+28d) | 2010-03-22 → 2010-04-19 (+28d) |  |  | 196.15d → 253.39d |  |  |
| 150 | **Cold Assemblies** | 2009-10-01 → 2009-10-29 (+28d) | 2010-03-12 → 2010-04-09 (+28d) |  |  | 196.15d → 253.39d |  |  |
| 151 | **Dewar Internal Structure** | 2010-02-15 → 2010-03-15 (+28d) | 2010-03-12 → 2010-04-09 (+28d) |  |  | 165.65d → 222.89d |  |  |
| 152 | Interface Specification | 2010-02-15 → 2010-03-15 (+28d) | 2010-02-16 → 2010-03-16 (+28d) |  |  | 165.65d → 222.89d |  |  |
| 153 | Mechanical Model | 2010-02-16 → 2010-03-16 (+28d) | 2010-03-02 → 2010-03-30 (+28d) |  |  | 165.65d → 222.89d |  |  |
| 154 | FEA | 2010-03-02 → 2010-03-30 (+28d) | 2010-03-12 → 2010-04-09 (+28d) |  |  | 200.45d → 237.43d |  |  |
| 155 | Thermal Analysis | 2010-03-02 → 2010-03-30 (+28d) | 2010-03-09 → 2010-04-06 (+28d) |  |  | 165.65d → 222.89d |  |  |
| 156 | **Fore Optics** | 2009-10-01 → 2009-10-29 (+28d) | 2009-11-23 → 2009-12-21 (+28d) |  |  | 241.93d → 299.17d |  |  |
| 157 | **Input Baffle & Coronagraph** | 2009-10-16 → 2009-11-13 (+28d) | 2009-11-23 → 2009-12-21 (+28d) |  |  | 211.43d → 268.67d |  |  |
| 158 | Interface Specification | 2009-10-16 → 2009-11-13 (+28d) | 2009-10-19 → 2009-11-16 (+28d) |  |  | 231.43d → 288.67d |  |  |
| 159 | Mechanical Model | 2009-11-16 → 2009-12-14 (+28d) | 2009-11-23 → 2009-12-21 (+28d) |  |  | 211.43d → 268.67d |  |  |
| 160 | **Re-imager** | 2009-10-01 → 2009-10-29 (+28d) | 2009-10-12 → 2009-11-09 (+28d) |  |  | 344d → 378.65d |  |  |
| 161 | Interface Specification | 2009-10-01 → 2009-10-29 (+28d) | 2009-10-05 → 2009-11-02 (+28d) |  |  | 344d → 378.65d |  |  |
| 162 | Mechanical Model | 2009-10-05 → 2009-11-02 (+28d) | 2009-10-12 → 2009-11-09 (+28d) |  |  | 344d → 378.65d |  |  |
| 163 | **Adjustable Lyot Stop** | 2009-10-05 → 2009-11-02 (+28d) | 2009-10-16 → 2009-11-13 (+28d) |  |  | 263.1d → 320.34d |  |  |
| 164 | Interface Specification | 2009-10-05 → 2009-11-02 (+28d) | 2009-10-07 → 2009-11-04 (+28d) |  |  | 263.1d → 320.34d |  |  |
| 165 | Mechanical Model | 2009-10-07 → 2009-11-04 (+28d) | 2009-10-16 → 2009-11-13 (+28d) |  |  | 263.1d → 320.34d |  |  |
| 166 | **Filter Wheels** | 2009-11-13 → 2009-12-11 (+28d) | 2009-12-11 → 2010-01-27 (+47d) | 19.76d? → 33.26d? |  | 223.83d → 267.57d |  |  |
| 167 | **Mechanism** | 2009-11-13 → 2009-12-11 (+28d) | 2009-12-11 → 2010-01-27 (+47d) | 19.76d? → 33.26d? |  | 223.83d → 267.57d |  |  |
| 168 | Interface Specification | 2009-11-13 → 2009-12-11 (+28d) | 2009-11-17 → 2009-12-15 (+28d) |  |  | 223.83d → 281.08d |  |  |
| 169 | Mechanical Model | 2009-11-18 → 2010-01-05 (+48d) | 2009-12-11 → 2010-01-27 (+47d) |  |  | 223.83d → 267.57d |  |  |
| 170 | Filter Specifications | 2009-11-17 → 2009-12-15 (+28d) | 2009-11-18 → 2010-01-04 (+47d) | 1.43d? → 2.43d? |  | 223.83d → 267.57d |  |  |
| 171 | **Imager** | 2009-11-13 → 2009-12-11 (+28d) | 2010-02-08 → 2010-03-08 (+28d) |  |  | 165.65d → 222.89d |  |  |
| 172 | **Camera** | 2009-11-13 → 2009-12-11 (+28d) | 2009-11-26 → 2009-12-24 (+28d) |  |  | 165.65d → 222.89d |  |  |
| 173 | Interface Specification | 2009-11-13 → 2009-12-11 (+28d) | 2009-11-16 → 2009-12-14 (+28d) |  |  | 165.65d → 222.89d |  |  |
| 174 | Mechanical Model | 2009-11-16 → 2009-12-14 (+28d) | 2009-11-26 → 2009-12-24 (+28d) |  |  | 165.65d → 222.89d |  |  |
| 175 | **Detector Head** | 2009-11-26 → 2009-12-24 (+28d) | 2010-02-08 → 2010-03-08 (+28d) |  |  | 165.65d → 222.89d |  |  |
| 176 | **Mount** | 2009-11-26 → 2009-12-24 (+28d) | 2009-12-04 → 2010-01-01 (+28d) |  |  | 165.65d → 222.89d |  |  |
| 177 | Interface Specification | 2009-11-26 → 2009-12-24 (+28d) | 2009-11-27 → 2009-12-25 (+28d) |  |  | 165.65d → 222.89d |  |  |
| 178 | Mechanical Model | 2009-11-27 → 2009-12-25 (+28d) | 2009-12-04 → 2010-01-01 (+28d) |  |  | 165.65d → 222.89d |  |  |
| 179 | **Focus Mechanism** | 2009-12-04 → 2010-01-01 (+28d) | 2010-02-02 → 2010-03-02 (+28d) |  |  | 165.65d → 222.89d |  |  |
| 180 | Interface Specification | 2009-12-04 → 2010-01-01 (+28d) | 2009-12-31 → 2010-01-28 (+28d) |  |  | 165.65d → 222.89d |  |  |
| 181 | Mechanical Model | 2009-12-31 → 2010-01-28 (+28d) | 2010-02-02 → 2010-03-02 (+28d) |  |  | 165.65d → 222.89d |  |  |
| 182 | **Cooling Interface** | 2010-02-02 → 2010-03-02 (+28d) | 2010-02-08 → 2010-03-08 (+28d) |  |  | 165.65d → 222.89d |  |  |
| 183 | Interface Specification | 2010-02-02 → 2010-03-02 (+28d) | 2010-02-03 → 2010-03-03 (+28d) |  |  | 165.65d → 222.89d |  |  |
| 184 | Mechanical Model | 2010-02-03 → 2010-03-03 (+28d) | 2010-02-08 → 2010-03-08 (+28d) |  |  | 165.65d → 222.89d |  |  |
| 185 | **Warm Assemblies** | 2009-11-23 → 2009-12-21 (+28d) | 2010-03-22 → 2010-04-19 (+28d) |  |  | 211.43d → 263.2d |  |  |
| 186 | **Dewar Shell** | 2009-11-23 → 2009-12-21 (+28d) | 2010-03-22 → 2010-04-19 (+28d) |  |  | 211.43d → 263.2d |  |  |
| 187 | Interface Specification | 2009-11-24 → 2009-12-22 (+28d) | 2009-11-27 → 2009-12-25 (+28d) |  |  | 211.43d → 268.67d |  |  |
| 188 | Mechanical Model | 2009-11-27 → 2009-12-25 (+28d) | 2009-12-29 → 2010-01-26 (+28d) |  |  | 211.43d → 268.67d |  |  |
| 189 | Window Specifications | 2009-11-23 → 2009-12-21 (+28d) | 2009-11-24 → 2009-12-22 (+28d) |  |  | 211.43d → 268.67d |  |  |
| 190 | External Connections | 2010-03-18 → 2010-04-15 (+28d) | 2010-03-22 → 2010-04-19 (+28d) |  |  | 228.55d → 263.2d |  |  |
| 191 | Vacuum System Requirements | 2010-03-16 → 2010-04-13 (+28d) | 2010-03-18 → 2010-04-15 (+28d) |  |  | 228.55d → 263.2d |  |  |
| 192 | Cryogenic System Requirements | 2010-03-09 → 2010-04-06 (+28d) | 2010-03-16 → 2010-04-13 (+28d) |  |  | 228.55d → 263.2d |  |  |
| 193 | **Electronics** | 2010-02-02 → 2010-03-02 (+28d) | 2010-02-18 → 2010-03-18 (+28d) |  |  | 207.95d → 265.2d |  |  |
| 194 | **Motion Control** | 2010-02-02 → 2010-03-02 (+28d) | 2010-02-12 → 2010-03-12 (+28d) |  |  | 207.95d → 265.2d |  |  |
| 195 | Requirements | 2010-02-02 → 2010-03-02 (+28d) | 2010-02-09 → 2010-03-09 (+28d) |  |  | 207.95d → 265.2d |  |  |

| ID | Task | Start | Finish | Total float |
| --- | --- | --- | --- | --- |
| 196 | Initial Design | 2010-02-09 → 2010-03-09 (+28d) | 2010-02-12 → 2010-03-12 (+28d) | 207.95d → 265.2d |
| 197 | Power Control | 2010-02-12 → 2010-03-12 (+28d) | 2010-02-15 → 2010-03-15 (+28d) | 207.95d → 265.2d |
| 198 | Pressure Monitoring | 2010-02-15 → 2010-03-15 (+28d) | 2010-02-16 → 2010-03-16 (+28d) | 207.95d → 265.2d |
| 199 | Temperature Monitoring and Control | 2010-02-16 → 2010-03-16 (+28d) | 2010-02-18 → 2010-03-18 (+28d) | 238.36d → 273d |
| 200 | **Software** | 2010-02-02 → 2010-03-02 (+28d) | 2010-04-20 → 2010-05-18 (+28d) | 186.15d → 242.15d |
| 201 | Detector Control | 2010-03-12 → 2010-04-09 (+28d) | 2010-03-17 → 2010-04-14 (+28d) | 229.05d → 263.7d |
| 202 | Global Server | 2010-03-17 → 2010-04-14 (+28d) | 2010-03-22 → 2010-04-19 (+28d) | 229.05d → 263.7d |
| 203 | Motion Control | 2010-02-02 → 2010-03-02 (+28d) | 2010-02-05 → 2010-03-05 (+28d) | 186.15d → 243.39d |
| 204 | Power Control | 2010-02-05 → 2010-03-05 (+28d) | 2010-02-08 → 2010-03-08 (+28d) | 186.15d → 243.39d |
| 205 | Pressure Monitoring | 2010-02-08 → 2010-03-08 (+28d) | 2010-02-09 → 2010-03-09 (+28d) | 186.15d → 243.39d |
| 206 | Temperature Monitoring and Control | 2010-03-09 → 2010-04-06 (+28d) | 2010-03-12 → 2010-04-09 (+28d) | 165.65d → 222.89d |
| 207 | User Interface Requirements | 2010-03-12 → 2010-04-09 (+28d) | 2010-03-17 → 2010-04-14 (+28d) | 165.65d → 222.89d |
| 208 | Data Reduction Tools | 2010-04-02 → 2010-04-30 (+28d) | 2010-04-20 → 2010-05-18 (+28d) | 207.5d → 242.15d |
| 209 | **Interfaces** | 2010-02-18 → 2010-03-18 (+28d) | 2010-04-08 → 2010-05-06 (+28d) | 215.46d → 250.1d |
| 210 | Mechanical Interface Requirements | 2010-03-23 → 2010-04-20 (+28d) | 2010-03-25 → 2010-04-22 (+28d) | 215.46d → 250.1d |
| 211 | Electronic Interface Requirements | 2010-02-18 → 2010-03-18 (+28d) | 2010-02-22 → 2010-03-22 (+28d) | 238.36d → 273d |
| 212 | Software Interface Requirements | 2010-03-17 → 2010-04-14 (+28d) | 2010-03-22 → 2010-04-19 (+28d) | 218.77d → 253.41d |
| 213 | Interface Control Document | 2010-03-25 → 2010-04-22 (+28d) | 2010-04-08 → 2010-05-06 (+28d) | 215.46d → 250.1d |
| 214 | **Accessories** | 2010-03-23 → 2010-04-20 (+28d) | 2010-04-08 → 2010-05-06 (+28d) | 177.31d → 234.55d |
| 215 | **Alignment Tooling** | 2010-03-31 → 2010-04-28 (+28d) | 2010-04-08 → 2010-05-06 (+28d) | 215.41d → 250.05d |
| 216 | Initial Specifications | 2010-03-31 → 2010-04-28 (+28d) | 2010-04-01 → 2010-04-29 (+28d) | 215.41d → 250.05d |
| 217 | Mechanical Model | 2010-04-02 → 2010-04-30 (+28d) | 2010-04-08 → 2010-05-06 (+28d) | 215.41d → 250.05d |
| 218 | **Assembly Tooling** | 2010-03-23 → 2010-04-20 (+28d) | 2010-03-31 → 2010-04-28 (+28d) | 177.31d → 234.55d |
| 219 | Initial Specifications | 2010-03-23 → 2010-04-20 (+28d) | 2010-03-24 → 2010-04-21 (+28d) | 177.31d → 234.55d |
| 220 | Mechanical Model | 2010-03-24 → 2010-04-21 (+28d) | 2010-03-31 → 2010-04-28 (+28d) | 177.31d → 234.55d |

## Version 4 (saved 2009-11-19, file Imager_and_IFS_PD_Phase_v1_2_tracked_Oct09.mpp)

Last finish 2011-04-22 → 2011-04-21 (-1d). Complete tasks 12 → 13.

Removed: 27 Project Meetings 1; 28 Project Meetings 2; 29 Project Meetings 3; 30 Project Meetings 4; 57 Budget Maintenance 5; 104 Separate or combined capability above and below 1 micron

Changed:

| ID | Task | Start | Finish | Duration | Complete | Total float | Predecessors | Other |
| --- | --- | --- | --- | --- | --- | --- | --- | --- |
| 1 | **Milestones** |  | 2010-06-21 → 2010-06-18 (-3d) | 296.18d? → 295.81d? |  |  |  |  |
| 3 | Imager Preliminary Design Review | 2010-06-14 → 2010-06-03 (-11d) | 2010-06-14 → 2010-06-03 (-11d) |  |  | 223.89d → 231.05d |  |  |
| 4 | IFS System Design Review | 2010-06-21 → 2010-06-18 (-3d) | 2010-06-21 → 2010-06-18 (-3d) |  |  |  |  |  |
| 5 | **Near-IR Imager and IFS** |  | 2011-04-22 → 2011-04-21 (-1d) | 491.05d? → 490.68d? | 6% → 9% |  |  |  |
| 6 | **Management** |  |  |  | 6% → 8% | 113.55d → 113.18d |  |  |
| 7 | **Monthly Reports** |  |  |  | 28% → 33% | 119.05d → 118.68d |  |  |
| 13 | Monthly Reports 6 | 2009-11-05 A | 2009-11-05 A |  | 0% → 100% | 380.05d → none |  |  |
| 26 | **Project Meetings** | 2009-09-29 → 2010-01-15 (+108d) |  | 294.5d → 216.5d |  | 113.55d → 113.18d |  |  |
| 27 | Project Meeting 1 |  |  |  |  |  |  | was named Project Meetings 5 |
| 28 | Project Meeting 2 |  |  |  |  |  |  | was named Project Meetings 6 |
| 29 | Project Meeting 3 |  |  |  |  |  |  | was named Project Meetings 7 |
| 30 | Project Meeting 4 |  |  |  |  |  |  | was named Project Meetings 8 |
| 31 | Project Meeting 5 |  |  |  |  |  |  | was named Project Meetings 9 |
| 32 | Project Meeting 6 |  |  |  |  |  |  | was named Project Meetings 10 |
| 33 | Project Meeting 7 |  |  |  |  |  |  | was named Project Meetings 11 |
| 34 | Project Meeting 8 |  |  |  |  |  |  | was named Project Meetings 12 |
| 35 | Project Meeting 9 |  |  |  |  |  |  | was named Project Meetings 13 |
| 36 | Project Meeting 10 |  |  |  |  |  |  | was named Project Meetings 14 |
| 37 | Project Meeting 11 |  |  |  |  |  |  | was named Project Meetings 15 |
| 40 | Cost Review | 2010-04-09 → 2010-04-20 (+11d) | 2010-05-25 → 2010-06-03 (+9d) |  |  | 237.43d → 230.06d |  |  |
| 48 | **Budget Maintenance** |  |  |  | 22% → 25% | 143.05d → 142.68d |  |  |
| 51 | Budget Maintenance 3 | 2009-10-05 → 2009-12-04 (+60d) | 2009-10-05 → 2009-12-04 (+60d) |  |  | 391.73d → 359.05d |  | constraint start no earlier than 2009-10-04 → start no earlier than 2009-12-04 |
| 52 | Budget Maintenance 4 | 2009-12-04 → 2010-02-04 (+62d) | 2009-12-04 → 2010-02-04 (+62d) |  |  | 347.73d → 315.05d |  | constraint start no earlier than 2009-12-04 → start no earlier than 2010-02-04 |
| 57 | Preliminary Design Report | 2010-05-14 → 2010-05-07 (-7d) | 2010-05-28 → 2010-05-19 (-9d) | 10d → 8d |  | 222.89d → 229.68d |  | resources Sean Adkins; Instrument Scientist; ME - Jim Bell; ME - TBD; Software Engineer; Electronics Engineer; WMKO Support Astronomer; WMKO Software Staff; WMKO Instrument Staff; WMKO Electronics Staff; OE - Optical Engineer 2 → Sean Adkins [125%]; Instrument Scientist; ME - Jim Bell; ME - TBD; Software Engineer; Electronics Engineer; WMKO Support Astronomer; WMKO Software Staff; WMKO Instrument Staff; WMKO Electronics Staff; OE - Optical Engineer 2 |
| 58 | Preliminary Design Review | 2010-06-11 → 2010-06-02 (-9d) | 2010-06-15 → 2010-06-03 (-12d) |  |  | 222.89d → 229.68d |  |  |
| 59 | **Science** | 2009-11-13 → 2010-01-08 (+56d) | 2010-05-14 → 2010-04-27 (-17d) | 130.16d? → 77.16d? |  | 244.89d → 257.89d |  |  |
| 60 | **Science Team Meetings** | 2009-11-13 → 2010-01-22 (+70d) | 2010-01-04 → 2010-04-05 (+91d) | 36.5d? → 51.5d? |  | 338.55d → 273.55d |  |  |
| 61 | Meeting 1 | 2009-11-13 → 2010-01-22 (+70d) | 2009-11-16 → 2010-01-25 (+70d) |  |  | 373.55d → 323.55d | 2FS+7mo → 2FS+9.5mo |  |
| 62 | Meeting 2 | 2009-12-11 → 2010-04-02 (+112d) | 2010-01-04 → 2010-04-05 (+91d) | 2d? → 1.5d? |  | 338.55d → 273.55d | 2FS+8mo → 2FS+12mo |  |
| 63 | **Common Observing Operations Concept Document** | 2009-11-13 → 2010-01-08 (+56d) | 2010-05-14 → 2010-04-27 (-17d) | 130.16d? → 77.16d? |  | 244.89d → 257.89d |  |  |
| 64 | Initial Draft | 2009-11-13 → 2010-01-08 (+56d) | 2009-12-10 → 2010-02-04 (+56d) |  |  | 355.3d → 315.3d | 2FS+7mo → 2FS+9mo |  |
| 65 | Final Version | 2010-03-31 → 2010-04-09 (+9d) | 2010-05-14 → 2010-04-27 (-17d) | 31.09d? → 5.51d? |  | 222.89d → 238.39d |  | resources Sean Adkins [20%]; Instrument Scientist [20%]; Science Team [20%] → Sean Adkins; Instrument Scientist; Science Team |
| 66 | **Instrument Design and Fabrication** |  | 2011-04-22 → 2011-04-21 (-1d) | 481.05d? → 480.68d? | 6% → 9% |  |  |  |
| 67 | **AO System to Instrument Interface Definitions** | 2009-09-14 A | 2009-10-02 → 2010-01-08 (+98d) | 14d? → 84d? | 0% → 28% | 405.05d → 335.05d |  |  |
| 68 | Optical | 2009-09-14 A |  |  | 0% → 50% | 405.05d → 0d |  |  |
| 69 | Mechanical | 2009-09-16 A |  |  | 0% → 50% | 405.05d → 0d |  |  |
| 70 | Electronic/Electrical | 2009-09-24 A |  |  | 0% → 25% | 405.05d → 335.05d |  |  |
| 72 | Alignment and Calibration Concept for Instrument on AO System | 2009-09-30 → 2010-01-06 (+98d) | 2009-10-02 → 2010-01-08 (+98d) |  |  | 405.05d → 335.05d | 71 → 71FS+14w |  |
| 73 | **Shared Facilities** |  | 2010-04-27 → 2010-05-06 (+9d) | 223.85d? → 230.85d? |  | 257.2d → 250.2d |  |  |
| 74 | **AO System** |  | 2010-04-27 → 2010-05-06 (+9d) | 223.85d? → 230.85d? |  | 257.2d → 250.2d |  |  |
| 75 | **High Order AO Relay** |  | 2010-04-27 → 2010-05-06 (+9d) | 223.85d? → 230.85d? |  | 257.2d → 250.2d |  |  |
| 77 | RTC and Control Liason | 2010-04-09 → 2010-04-20 (+11d) | 2010-04-27 → 2010-05-06 (+9d) |  |  | 257.2d → 250.2d |  |  |
| 78 | **ADC** | 2009-10-05 → 2009-11-30 (+56d) | 2009-11-20 → 2010-02-05 (+77d) | 35d? → 50d? |  | 369.05d → 314.05d |  |  |
| 79 | Requirements Liason | 2009-10-05 → 2009-11-30 (+56d) | 2009-10-30 → 2010-01-15 (+77d) |  |  | 369.05d → 314.05d | 76FS+2w → 76FS+10w |  |
| 80 | Design Liason | 2009-11-02 → 2010-01-18 (+77d) | 2009-11-20 → 2010-02-05 (+77d) |  |  | 369.05d → 314.05d |  |  |
| 81 | **Calibration Faciltiy** | 2010-01-11 → 2010-01-12 (+1d) | 2010-02-22 → 2010-02-23 (+1d) |  |  | 303.4d → 302.8d |  |  |
| 82 | Requirements Liason | 2010-01-11 → 2010-01-12 (+1d) | 2010-01-25 → 2010-01-26 (+1d) |  |  | 303.4d → 302.8d |  |  |
| 83 | Design Liason | 2010-01-25 → 2010-01-26 (+1d) | 2010-02-22 → 2010-02-23 (+1d) |  |  | 303.4d → 302.8d |  |  |
| 84 | **Nasmyth Enclosure** | 2010-03-16 → 2010-03-25 (+9d) | 2010-04-27 → 2010-05-06 (+9d) |  |  | 257.71d → 250.71d |  |  |
| 85 | Requirements Liason | 2010-03-16 → 2010-03-25 (+9d) | 2010-04-08 → 2010-04-19 (+11d) |  |  | 257.71d → 250.71d |  |  |
| 86 | Design Liason | 2010-04-08 → 2010-04-19 (+11d) | 2010-04-27 → 2010-05-06 (+9d) |  |  | 257.71d → 250.71d |  |  |
| 87 | **Instrument** |  | 2011-04-22 → 2011-04-21 (-1d) | 473.05d? → 472.68d? | 3% → 5% |  |  |  |
| 88 | **IFS System Design Phase** | 2009-11-02 A | 2010-06-22 → 2010-06-23 (+1d) | 166.18d? → 167.83d? | 0% → 7% | 0d → 215.85d |  |  |
| 89 | **IFS Performance Budgets** | 2009-11-02 A |  |  | 0% → 20% | 0d → 327.71d |  |  |
| 90 | Throughput | 2009-11-02 A |  |  | 0% → 40% |  |  |  |
| 91 | Background | 2009-11-10 A |  |  | 0% → 40% | 0.85d → 0d |  |  |
| 93 | Spectroscopic performance | 2009-12-04 A |  |  | 0% → 20% |  |  |  |
| 95 | **Trade Studies** | 2009-11-10 A | 2010-03-22 → 2010-06-23 (+93d) | 93.95d → 161.16d | 0% → 10% | 0d → 215.85d |  |  |
| 96 | FOV and spatial sampling | 2009-11-10 A |  |  | 0% → 20% |  |  |  |
| 97 | Wavelength coverage and spatial sampling | 2009-12-11 A |  |  | 0% → 20% |  |  |  |
| 99 | Wavefront error allocations | 2010-03-05 → 2010-06-08 (+95d) | 2010-03-16 → 2010-06-17 (+93d) |  |  | 283.43d → 215.85d | Separate or combined capability above and below 1 micron → 108 |  |
| 100 | Trade study report | 2010-03-16 → 2010-06-17 (+93d) | 2010-03-22 → 2010-06-23 (+93d) |  |  | 283.43d → 215.85d |  |  |
| 101 | **Conceptual Designs** |  | 2010-06-22 → 2010-06-21 (-1d) | 85.59d? → 85.22d? |  |  |  |  |
| 103 | Evaluation of design options |  |  | 9.74d? → 10d? |  |  |  |  |
| 107 | Performance budget report |  | 2010-06-07 → 2010-06-04 (-3d) |  |  |  |  |  |
| 109 | System requirements document |  | 2010-06-15 → 2010-06-14 (-1d) |  |  |  |  |  |
| 110 | System design manual | 2010-06-15 → 2010-06-14 (-1d) | 2010-06-22 → 2010-06-21 (-1d) |  |  |  |  |  |
| 111 | **System Design Review** | 2010-06-15 → 2010-06-14 (-1d) | 2010-06-22 → 2010-06-21 (-1d) |  |  |  |  |  |
| 112 | System design report | 2010-06-15 → 2010-06-14 (-1d) |  |  |  |  |  |  |
| 113 | System design review meeting |  | 2010-06-22 → 2010-06-21 (-1d) |  |  |  |  |  |

| ID | Task | Start | Finish | Duration | Complete | Total float | Predecessors | Other |
| --- | --- | --- | --- | --- | --- | --- | --- | --- |
| 114 | **IFS Preliminary Design Phase** | 2010-06-22 → 2010-06-21 (-1d) | 2011-04-22 → 2011-04-21 (-1d) |  |  |  |  |  |
| 115 | Initial AO system to instrument interface definitions | 2010-06-22 → 2010-06-21 (-1d) | 2010-07-01 → 2010-06-30 (-1d) |  |  |  |  |  |
| 116 | Alignment and calibration concept | 2010-07-01 → 2010-06-30 (-1d) |  |  |  |  |  |  |
| 117 | Optical design |  | 2010-11-18 → 2010-11-17 (-1d) |  |  |  |  |  |
| 118 | Mechanical design | 2010-08-26 → 2010-08-25 (-1d) |  |  |  |  |  |  |
| 119 | Electronic design | 2011-02-10 → 2011-02-09 (-1d) | 2011-03-24 → 2011-03-23 (-1d) |  |  |  |  |  |
| 120 | Software design | 2011-02-10 → 2011-02-09 (-1d) |  |  |  |  |  |  |
| 122 | Preliminary design review meeting |  | 2011-04-22 → 2011-04-21 (-1d) |  |  |  |  |  |
| 123 | **Near-IR Imager and IFS Preliminary Design** |  | 2010-05-18 → 2010-05-17 (-1d) | 230.9d? → 230d? | 8% → 10% | 242.15d → 243.05d |  |  |
| 124 | **Imager Trade Studies** |  | 2009-10-30 → 2009-11-27 (+28d) | 88.5d? → 108.5d? | 38% → 46% | 384.55d → 364.55d |  |  |
| 125 | Imager Wavefront Error | 2009-10-05 → 2009-11-02 (+28d) | 2009-10-30 → 2009-11-27 (+28d) |  |  | 372.55d → 352.55d | 135FS+20d → 135FS+40d |  |
| 127 | Imager Short Wavelength Cut-off | 2009-10-05 A |  |  | 0% → 50% | 368.28d → 0.5d |  |  |
| 128 | **Imager Performance Budgets** |  | 2010-04-16 → 2010-04-27 (+11d) | 188.15d? → 195.15d? | 2% → 10% | 264.9d → 257.9d |  |  |
| 130 | Imager Background | 2009-11-05 A |  |  | 0% → 50% |  |  |  |
| 132 | Imager Wavefront Error | 2009-10-30 → 2009-11-27 (+28d) | 2009-11-17 → 2009-12-15 (+28d) |  |  | 372.55d → 352.55d |  |  |
| 133 | Imager Size and Mass | 2010-04-09 → 2010-04-20 (+11d) | 2010-04-16 → 2010-04-27 (+11d) |  |  | 264.9d → 257.9d |  |  |
| 134 | **Optical Design** |  | 2010-01-11 → 2010-01-12 (+1d) | 119.65d? → 120.25d? | 33% → 38% | 303.4d → 302.8d |  |  |
| 136 | **Optical Modeling** | 2009-10-19 → 2009-11-02 A (+14d) | 2010-01-04 → 2010-01-05 (+1d) | 55.65d? → 46.25d? | 0% → 8% | 222.89d → 302.8d |  |  |
| 137 | Fore Optics | 2009-10-19 → 2009-11-02 A (+14d) | 2009-10-29 → 2009-11-16 (+18d) | 6d? → 10.9d? | 0% → 10% | 222.89d → 0d | 135FS+6w → 135FS+8w | resources OE - Optical Engineer 2; Sean Adkins; Instrument Scientist → OE - Optical Engineer 2 [50%]; Sean Adkins [50%]; Instrument Scientist [50%] |
| 138 | Lyot Stop | 2009-10-29 → 2009-11-16 (+18d) | 2009-11-02 → 2009-11-18 (+16d) |  |  | 222.89d → 0d |  |  |
| 139 | Coronagraph | 2009-11-02 → 2009-11-18 (+16d) | 2009-11-13 → 2009-12-01 (+18d) |  |  | 222.89d → 0d |  |  |
| 140 | Imager Camera | 2009-11-13 → 2009-12-01 A (+18d) | 2009-12-11 → 2009-12-22 (+11d) | 20d? → 15d? | 0% → 10% | 222.89d → 230.15d |  |  |
| 141 | IFS Fold Mirror | 2009-12-11 → 2009-12-22 (+11d) | 2010-01-04 → 2010-01-05 (+1d) | 1.76d? → 2.36d? |  | 303.4d → 302.8d |  |  |
| 142 | Preliminary Design Performance Analysis | 2010-01-04 → 2010-01-05 (+1d) | 2010-01-11 → 2010-01-12 (+1d) |  |  | 303.4d → 302.8d |  |  |
| 143 | **Dewar** | 2009-10-29 → 2009-11-16 (+18d) | 2010-04-19 → 2010-04-28 (+9d) | 121.95d? → 116.95d? |  | 253.39d → 255.65d |  |  |
| 144 | **Cold Assemblies** | 2009-10-29 → 2009-11-16 (+18d) | 2010-04-09 → 2010-04-20 (+11d) | 115.45d? → 110.45d? |  | 253.39d → 255.65d |  |  |
| 145 | **Dewar Internal Structure** | 2010-03-15 → 2010-03-24 (+9d) | 2010-04-09 → 2010-04-20 (+11d) |  |  | 222.89d → 230.15d |  |  |
| 146 | Interface Specification | 2010-03-15 → 2010-03-24 (+9d) | 2010-03-16 → 2010-03-25 (+9d) |  |  | 222.89d → 230.15d |  |  |
| 147 | Mechanical Model | 2010-03-16 → 2010-03-25 (+9d) | 2010-03-30 → 2010-04-08 (+9d) |  |  | 222.89d → 230.15d |  |  |
| 148 | FEA | 2010-03-30 → 2010-04-08 (+9d) | 2010-04-09 → 2010-04-20 (+11d) |  |  | 237.43d → 230.43d |  |  |
| 149 | Thermal Analysis | 2010-03-30 → 2010-04-08 (+9d) | 2010-04-06 → 2010-04-15 (+9d) |  |  | 222.89d → 230.15d |  |  |
| 150 | **Fore Optics** | 2009-10-29 → 2009-11-16 (+18d) | 2009-12-21 → 2009-12-30 (+9d) | 37d? → 32d? |  | 299.17d → 300.88d |  |  |
| 151 | **Input Baffle & Coronagraph** | 2009-11-13 → 2009-12-01 (+18d) | 2009-12-21 → 2009-12-30 (+9d) | 26.5d? → 21.5d? |  | 268.67d → 275.38d |  |  |
| 152 | Interface Specification | 2009-11-13 → 2009-12-01 (+18d) | 2009-11-16 → 2009-12-02 (+16d) |  |  | 288.67d → 290.38d |  |  |
| 153 | Mechanical Model | 2009-12-14 → 2009-12-23 (+9d) | 2009-12-21 → 2009-12-30 (+9d) |  |  | 268.67d → 275.38d |  |  |
| 154 | **Re-imager** | 2009-10-29 → 2009-11-16 (+18d) | 2009-11-09 → 2009-11-25 (+16d) |  |  | 378.65d → 366.65d |  |  |
| 155 | Interface Specification | 2009-10-29 → 2009-11-16 (+18d) | 2009-11-02 → 2009-11-18 (+16d) |  |  | 378.65d → 366.65d |  |  |
| 156 | Mechanical Model | 2009-11-02 → 2009-11-18 (+16d) | 2009-11-09 → 2009-11-25 (+16d) |  |  | 378.65d → 366.65d |  |  |
| 157 | **Adjustable Lyot Stop** | 2009-11-02 → 2009-11-18 (+16d) | 2009-11-13 → 2009-12-01 (+18d) |  |  | 320.34d → 330.84d |  |  |
| 158 | Interface Specification | 2009-11-02 → 2009-11-18 (+16d) | 2009-11-04 → 2009-11-20 (+16d) |  |  | 320.34d → 330.84d |  |  |
| 159 | Mechanical Model | 2009-11-04 → 2009-11-20 (+16d) | 2009-11-13 → 2009-12-01 (+18d) |  |  | 320.34d → 330.84d |  |  |
| 160 | **Filter Wheels** | 2009-12-11 → 2009-12-22 (+11d) |  | 33.26d? → 26.26d? |  | 267.57d → 290.07d |  |  |
| 161 | **Mechanism** | 2009-12-11 → 2009-12-22 (+11d) |  | 33.26d? → 26.26d? |  | 267.57d → 290.07d |  |  |
| 162 | Interface Specification | 2009-12-11 → 2009-12-22 (+11d) | 2009-12-15 → 2009-12-24 (+9d) |  |  | 281.08d → 296.58d |  |  |
| 164 | Filter Specifications | 2009-12-15 → 2009-12-24 (+9d) |  |  |  | 267.57d → 290.07d |  |  |
| 165 | **Imager** | 2009-12-11 → 2009-12-22 (+11d) | 2010-03-08 → 2010-03-17 (+9d) |  |  | 222.89d → 230.15d |  |  |
| 166 | **Camera** | 2009-12-11 → 2009-12-22 (+11d) | 2009-12-24 → 2010-01-04 (+11d) |  |  | 222.89d → 230.15d |  |  |
| 167 | Interface Specification | 2009-12-11 → 2009-12-22 (+11d) | 2009-12-14 → 2009-12-23 (+9d) |  |  | 222.89d → 230.15d |  |  |
| 168 | Mechanical Model | 2009-12-14 → 2009-12-23 (+9d) | 2009-12-24 → 2010-01-04 (+11d) |  |  | 222.89d → 230.15d |  |  |
| 169 | **Detector Head** | 2009-12-24 → 2010-01-04 (+11d) | 2010-03-08 → 2010-03-17 (+9d) |  |  | 222.89d → 230.15d |  |  |
| 170 | **Mount** | 2009-12-24 → 2010-01-04 (+11d) | 2010-01-01 → 2010-01-12 (+11d) |  |  | 222.89d → 230.15d |  |  |
| 171 | Interface Specification | 2009-12-24 → 2010-01-04 (+11d) | 2009-12-25 → 2010-01-05 (+11d) |  |  | 222.89d → 230.15d |  |  |
| 172 | Mechanical Model | 2009-12-25 → 2010-01-05 (+11d) | 2010-01-01 → 2010-01-12 (+11d) |  |  | 222.89d → 230.15d |  |  |
| 173 | **Focus Mechanism** | 2010-01-01 → 2010-01-12 (+11d) | 2010-03-02 → 2010-03-11 (+9d) |  |  | 222.89d → 230.15d |  |  |
| 174 | Interface Specification | 2010-01-01 → 2010-01-12 (+11d) | 2010-01-28 → 2010-02-08 (+11d) |  |  | 222.89d → 230.15d |  |  |
| 175 | Mechanical Model | 2010-01-28 → 2010-02-08 (+11d) | 2010-03-02 → 2010-03-11 (+9d) |  |  | 222.89d → 230.15d |  |  |
| 176 | **Cooling Interface** | 2010-03-02 → 2010-03-11 (+9d) | 2010-03-08 → 2010-03-17 (+9d) |  |  | 222.89d → 230.15d |  |  |
| 177 | Interface Specification | 2010-03-02 → 2010-03-11 (+9d) | 2010-03-03 → 2010-03-12 (+9d) |  |  | 222.89d → 230.15d |  |  |
| 178 | Mechanical Model | 2010-03-03 → 2010-03-12 (+9d) | 2010-03-08 → 2010-03-17 (+9d) |  |  | 222.89d → 230.15d |  |  |
| 179 | **Warm Assemblies** | 2009-12-21 → 2009-12-30 (+9d) | 2010-04-19 → 2010-04-28 (+9d) |  |  | 263.2d → 256.2d |  |  |
| 180 | **Dewar Shell** | 2009-12-21 → 2009-12-30 (+9d) | 2010-04-19 → 2010-04-28 (+9d) |  |  | 263.2d → 256.2d |  |  |
| 181 | Interface Specification | 2009-12-22 → 2009-12-31 (+9d) | 2009-12-25 → 2010-01-05 (+11d) |  |  | 268.67d → 275.38d |  |  |
| 182 | Mechanical Model | 2009-12-25 → 2010-01-05 (+11d) | 2010-01-26 → 2010-02-04 (+9d) |  |  | 268.67d → 275.38d |  |  |
| 183 | Window Specifications | 2009-12-21 → 2009-12-30 (+9d) | 2009-12-22 → 2009-12-31 (+9d) |  |  | 268.67d → 275.38d |  |  |
| 184 | External Connections | 2010-04-15 → 2010-04-26 (+11d) | 2010-04-19 → 2010-04-28 (+9d) |  |  | 263.2d → 256.2d |  |  |
| 185 | Vacuum System Requirements | 2010-04-13 → 2010-04-22 (+9d) | 2010-04-15 → 2010-04-26 (+11d) |  |  | 263.2d → 256.2d |  |  |
| 186 | Cryogenic System Requirements | 2010-04-06 → 2010-04-15 (+9d) | 2010-04-13 → 2010-04-22 (+9d) |  |  | 263.2d → 256.2d |  |  |
| 187 | **Electronics** | 2010-03-02 → 2010-03-11 (+9d) | 2010-03-18 → 2010-03-29 (+11d) |  |  | 265.2d → 260.7d |  |  |
| 188 | **Motion Control** | 2010-03-02 → 2010-03-11 (+9d) | 2010-03-12 → 2010-03-23 (+11d) |  |  | 265.2d → 260.7d |  |  |
| 189 | Requirements | 2010-03-02 → 2010-03-11 (+9d) | 2010-03-09 → 2010-03-18 (+9d) |  |  | 265.2d → 260.7d |  |  |

| ID | Task | Start | Finish | Duration | Total float |
| --- | --- | --- | --- | --- | --- |
| 190 | Initial Design | 2010-03-09 → 2010-03-18 (+9d) | 2010-03-12 → 2010-03-23 (+11d) |  | 265.2d → 260.7d |
| 191 | Power Control | 2010-03-12 → 2010-03-23 (+11d) | 2010-03-15 → 2010-03-24 (+9d) |  | 265.2d → 260.7d |
| 192 | Pressure Monitoring | 2010-03-15 → 2010-03-24 (+9d) | 2010-03-16 → 2010-03-25 (+9d) |  | 265.2d → 260.7d |
| 193 | Temperature Monitoring and Control | 2010-03-16 → 2010-03-25 (+9d) | 2010-03-18 → 2010-03-29 (+11d) |  | 273d → 266d |
| 194 | **Software** | 2010-03-02 → 2010-03-11 (+9d) | 2010-05-18 → 2010-04-29 (-19d) | 55.05d? → 35.05d? | 242.15d → 255.15d |
| 195 | Detector Control | 2010-04-09 → 2010-04-20 (+11d) | 2010-04-14 → 2010-04-23 (+9d) |  | 263.7d → 256.7d |
| 196 | Global Server | 2010-04-14 → 2010-04-23 (+9d) | 2010-04-19 → 2010-04-28 (+9d) |  | 263.7d → 256.7d |
| 197 | Motion Control | 2010-03-02 → 2010-03-11 (+9d) | 2010-03-05 → 2010-03-16 (+11d) |  | 243.39d → 258.89d |
| 198 | Power Control | 2010-03-05 → 2010-03-16 (+11d) | 2010-03-08 → 2010-03-17 (+9d) |  | 243.39d → 258.89d |
| 199 | Pressure Monitoring | 2010-03-08 → 2010-03-17 (+9d) | 2010-03-09 → 2010-03-18 (+9d) |  | 243.39d → 258.89d |
| 200 | Temperature Monitoring and Control | 2010-04-06 → 2010-04-15 (+9d) | 2010-04-09 → 2010-04-20 (+11d) |  | 222.89d → 238.39d |
| 201 | User Interface Requirements | 2010-04-09 → 2010-04-20 (+11d) | 2010-04-14 → 2010-04-23 (+9d) |  | 222.89d → 238.39d |
| 202 | Data Reduction Tools | 2010-04-30 → 2010-04-13 (-17d) | 2010-05-18 → 2010-04-29 (-19d) |  | 242.15d → 255.15d |
| 203 | **Interfaces** | 2010-03-18 → 2010-03-29 (+11d) | 2010-05-06 → 2010-05-17 (+11d) |  | 250.1d → 243.1d |
| 204 | Mechanical Interface Requirements | 2010-04-20 → 2010-04-29 (+9d) | 2010-04-22 → 2010-05-03 (+11d) |  | 250.1d → 243.1d |
| 205 | Electronic Interface Requirements | 2010-03-18 → 2010-03-29 (+11d) | 2010-03-22 → 2010-03-31 (+9d) |  | 273d → 266d |
| 206 | Software Interface Requirements | 2010-04-14 → 2010-04-23 (+9d) | 2010-04-19 → 2010-04-28 (+9d) |  | 253.41d → 246.41d |
| 207 | Interface Control Document | 2010-04-22 → 2010-05-03 (+11d) | 2010-05-06 → 2010-05-17 (+11d) |  | 250.1d → 243.1d |
| 208 | **Accessories** | 2010-04-20 → 2010-04-29 (+9d) | 2010-05-06 → 2010-05-17 (+11d) |  | 234.55d → 230.05d |
| 209 | **Alignment Tooling** | 2010-04-28 → 2010-05-07 (+9d) | 2010-05-06 → 2010-05-17 (+11d) |  | 250.05d → 243.05d |
| 210 | Initial Specifications | 2010-04-28 → 2010-05-07 (+9d) | 2010-04-29 → 2010-05-10 (+11d) |  | 250.05d → 243.05d |
| 211 | Mechanical Model | 2010-04-30 → 2010-05-11 (+11d) | 2010-05-06 → 2010-05-17 (+11d) |  | 250.05d → 243.05d |
| 212 | **Assembly Tooling** | 2010-04-20 → 2010-04-29 (+9d) | 2010-04-28 → 2010-05-07 (+9d) |  | 234.55d → 230.05d |
| 213 | Initial Specifications | 2010-04-20 → 2010-04-29 (+9d) | 2010-04-21 → 2010-04-30 (+9d) |  | 234.55d → 230.05d |
| 214 | Mechanical Model | 2010-04-21 → 2010-04-30 (+9d) | 2010-04-28 → 2010-05-07 (+9d) |  | 234.55d → 230.05d |

## Version 5 (saved 2009-12-18, file Imager_and_IFS_PD_Phase_v1_2_tracked_Nov09.mpp)

Last finish 2011-04-21 → 2011-03-04 (-48d). Complete tasks 13 → 18.

Changed:

| ID | Task | Start | Finish | Duration | Complete | Total float | Predecessors | Other |
| --- | --- | --- | --- | --- | --- | --- | --- | --- |
| 1 | **Milestones** |  | 2010-06-18 → 2010-06-09 (-9d) | 295.81d? → 288d? |  | 218.87d → 192.89d |  |  |
| 3 | Imager Preliminary Design Review | 2010-06-03 → 2010-06-09 (+6d) | 2010-06-03 → 2010-06-09 (+6d) |  |  | 231.05d → 192.89d |  |  |
| 4 | IFS System Design Review | 2010-06-18 → 2010-05-04 (-45d) | 2010-06-18 → 2010-05-04 (-45d) |  |  |  |  |  |
| 5 | **Near-IR Imager and IFS** |  | 2011-04-21 → 2011-03-04 (-48d) | 490.68d? → 456.89d? | 9% → 12% |  |  |  |
| 6 | **Management** |  |  |  | 8% → 9% | 113.18d → 79.39d |  |  |
| 7 | **Monthly Reports** |  |  |  | 33% → 39% | 118.68d → 84.89d |  |  |
| 14 | Monthly Reports 7 | 2009-12-07 A | 2009-12-07 A |  | 0% → 100% | 358.05d → none |  |  |
| 40 | Cost Review | 2010-04-20 → 2010-04-23 (+3d) | 2010-06-03 → 2010-06-09 (+6d) |  |  | 230.06d → 192.67d |  |  |
| 41 | **Project Plan Maintenance** |  |  |  | 33% → 50% | 162.68d → 128.89d |  |  |
| 44 | Project Plan Maintenance 3 | 2009-12-04 A | 2009-12-04 A |  | 0% → 100% | 359.05d → none |  |  |
| 57 | Preliminary Design Report | 2010-05-07 → 2010-05-13 (+6d) | 2010-05-19 → 2010-05-25 (+6d) |  |  | 229.68d → 191.89d |  |  |
| 58 | Preliminary Design Review | 2010-06-02 → 2010-06-08 (+6d) | 2010-06-03 → 2010-06-09 (+6d) |  |  | 229.68d → 191.89d |  |  |
| 59 | **Science** |  | 2010-04-27 → 2010-04-30 (+3d) | 77.16d? → 80.76d? |  | 257.89d → 220.13d |  |  |
| 63 | **Common Observing Operations Concept Document** |  | 2010-04-27 → 2010-04-30 (+3d) | 77.16d? → 80.76d? |  | 257.89d → 220.13d |  |  |
| 65 | Final Version | 2010-04-09 → 2010-04-15 (+6d) | 2010-04-27 → 2010-04-30 (+3d) |  |  | 238.39d → 200.63d |  |  |
| 66 | **Instrument Design and Fabrication** |  | 2011-04-21 → 2011-03-04 (-48d) | 480.68d? → 446.89d? | 9% → 12% |  |  |  |
| 67 | **AO System to Instrument Interface Definitions** |  |  |  | 28% → 64% | 335.05d → 300.89d |  |  |
| 68 | Optical |  | 2009-09-16 A |  | 50% → 100% | 0d → none |  |  |
| 69 | Mechanical |  | 2009-09-24 A |  | 50% → 100% | 0d → none |  |  |
| 70 | Electronic/Electrical |  |  |  | 25% → 75% | 335.05d → 0d |  |  |
| 72 | Alignment and Calibration Concept for Instrument on AO System | 2010-01-06 A |  |  | 0% → 25% | 335.05d → 300.89d |  |  |
| 73 | **Shared Facilities** |  | 2010-05-06 → 2010-05-12 (+6d) | 230.85d? → 234.45d? | 27% → 36% | 250.2d → 212.44d |  |  |
| 74 | **AO System** |  | 2010-05-06 → 2010-05-12 (+6d) | 230.85d? → 234.45d? |  | 250.2d → 212.44d |  |  |
| 75 | **High Order AO Relay** |  | 2010-05-06 → 2010-05-12 (+6d) | 230.85d? → 234.45d? |  | 250.2d → 212.44d |  |  |
| 77 | RTC and Control Liason | 2010-04-20 → 2010-04-23 (+3d) | 2010-05-06 → 2010-05-12 (+6d) |  |  | 250.2d → 212.44d |  |  |
| 84 | **Nasmyth Enclosure** | 2010-03-25 → 2010-03-31 A (+6d) | 2010-05-06 → 2010-05-11 (+5d) |  | 0% → 50% | 250.71d → 212.96d |  |  |
| 85 | Requirements Liason | 2010-03-25 → 2010-03-31 A (+6d) | 2010-04-19 → 2010-04-23 (+4d) |  | 0% → 50% | 250.71d → 0d |  |  |
| 86 | Design Liason | 2010-04-19 → 2010-04-23 A (+4d) | 2010-05-06 → 2010-05-11 (+5d) |  | 0% → 50% | 250.71d → 212.96d |  |  |
| 87 | **Instrument** |  | 2011-04-21 → 2011-03-04 (-48d) | 472.68d? → 438.89d? | 5% → 7% |  |  |  |
| 88 | **IFS System Design Phase** |  | 2010-06-23 → 2010-05-07 (-47d) | 167.83d? → 134.04d? | 7% → 11% |  |  |  |
| 89 | **IFS Performance Budgets** |  | 2010-01-19 → 2010-03-16 (+56d) | 56.34d → 96.34d |  | 327.71d → 253.55d |  |  |
| 90 | Throughput |  | 2009-11-10 → 2010-01-05 (+56d) |  |  |  | 135FS+2mo → 135FS+4mo |  |
| 91 | Background |  | 2009-11-26 → 2010-01-21 (+56d) |  |  | 0d → 268.53d |  |  |
| 92 | Wavefront error | 2009-11-26 → 2010-01-21 (+56d) | 2009-12-04 → 2010-01-29 (+56d) |  |  | 0d → 15.84d |  |  |
| 93 | Spectroscopic performance |  | 2010-01-12 → 2010-03-09 (+56d) |  |  | 0.85d → 253.55d |  |  |
| 94 | Size and mass | 2010-01-12 → 2010-03-09 (+56d) | 2010-01-19 → 2010-03-16 (+56d) |  |  | 327.71d → 327.34d |  |  |
| 95 | **Trade Studies** |  | 2010-06-23 → 2010-05-07 (-47d) | 161.16d → 127.38d | 10% → 23% |  |  |  |
| 96 | FOV and spatial sampling |  | 2009-12-11 → 2010-02-05 (+56d) |  |  | 0d → 280.81d |  |  |
| 97 | Wavelength coverage and spatial sampling | 2009-12-11 A → 2009-11-10 A (-31d) | 2010-01-12 → 2009-12-11 (-32d) | 14.47d → 13.19d | 20% → 50% |  | 96, 90 → 96SS |  |
| 98 | Optimization of image slicing formats and spectrograph formats | 2010-01-12 → 2009-12-11 A (-32d) | 2010-02-22 → 2010-01-21 (-32d) | 20.25d → 23.77d | 0% → 20% | 0d → 291.85d | 93, 97 → 97 |  |
| 99 | Wavefront error allocations | 2010-06-08 → 2010-04-21 (-48d) | 2010-06-17 → 2010-04-30 (-48d) |  |  |  |  |  |
| 100 | Trade study report | 2010-06-17 → 2010-04-30 (-48d) | 2010-06-23 → 2010-05-07 (-47d) |  |  |  |  |  |
| 101 | **Conceptual Designs** | 2010-02-22 → 2010-01-05 (-48d) | 2010-06-21 → 2010-05-04 (-48d) |  |  |  |  |  |
| 102 | Development of design options | 2010-02-22 → 2010-01-05 (-48d) | 2010-04-27 → 2010-03-10 (-48d) |  |  |  | 98 → 90 |  |
| 103 | Evaluation of design options | 2010-04-27 → 2010-03-10 (-48d) | 2010-05-11 → 2010-03-24 (-48d) |  |  |  |  |  |
| 104 | Calibration and alignment issues | 2010-05-11 → 2010-03-24 (-48d) | 2010-05-19 → 2010-04-01 (-48d) |  |  |  |  |  |
| 105 | Downselect of conceptual design | 2010-05-19 → 2010-04-01 (-48d) | 2010-05-26 → 2010-04-08 (-48d) |  |  |  |  |  |
| 106 | Revised performance budgets | 2010-05-26 → 2010-04-08 (-48d) | 2010-06-01 → 2010-04-14 (-48d) |  |  |  |  |  |
| 107 | Performance budget report | 2010-06-01 → 2010-04-14 (-48d) | 2010-06-04 → 2010-04-20 (-45d) |  |  |  |  |  |
| 108 | Performance estimates | 2010-05-26 → 2010-04-08 (-48d) | 2010-06-08 → 2010-04-21 (-48d) |  |  |  |  |  |
| 109 | System requirements document | 2010-06-08 → 2010-04-21 (-48d) | 2010-06-14 → 2010-04-28 (-47d) |  |  |  |  |  |
| 110 | System design manual | 2010-06-14 → 2010-04-28 (-47d) | 2010-06-21 → 2010-05-04 (-48d) |  |  |  |  |  |
| 111 | **System Design Review** | 2010-06-14 → 2010-04-28 (-47d) | 2010-06-21 → 2010-05-05 (-47d) |  |  |  |  |  |
| 112 | System design report | 2010-06-14 → 2010-04-28 (-47d) | 2010-06-18 → 2010-05-03 (-46d) |  |  |  |  |  |
| 113 | System design review meeting | 2010-06-18 → 2010-05-03 (-46d) | 2010-06-21 → 2010-05-05 (-47d) |  |  |  |  |  |
| 114 | **IFS Preliminary Design Phase** | 2010-06-21 → 2010-05-05 (-47d) | 2011-04-21 → 2011-03-04 (-48d) |  |  |  |  |  |
| 115 | Initial AO system to instrument interface definitions | 2010-06-21 → 2010-05-05 (-47d) | 2010-06-30 → 2010-05-14 (-47d) |  |  |  |  |  |
| 116 | Alignment and calibration concept | 2010-06-30 → 2010-05-14 (-47d) | 2010-07-13 → 2010-05-26 (-48d) |  |  |  |  |  |
| 117 | Optical design | 2010-07-13 → 2010-05-26 (-48d) | 2010-11-17 → 2010-09-30 (-48d) |  |  |  |  |  |
| 118 | Mechanical design | 2010-08-25 → 2010-07-08 (-48d) | 2011-04-07 → 2011-02-18 (-48d) |  |  |  |  |  |
| 119 | Electronic design | 2011-02-09 → 2010-12-23 (-48d) | 2011-03-23 → 2011-02-03 (-48d) |  |  |  |  |  |
| 120 | Software design | 2011-02-09 → 2010-12-23 (-48d) | 2011-03-15 → 2011-01-26 (-48d) |  |  |  |  |  |
| 121 | Preliminary design report | 2011-04-07 → 2011-02-18 (-48d) | 2011-04-20 → 2011-03-03 (-48d) |  |  |  |  |  |
| 122 | Preliminary design review meeting | 2011-04-20 → 2011-03-03 (-48d) | 2011-04-21 → 2011-03-04 (-48d) |  |  |  |  |  |
| 123 | **Near-IR Imager and IFS Preliminary Design** |  | 2010-05-17 → 2010-05-21 (+4d) | 230d? → 234d? | 10% → 13% | 243.05d → 204.89d |  |  |
| 124 | **Imager Trade Studies** |  | 2009-11-27 → 2010-01-22 (+56d) | 108.5d? → 148.5d? | 46% → 34% | 364.55d → 290.39d |  |  |
| 125 | Imager Wavefront Error | 2009-11-02 → 2009-12-28 (+56d) | 2009-11-27 → 2010-01-22 (+56d) |  |  | 352.55d → 0d | 135FS+40d → 135FS+80d |  |
| 126 | Imager Pixel Scale |  | 2009-10-07 → 2010-01-20 (+105d) | 7.1d? → 14.7d? | 75% → 36% | 401.75d → 365.86d |  | resources Sean Adkins [62.5%]; Science Team [62.5%]; OE - Optical Engineer 2 [62.5%] → Sean Adkins [18.3%]; Science Team [62.5%]; OE - Optical Engineer 2 [62.5%] |
| 127 | Imager Short Wavelength Cut-off |  | 2009-10-07 A |  | 50% → 100% | 0.5d → none |  |  |
| 128 | **Imager Performance Budgets** |  | 2010-04-27 → 2010-04-30 (+3d) | 195.15d? → 198.75d? | 10% → 38% | 257.9d → 220.14d |  |  |

| ID | Task | Start | Finish | Duration | Complete | Total float | Predecessors | Other |
| --- | --- | --- | --- | --- | --- | --- | --- | --- |
| 129 | Imager Sensitivity |  | 2009-11-05 → 2009-12-03 (+28d) |  | 50% → 80% | 0d → 4.59d | 127FS+1mo → 127FS+2mo |  |
| 130 | Imager Background |  | 2009-11-11 → 2010-01-07 (+57d) | 4.5d? → 5.73d? | 50% → 80% | 367.78d → 0d | 129 → 129FS+1mo |  |
| 131 | Imager Companion Sensitivity | 2009-11-11 → 2010-01-08 A (+58d) | 2009-11-24 → 2010-01-20 (+57d) |  | 0% → 25% | 367.78d → 366.18d |  |  |
| 132 | Imager Wavefront Error | 2009-11-27 → 2010-01-22 A (+56d) | 2009-12-15 → 2010-02-09 (+56d) |  | 0% → 25% | 352.55d → 352.18d |  |  |
| 133 | Imager Size and Mass | 2010-04-20 A | 2010-04-27 → 2010-04-30 (+3d) |  | 0% → 25% | 257.9d → 220.14d |  |  |
| 134 | **Optical Design** |  | 2010-01-12 → 2010-01-15 (+3d) | 120.25d? → 124d? | 38% → 34% | 302.8d → 288.39d |  |  |
| 136 | **Optical Modeling** | 2009-11-02 A → 2009-11-30 A (+28d) | 2010-01-05 → 2010-01-15 (+10d) | 46.25d? → 35d? | 8% → 10% | 302.8d → 288.39d |  |  |
| 137 | Fore Optics | 2009-11-02 A → 2009-11-30 A (+28d) | 2009-11-16 → 2010-01-15 (+60d) | 10.9d? → 20d? | 10% → 20% | 0d → 288.39d |  | constraint none → start no earlier than 2009-11-29; resources OE - Optical Engineer 2 [50%]; Sean Adkins [50%]; Instrument Scientist [50%] → OE - Optical Engineer 2 [50%]; Sean Adkins [15.3%]; Instrument Scientist [50%] |
| 138 | Lyot Stop | 2009-11-16 → 2009-12-14 (+28d) | 2009-11-18 → 2010-01-04 (+47d) | 2d? → 2.5d? |  | 0d → 27.35d | 137 → 135FS+8w | constraint none → start no earlier than 2009-12-13 |
| 139 | Coronagraph | 2009-11-18 → 2010-01-04 (+47d) | 2009-12-01 → 2010-01-14 (+44d) |  |  | 0d → 27.35d |  |  |
| 140 | Imager Camera | 2009-12-01 A → 2009-12-07 (+6d) | 2009-12-22 → 2009-12-25 (+3d) |  | 10% → 0% | 230.15d → -3.6d | 139 → none | constraint none → start no earlier than 2009-12-06 |
| 141 | IFS Fold Mirror | 2009-12-22 → 2009-12-28 (+6d) |  |  |  | 302.8d → 268.64d |  |  |
| 143 | **Dewar** | 2009-11-16 → 2009-12-28 (+42d) | 2010-04-28 → 2010-05-04 (+6d) | 116.95d? → 91.45d? |  | 255.65d → -3.6d |  |  |
| 144 | **Cold Assemblies** | 2009-11-16 → 2009-12-28 (+42d) | 2010-04-20 → 2010-04-23 (+3d) | 110.45d? → 84.95d? |  | 255.65d → -3.6d |  |  |
| 145 | **Dewar Internal Structure** | 2010-03-24 → 2010-03-30 (+6d) | 2010-04-20 → 2010-04-23 (+3d) |  |  | 230.15d → -3.6d |  |  |
| 146 | Interface Specification | 2010-03-24 → 2010-03-30 (+6d) | 2010-03-25 → 2010-03-31 (+6d) |  |  | 230.15d → -3.6d |  |  |
| 147 | Mechanical Model | 2010-03-25 → 2010-03-31 (+6d) | 2010-04-08 → 2010-04-14 (+6d) |  |  | 230.15d → -3.6d |  |  |
| 148 | FEA | 2010-04-08 → 2010-04-14 (+6d) | 2010-04-20 → 2010-04-23 (+3d) |  |  | 230.43d → -3.6d |  |  |
| 149 | Thermal Analysis | 2010-04-08 → 2010-04-14 (+6d) | 2010-04-15 → 2010-04-21 (+6d) |  |  | 230.15d → 191.55d |  |  |
| 150 | **Fore Optics** | 2009-11-16 → 2010-01-15 (+60d) | 2009-12-30 → 2010-03-12 (+72d) | 32d? → 40.5d? |  | 300.88d → 27.35d |  |  |
| 151 | **Input Baffle & Coronagraph** | 2009-12-01 → 2010-01-15 (+45d) | 2009-12-30 → 2010-01-25 (+26d) | 21.5d? → 6.5d? |  | 275.38d → 27.35d |  |  |
| 152 | Interface Specification | 2009-12-01 → 2010-01-15 (+45d) | 2009-12-02 → 2010-01-18 (+47d) |  |  | 290.38d → 27.35d |  |  |
| 153 | Mechanical Model | 2009-12-23 → 2010-01-18 (+26d) | 2009-12-30 → 2010-01-25 (+26d) |  |  | 275.38d → 27.35d |  |  |
| 154 | **Re-imager** | 2009-11-16 → 2010-01-18 (+63d) | 2009-11-25 → 2010-01-26 (+62d) |  |  | 366.65d → 288.39d |  |  |
| 155 | Interface Specification | 2009-11-16 → 2010-01-18 (+63d) | 2009-11-18 → 2010-01-19 (+62d) |  |  | 366.65d → 288.39d |  |  |
| 156 | Mechanical Model | 2009-11-18 → 2010-01-19 (+62d) | 2009-11-25 → 2010-01-26 (+62d) |  |  | 366.65d → 288.39d |  |  |
| 157 | **Adjustable Lyot Stop** | 2009-11-18 → 2010-03-01 (+103d) | 2009-12-01 → 2010-03-12 (+101d) |  |  | 330.84d → 224.08d |  |  |
| 158 | Interface Specification | 2009-11-18 → 2010-03-01 (+103d) | 2009-11-20 → 2010-03-02 (+102d) |  |  | 330.84d → 224.08d | 138 → 138FS+8w |  |
| 159 | Mechanical Model | 2009-11-20 → 2010-03-03 (+103d) | 2009-12-01 → 2010-03-12 (+101d) |  |  | 330.84d → 224.08d |  |  |
| 160 | **Filter Wheels** | 2009-12-22 → 2009-12-28 (+6d) |  | 26.26d? → 22.67d? |  | 290.07d → 255.92d |  |  |
| 161 | **Mechanism** | 2009-12-22 → 2009-12-28 (+6d) |  | 26.26d? → 22.67d? |  | 290.07d → 255.92d |  |  |
| 162 | Interface Specification | 2009-12-22 → 2009-12-28 (+6d) | 2009-12-24 → 2009-12-29 (+5d) |  |  | 296.58d → 258.82d |  |  |
| 164 | Filter Specifications | 2009-12-24 → 2009-12-29 (+5d) |  |  |  | 290.07d → 255.92d |  |  |
| 165 | **Imager** | 2009-12-22 → 2009-12-28 (+6d) | 2010-03-17 → 2010-03-23 (+6d) |  |  | 230.15d → -3.6d |  |  |
| 166 | **Camera** | 2009-12-22 → 2009-12-28 (+6d) | 2010-01-04 → 2010-01-07 (+3d) |  |  | 230.15d → -3.6d |  |  |
| 167 | Interface Specification | 2009-12-22 → 2009-12-28 (+6d) | 2009-12-23 → 2009-12-29 (+6d) |  |  | 230.15d → -3.6d |  |  |
| 168 | Mechanical Model | 2009-12-23 → 2009-12-29 (+6d) | 2010-01-04 → 2010-01-07 (+3d) |  |  | 230.15d → -3.6d |  |  |
| 169 | **Detector Head** | 2010-01-04 → 2010-01-08 (+4d) | 2010-03-17 → 2010-03-23 (+6d) |  |  | 230.15d → -3.6d |  |  |
| 170 | **Mount** | 2010-01-04 → 2010-01-08 (+4d) | 2010-01-12 → 2010-01-15 (+3d) |  |  | 230.15d → -3.6d |  |  |
| 171 | Interface Specification | 2010-01-04 → 2010-01-08 (+4d) | 2010-01-05 → 2010-01-08 (+3d) |  |  | 230.15d → -3.6d |  |  |
| 172 | Mechanical Model | 2010-01-05 → 2010-01-11 (+6d) | 2010-01-12 → 2010-01-15 (+3d) |  |  | 230.15d → -3.6d |  |  |
| 173 | **Focus Mechanism** | 2010-01-12 → 2010-01-18 (+6d) | 2010-03-11 → 2010-03-17 (+6d) |  |  | 230.15d → -3.6d |  |  |
| 174 | Interface Specification | 2010-01-12 → 2010-01-18 (+6d) | 2010-02-08 → 2010-02-11 (+3d) |  |  | 230.15d → -3.6d |  |  |
| 175 | Mechanical Model | 2010-02-08 → 2010-02-12 (+4d) | 2010-03-11 → 2010-03-17 (+6d) |  |  | 230.15d → -3.6d |  |  |
| 176 | **Cooling Interface** | 2010-03-11 → 2010-03-17 (+6d) | 2010-03-17 → 2010-03-23 (+6d) |  |  | 230.15d → -3.6d |  |  |
| 177 | Interface Specification | 2010-03-11 → 2010-03-17 (+6d) | 2010-03-12 → 2010-03-18 (+6d) |  |  | 230.15d → -3.6d |  |  |
| 178 | Mechanical Model | 2010-03-12 → 2010-03-18 (+6d) | 2010-03-17 → 2010-03-23 (+6d) |  |  | 230.15d → -3.6d |  |  |
| 179 | **Warm Assemblies** | 2009-12-30 → 2010-01-25 (+26d) | 2010-04-28 → 2010-05-04 (+6d) | 84.95d? → 70.95d? |  | 256.2d → 27.35d |  |  |
| 180 | **Dewar Shell** | 2009-12-30 → 2010-01-25 (+26d) | 2010-04-28 → 2010-05-04 (+6d) | 84.95d? → 70.95d? |  | 256.2d → 27.35d |  |  |
| 181 | Interface Specification | 2009-12-31 → 2010-01-26 (+26d) | 2010-01-05 → 2010-01-29 (+24d) |  |  | 275.38d → 27.35d |  |  |
| 182 | Mechanical Model | 2010-01-05 → 2010-01-29 (+24d) | 2010-02-04 → 2010-03-02 (+26d) |  |  | 275.38d → 27.35d |  |  |
| 183 | Window Specifications | 2009-12-30 → 2010-01-25 (+26d) | 2009-12-31 → 2010-01-26 (+26d) |  |  | 275.38d → 27.35d |  |  |
| 184 | External Connections | 2010-04-26 → 2010-04-29 (+3d) | 2010-04-28 → 2010-05-04 (+6d) |  |  | 256.2d → 218.44d |  |  |
| 185 | Vacuum System Requirements | 2010-04-22 → 2010-04-28 (+6d) | 2010-04-26 → 2010-04-29 (+3d) |  |  | 256.2d → 218.44d |  |  |
| 186 | Cryogenic System Requirements | 2010-04-15 → 2010-04-21 (+6d) | 2010-04-22 → 2010-04-28 (+6d) |  |  | 256.2d → 218.44d |  |  |
| 187 | **Electronics** | 2010-03-11 → 2010-03-17 (+6d) | 2010-03-29 → 2010-04-01 (+3d) |  |  | 260.7d → 222.94d |  |  |
| 188 | **Motion Control** | 2010-03-11 → 2010-03-17 (+6d) | 2010-03-23 → 2010-03-26 (+3d) |  |  | 260.7d → 222.94d |  |  |
| 189 | Requirements | 2010-03-11 → 2010-03-17 (+6d) | 2010-03-18 → 2010-03-24 (+6d) |  |  | 260.7d → 222.94d |  |  |
| 190 | Initial Design | 2010-03-18 → 2010-03-24 (+6d) | 2010-03-23 → 2010-03-26 (+3d) |  |  | 260.7d → 222.94d |  |  |
| 191 | Power Control | 2010-03-23 → 2010-03-26 (+3d) | 2010-03-24 → 2010-03-30 (+6d) |  |  | 260.7d → 222.94d |  |  |
| 192 | Pressure Monitoring | 2010-03-24 → 2010-03-30 (+6d) | 2010-03-25 → 2010-03-31 (+6d) |  |  | 260.7d → 222.94d |  |  |
| 193 | Temperature Monitoring and Control | 2010-03-25 → 2010-03-31 (+6d) | 2010-03-29 → 2010-04-01 (+3d) |  |  | 266d → 228.24d |  |  |
| 194 | **Software** | 2010-03-11 → 2010-03-17 (+6d) | 2010-04-29 → 2010-05-05 (+6d) |  |  | 255.15d → 217.39d |  |  |
| 195 | Detector Control | 2010-04-20 → 2010-04-23 (+3d) | 2010-04-23 → 2010-04-28 (+5d) |  |  | 256.7d → 218.94d |  |  |
| 196 | Global Server | 2010-04-23 → 2010-04-28 (+5d) | 2010-04-28 → 2010-05-03 (+5d) |  |  | 256.7d → 218.94d |  |  |
| 197 | Motion Control | 2010-03-11 → 2010-03-17 (+6d) | 2010-03-16 → 2010-03-19 (+3d) |  |  | 258.89d → 221.13d |  |  |
| 198 | Power Control | 2010-03-16 → 2010-03-19 (+3d) | 2010-03-17 → 2010-03-22 (+5d) |  |  | 258.89d → 221.13d |  |  |
| 199 | Pressure Monitoring | 2010-03-17 → 2010-03-22 (+5d) | 2010-03-18 → 2010-03-23 (+5d) |  |  | 258.89d → 221.13d |  |  |
| 200 | Temperature Monitoring and Control | 2010-04-15 → 2010-04-21 (+6d) | 2010-04-20 → 2010-04-23 (+3d) |  |  | 238.39d → 200.63d |  |  |
| 201 | User Interface Requirements | 2010-04-20 → 2010-04-23 (+3d) | 2010-04-23 → 2010-04-29 (+6d) |  |  | 238.39d → 200.63d |  |  |

| ID | Task | Start | Finish | Duration | Total float |
| --- | --- | --- | --- | --- | --- |
| 202 | Data Reduction Tools | 2010-04-13 → 2010-04-16 (+3d) | 2010-04-29 → 2010-05-05 (+6d) |  | 255.15d → 217.39d |
| 203 | **Interfaces** | 2010-03-29 → 2010-04-01 (+3d) | 2010-05-17 → 2010-05-18 (+1d) | 35.85d? → 32.53d? | 243.1d → 208.66d |
| 204 | Mechanical Interface Requirements | 2010-04-29 → 2010-04-21 (-8d) | 2010-05-03 → 2010-04-23 (-10d) |  | 243.1d → 214.49d |
| 205 | Electronic Interface Requirements | 2010-03-29 → 2010-04-01 (+3d) | 2010-03-31 → 2010-04-06 (+6d) |  | 266d → 228.24d |
| 206 | Software Interface Requirements | 2010-04-23 → 2010-04-29 (+6d) | 2010-04-28 → 2010-05-03 (+5d) |  | 246.41d → 208.66d |
| 207 | Interface Control Document |  | 2010-05-17 → 2010-05-18 (+1d) |  | 243.1d → 208.66d |
| 208 | **Accessories** | 2010-04-29 → 2010-05-05 (+6d) | 2010-05-17 → 2010-05-21 (+4d) |  | 230.05d → 191.89d |
| 209 | **Alignment Tooling** | 2010-05-07 → 2010-05-13 (+6d) | 2010-05-17 → 2010-05-21 (+4d) |  | 243.05d → 204.89d |
| 210 | Initial Specifications | 2010-05-07 → 2010-05-13 (+6d) | 2010-05-10 → 2010-05-14 (+4d) |  | 243.05d → 204.89d |
| 211 | Mechanical Model | 2010-05-11 → 2010-05-17 (+6d) | 2010-05-17 → 2010-05-21 (+4d) |  | 243.05d → 204.89d |
| 212 | **Assembly Tooling** | 2010-04-29 → 2010-05-05 (+6d) | 2010-05-07 → 2010-05-13 (+6d) |  | 230.05d → 191.89d |
| 213 | Initial Specifications | 2010-04-29 → 2010-05-05 (+6d) | 2010-04-30 → 2010-05-06 (+6d) |  | 230.05d → 191.89d |
| 214 | Mechanical Model | 2010-04-30 → 2010-05-06 (+6d) | 2010-05-07 → 2010-05-13 (+6d) |  | 230.05d → 191.89d |

## Version 6 (saved 2010-01-20, file Imager_and_IFS_PD_Phase_v1_2_tracked_Dec09.mpp)

Last finish 2011-03-04 → 2011-01-27 (-36d). Complete tasks 18 → 19.

Changed:

| ID | Task | Start | Finish | Duration | Complete | Total float | Predecessors | Other |
| --- | --- | --- | --- | --- | --- | --- | --- | --- |
| 1 | **Milestones** |  | 2010-06-09 → 2010-05-24 (-16d) | 288d? → 276.26d? |  | 192.89d → 177.97d |  |  |
| 3 | Imager Preliminary Design Review | 2010-06-09 → 2010-05-24 (-16d) | 2010-06-09 → 2010-05-24 (-16d) |  |  | 192.89d → 177.97d |  |  |
| 4 | IFS System Design Review | 2010-05-04 → 2010-03-26 (-39d) | 2010-05-04 → 2010-03-26 (-39d) |  |  |  |  |  |
| 5 | **Near-IR Imager and IFS** |  | 2011-03-04 → 2011-01-27 (-36d) | 456.89d? → 430.22d? | 12% → 15% |  |  |  |
| 6 | **Management** |  |  |  | 9% → 10% | 79.39d → 52.72d |  |  |
| 7 | **Monthly Reports** |  |  |  | 39% → 44% | 84.89d → 58.22d |  |  |
| 15 | Monthly Reports 8 | 2010-01-05 A | 2010-01-05 A |  | 0% → 100% | 302.89d → none |  |  |
| 40 | Cost Review | 2010-04-23 → 2010-03-12 (-42d) | 2010-06-09 → 2010-04-27 (-43d) |  |  | 192.67d → 196.96d |  |  |
| 57 | Preliminary Design Report | 2010-05-13 → 2010-04-27 (-16d) | 2010-05-25 → 2010-05-07 (-18d) |  |  | 191.89d → 176.97d |  |  |
| 58 | Preliminary Design Review | 2010-06-08 → 2010-05-21 (-18d) | 2010-06-09 → 2010-05-25 (-15d) |  |  | 191.89d → 176.97d |  |  |
| 59 | **Science** |  | 2010-04-30 → 2010-04-27 (-3d) | 80.76d? → 77.76d? |  | 220.13d → 196.47d |  |  |
| 63 | **Common Observing Operations Concept Document** |  | 2010-04-30 → 2010-04-27 (-3d) | 80.76d? → 77.76d? |  | 220.13d → 196.47d |  |  |
| 65 | Final Version | 2010-04-15 → 2010-04-12 (-3d) | 2010-04-30 → 2010-04-27 (-3d) |  |  | 200.63d → 176.97d |  |  |
| 66 | **Instrument Design and Fabrication** |  | 2011-03-04 → 2011-01-27 (-36d) | 446.89d? → 420.22d? | 12% → 16% |  |  |  |
| 73 | **Shared Facilities** |  | 2010-05-12 → 2010-05-11 (-1d) | 234.45d? → 233.93d? |  | 212.44d → 186.29d |  |  |
| 74 | **AO System** |  | 2010-05-12 → 2010-05-07 (-5d) | 234.45d? → 231.45d? |  | 212.44d → 188.78d |  |  |
| 75 | **High Order AO Relay** |  | 2010-05-12 → 2010-05-07 (-5d) | 234.45d? → 231.45d? |  | 212.44d → 188.78d |  |  |
| 77 | RTC and Control Liason | 2010-04-23 → 2010-04-20 (-3d) | 2010-05-12 → 2010-05-07 (-5d) |  |  | 212.44d → 188.78d |  |  |
| 78 | **ADC** | 2009-11-30 → 2010-01-25 (+56d) | 2010-02-05 → 2010-03-12 (+35d) | 50d? → 35d? |  | 279.89d → 228.22d |  |  |
| 79 | Requirements Liason | 2009-11-30 → 2010-01-25 (+56d) | 2010-01-15 → 2010-02-19 (+35d) |  |  | 279.89d → 228.22d |  | constraint none → start no earlier than 2010-01-24 |
| 80 | Design Liason | 2010-01-18 → 2010-02-22 (+35d) | 2010-02-05 → 2010-03-12 (+35d) |  |  | 279.89d → 228.22d |  |  |
| 81 | **Calibration Faciltiy** | 2010-01-12 → 2010-02-09 (+28d) | 2010-02-23 → 2010-03-23 (+28d) |  |  | 268.64d → 221.97d |  |  |
| 82 | Requirements Liason | 2010-01-12 → 2010-02-09 (+28d) | 2010-01-26 → 2010-02-23 (+28d) |  |  | 268.64d → 221.97d | 142, 86 → 142 |  |
| 83 | Design Liason | 2010-01-26 → 2010-02-23 (+28d) | 2010-02-23 → 2010-03-23 (+28d) |  |  | 268.64d → 221.97d |  |  |
| 85 | Requirements Liason |  |  |  |  |  | 146, 76FS+7d → 146 |  |
| 87 | **Instrument** |  | 2011-03-04 → 2011-01-27 (-36d) | 438.89d? → 412.22d? | 7% → 12% |  |  |  |
| 88 | **IFS System Design Phase** |  | 2010-05-07 → 2010-04-15 (-22d) | 134.04d? → 118.34d? | 11% → 25% | 215.85d → 204.88d |  |  |
| 89 | **IFS Performance Budgets** |  | 2010-03-16 → 2010-04-15 (+30d) | 96.34d → 118.34d | 20% → 23% | 253.55d → 204.88d |  |  |
| 90 | Throughput |  | 2010-01-05 → 2010-02-04 (+30d) | 6.67d → 8.33d |  | 0d → 229.69d |  |  |
| 91 | Background |  | 2010-01-21 → 2010-02-22 (+32d) |  |  | 268.53d → 221.29d |  |  |
| 92 | Wavefront error | 2010-01-21 → 2010-02-22 (+32d) | 2010-01-29 → 2010-03-02 (+32d) |  |  | 15.84d → 268.53d |  |  |
| 93 | Spectroscopic performance |  | 2010-03-09 → 2010-04-08 (+30d) |  | 20% → 30% | 253.55d → 204.88d |  |  |
| 94 | Size and mass | 2010-03-09 → 2010-04-08 (+30d) | 2010-03-16 → 2010-04-15 (+30d) |  |  | 327.34d → 253.55d |  |  |
| 95 | **Trade Studies** |  | 2010-05-07 → 2010-03-31 (-37d) | 127.38d → 100.71d | 23% → 30% |  |  |  |
| 96 | FOV and spatial sampling |  | 2010-02-05 → 2010-03-09 (+32d) |  |  | 280.81d → 232.14d |  |  |
| 98 | Optimization of image slicing formats and spectrograph formats |  |  |  | 20% → 40% | 291.85d → 265.19d |  |  |
| 99 | Wavefront error allocations | 2010-04-21 → 2010-03-15 (-37d) | 2010-04-30 → 2010-03-25 (-36d) |  |  |  |  |  |
| 100 | Trade study report | 2010-04-30 → 2010-03-25 (-36d) | 2010-05-07 → 2010-03-31 (-37d) |  |  |  |  |  |
| 101 | **Conceptual Designs** | 2010-01-05 → 2009-11-30 A (-36d) | 2010-05-04 → 2010-03-29 (-36d) |  | 0% → 23% | 0d → 218d |  |  |
| 102 | Development of design options | 2010-01-05 → 2009-11-30 A (-36d) | 2010-03-10 → 2010-02-02 (-36d) |  | 0% → 43% |  | 90 → 90SS+1mo |  |
| 103 | Evaluation of design options | 2010-03-10 → 2010-02-02 (-36d) | 2010-03-24 → 2010-02-16 (-36d) |  |  |  |  |  |
| 104 | Calibration and alignment issues | 2010-03-24 → 2010-02-16 (-36d) | 2010-04-01 → 2010-02-23 (-37d) |  |  |  |  |  |
| 105 | Downselect of conceptual design | 2010-04-01 → 2010-02-23 (-37d) | 2010-04-08 → 2010-03-02 (-37d) |  |  |  |  |  |
| 106 | Revised performance budgets | 2010-04-08 → 2010-03-02 (-37d) | 2010-04-14 → 2010-03-08 (-37d) |  |  |  |  |  |
| 107 | Performance budget report | 2010-04-14 → 2010-03-08 (-37d) | 2010-04-20 → 2010-03-12 (-39d) |  |  |  |  |  |
| 108 | Performance estimates | 2010-04-08 → 2010-03-02 (-37d) | 2010-04-21 → 2010-03-15 (-37d) |  |  |  |  |  |
| 109 | System requirements document | 2010-04-21 → 2010-03-15 (-37d) | 2010-04-28 → 2010-03-22 (-37d) |  |  |  |  |  |
| 110 | System design manual | 2010-04-28 → 2010-03-22 (-37d) | 2010-05-04 → 2010-03-29 (-36d) |  |  |  |  |  |
| 111 | **System Design Review** | 2010-04-28 → 2010-03-22 (-37d) | 2010-05-05 → 2010-03-29 (-37d) |  |  |  |  |  |
| 112 | System design report | 2010-04-28 → 2010-03-22 (-37d) | 2010-05-03 → 2010-03-26 (-38d) |  |  |  |  |  |
| 113 | System design review meeting | 2010-05-03 → 2010-03-26 (-38d) | 2010-05-05 → 2010-03-29 (-37d) |  |  |  |  |  |
| 114 | **IFS Preliminary Design Phase** | 2010-05-05 → 2010-03-29 (-37d) | 2011-03-04 → 2011-01-27 (-36d) |  |  |  |  |  |
| 115 | Initial AO system to instrument interface definitions | 2010-05-05 → 2010-03-29 (-37d) | 2010-05-14 → 2010-04-07 (-37d) |  |  |  |  |  |
| 116 | Alignment and calibration concept | 2010-05-14 → 2010-04-07 (-37d) | 2010-05-26 → 2010-04-19 (-37d) |  |  |  |  |  |
| 117 | Optical design | 2010-05-26 → 2010-04-19 (-37d) | 2010-09-30 → 2010-08-25 (-36d) |  |  |  |  |  |
| 118 | Mechanical design | 2010-07-08 → 2010-06-02 (-36d) | 2011-02-18 → 2011-01-13 (-36d) |  |  |  |  |  |
| 119 | Electronic design | 2010-12-23 → 2010-11-17 (-36d) | 2011-02-03 → 2010-12-29 (-36d) |  |  |  |  |  |
| 120 | Software design | 2010-12-23 → 2010-11-17 (-36d) | 2011-01-26 → 2010-12-20 (-37d) |  |  |  |  |  |
| 121 | Preliminary design report | 2011-02-18 → 2011-01-13 (-36d) | 2011-03-03 → 2011-01-25 (-37d) |  |  |  |  |  |
| 122 | Preliminary design review meeting | 2011-03-03 → 2011-01-25 (-37d) | 2011-03-04 → 2011-01-27 (-36d) |  |  |  |  |  |
| 123 | **Near-IR Imager and IFS Preliminary Design** |  | 2010-05-21 → 2010-05-14 (-7d) | 234d? → 228.15d? | 13% → 16% | 204.89d → 184.08d |  |  |
| 124 | **Imager Trade Studies** |  |  |  | 34% → 44% | 290.39d → 263.73d |  |  |
| 126 | Imager Pixel Scale |  |  |  | 36% → 50% | 365.86d → 265.4d |  |  |
| 128 | **Imager Performance Budgets** |  | 2010-04-30 → 2010-04-27 (-3d) | 198.75d? → 195.15d? | 38% → 43% | 220.14d → 197.07d |  |  |
| 129 | Imager Sensitivity |  |  |  | 80% → 90% | 4.59d → 5.16d |  |  |
| 130 | Imager Background |  |  |  | 80% → 90% |  |  |  |
| 131 | Imager Companion Sensitivity |  |  |  | 25% → 40% | 366.18d → 265.72d |  |  |
| 133 | Imager Size and Mass |  | 2010-04-30 → 2010-04-27 (-3d) |  |  | 220.14d → 197.07d |  |  |
| 134 | **Optical Design** |  | 2010-01-15 → 2010-02-09 (+25d) | 124d? → 140.25d? | 34% → 43% | 288.39d → 245.47d |  |  |
| 136 | **Optical Modeling** |  | 2010-01-15 → 2010-02-02 (+18d) | 35d? → 46.25d? | 10% → 23% | 288.39d → 250.47d |  |  |

| ID | Task | Start | Finish | Duration | Complete | Total float | Predecessors | Other |
| --- | --- | --- | --- | --- | --- | --- | --- | --- |
| 137 | Fore Optics |  |  |  | 20% → 40% | 288.39d → 261.72d |  |  |
| 138 | Lyot Stop | 2009-12-14 A |  |  | 0% → 30% | 27.35d → 0d |  |  |
| 139 | Coronagraph | 2010-01-04 A |  |  | 0% → 25% |  |  |  |
| 140 | Imager Camera | 2009-12-07 → 2010-01-11 (+35d) | 2009-12-25 → 2010-01-29 (+35d) |  |  | -3.6d → 28.85d |  | constraint start no earlier than 2009-12-06 → start no earlier than 2010-01-11 |
| 141 | IFS Fold Mirror | 2009-12-28 → 2010-02-01 (+35d) | 2010-01-05 → 2010-02-02 (+28d) | 2.36d? → 1.25d? |  | 268.64d → 221.97d |  |  |
| 142 | Preliminary Design Performance Analysis | 2010-01-05 → 2010-02-02 (+28d) | 2010-01-12 → 2010-02-09 (+28d) |  |  | 268.64d → 221.97d |  |  |
| 143 | **Dewar** | 2009-12-28 → 2010-01-15 (+18d) | 2010-05-04 → 2010-04-15 (-19d) | 91.45d? → 64.95d? |  | -3.6d → 27.35d |  |  |
| 144 | **Cold Assemblies** | 2009-12-28 → 2010-01-15 (+18d) | 2010-04-23 → 2010-04-15 (-8d) | 84.95d? → 64.95d? |  | -3.6d → 27.35d |  |  |
| 145 | **Dewar Internal Structure** | 2010-03-30 → 2010-02-12 (-46d) | 2010-04-23 → 2010-03-11 (-43d) | 18.5d? → 20d? |  | -3.6d → 28.85d |  |  |
| 146 | Interface Specification | 2010-03-30 → 2010-02-12 (-46d) | 2010-03-31 → 2010-02-12 (-47d) |  |  | -3.6d → 28.85d | 178 → 168 |  |
| 147 | Mechanical Model | 2010-03-31 → 2010-02-15 (-44d) | 2010-04-14 → 2010-02-26 (-47d) |  |  | -3.6d → 28.85d |  |  |
| 148 | FEA | 2010-04-14 → 2010-03-02 (-43d) | 2010-04-23 → 2010-03-11 (-43d) |  |  | -3.6d → 27.35d |  |  |
| 149 | Thermal Analysis | 2010-04-14 → 2010-03-01 (-44d) | 2010-04-21 → 2010-03-05 (-47d) |  |  | 191.55d → 198d |  |  |
| 160 | **Filter Wheels** | 2009-12-28 → 2010-02-01 (+35d) | 2010-01-27 → 2010-02-26 (+30d) | 22.67d? → 19.76d? |  | 255.92d → 207.16d |  |  |
| 161 | **Mechanism** | 2009-12-28 → 2010-02-01 (+35d) | 2010-01-27 → 2010-02-26 (+30d) | 22.67d? → 19.76d? |  | 255.92d → 207.16d |  |  |
| 162 | Interface Specification | 2009-12-28 → 2010-02-01 (+35d) | 2009-12-29 → 2010-02-02 (+35d) |  |  | 258.82d → 207.16d |  |  |
| 163 | Mechanical Model | 2010-01-05 → 2010-02-04 (+30d) | 2010-01-27 → 2010-02-26 (+30d) |  |  | 255.92d → 207.16d |  |  |
| 164 | Filter Specifications | 2009-12-29 → 2010-02-02 (+35d) | 2010-01-04 → 2010-02-04 (+31d) | 2.43d? → 1.43d? |  | 255.92d → 207.16d |  |  |
| 165 | **Imager** | 2009-12-28 → 2010-02-01 (+35d) | 2010-03-23 → 2010-04-15 (+23d) | 61.45d? → 53.95d? |  | -3.6d → 28.85d |  |  |
| 166 | **Camera** | 2009-12-28 → 2010-02-01 (+35d) | 2010-01-07 → 2010-02-11 (+35d) |  |  | -3.6d → 28.85d |  |  |
| 167 | Interface Specification | 2009-12-28 → 2010-02-01 (+35d) | 2009-12-29 → 2010-02-02 (+35d) |  |  | -3.6d → 28.85d |  |  |
| 168 | Mechanical Model | 2009-12-29 → 2010-02-02 (+35d) | 2010-01-07 → 2010-02-11 (+35d) |  |  | -3.6d → 28.85d |  |  |
| 169 | **Detector Head** | 2010-01-08 → 2010-02-02 (+25d) | 2010-03-23 → 2010-04-15 (+23d) |  |  | -3.6d → 176.97d |  |  |
| 170 | **Mount** | 2010-01-08 → 2010-02-02 (+25d) | 2010-01-15 → 2010-02-10 (+26d) |  |  | -3.6d → 176.97d |  |  |
| 171 | Interface Specification | 2010-01-08 → 2010-02-02 (+25d) | 2010-01-08 → 2010-02-03 (+26d) |  |  | -3.6d → 176.97d | 168 → 167 |  |
| 172 | Mechanical Model | 2010-01-11 → 2010-02-03 (+23d) | 2010-01-15 → 2010-02-10 (+26d) |  |  | -3.6d → 176.97d |  |  |
| 173 | **Focus Mechanism** | 2010-01-18 → 2010-02-10 (+23d) | 2010-03-17 → 2010-04-09 (+23d) |  |  | -3.6d → 176.97d |  |  |
| 174 | Interface Specification | 2010-01-18 → 2010-02-10 (+23d) | 2010-02-11 → 2010-03-09 (+26d) |  |  | -3.6d → 176.97d |  |  |
| 175 | Mechanical Model | 2010-02-12 → 2010-03-09 (+25d) | 2010-03-17 → 2010-04-09 (+23d) |  |  | -3.6d → 176.97d |  |  |
| 176 | **Cooling Interface** | 2010-03-17 → 2010-04-09 (+23d) | 2010-03-23 → 2010-04-15 (+23d) |  |  | -3.6d → 204.28d |  |  |
| 177 | Interface Specification | 2010-03-17 → 2010-04-09 (+23d) | 2010-03-18 → 2010-04-12 (+25d) |  |  | -3.6d → 204.28d |  |  |
| 178 | Mechanical Model | 2010-03-18 → 2010-04-12 (+25d) | 2010-03-23 → 2010-04-15 (+23d) |  |  | -3.6d → 204.28d |  |  |
| 179 | **Warm Assemblies** |  | 2010-05-04 → 2010-03-18 (-47d) | 70.95d? → 38.5d? |  |  |  |  |
| 180 | **Dewar Shell** |  | 2010-05-04 → 2010-03-18 (-47d) | 70.95d? → 38.5d? |  |  |  |  |
| 184 | External Connections | 2010-04-29 → 2010-03-16 (-44d) | 2010-05-04 → 2010-03-18 (-47d) |  |  | 218.44d → 224.22d |  |  |
| 185 | Vacuum System Requirements | 2010-04-28 → 2010-03-15 (-44d) | 2010-04-29 → 2010-03-16 (-44d) |  |  | 218.44d → 224.22d |  |  |
| 186 | Cryogenic System Requirements | 2010-04-21 → 2010-03-08 (-44d) | 2010-04-28 → 2010-03-12 (-47d) |  |  | 218.44d → 224.22d |  |  |
| 187 | **Electronics** | 2010-03-17 → 2010-04-09 (+23d) | 2010-04-01 → 2010-04-27 (+26d) |  |  | 222.94d → 178.78d |  |  |
| 188 | **Motion Control** | 2010-03-17 → 2010-04-09 (+23d) | 2010-03-26 → 2010-04-21 (+26d) |  |  | 222.94d → 178.78d |  |  |
| 189 | Requirements | 2010-03-17 → 2010-04-09 (+23d) | 2010-03-24 → 2010-04-16 (+23d) |  |  | 222.94d → 178.78d |  |  |
| 190 | Initial Design | 2010-03-24 → 2010-04-16 (+23d) | 2010-03-26 → 2010-04-21 (+26d) |  |  | 222.94d → 178.78d |  |  |
| 191 | Power Control | 2010-03-26 → 2010-04-21 (+26d) | 2010-03-30 → 2010-04-22 (+23d) |  |  | 222.94d → 178.78d |  |  |
| 192 | Pressure Monitoring | 2010-03-30 → 2010-04-22 (+23d) | 2010-03-31 → 2010-04-23 (+23d) |  |  | 222.94d → 178.78d |  |  |
| 193 | Temperature Monitoring and Control | 2010-03-31 → 2010-04-23 (+23d) | 2010-04-01 → 2010-04-27 (+26d) |  |  | 228.24d → 184.08d |  |  |
| 194 | **Software** | 2010-03-17 → 2010-04-09 (+23d) | 2010-05-05 → 2010-04-30 (-5d) | 35.05d? → 14.55d? |  | 217.39d → 176.97d |  |  |
| 195 | Detector Control | 2010-04-23 → 2010-04-20 (-3d) | 2010-04-28 → 2010-04-23 (-5d) |  |  | 218.94d → 195.28d |  |  |
| 196 | Global Server | 2010-04-28 → 2010-04-23 (-5d) | 2010-05-03 → 2010-04-28 (-5d) |  |  | 218.94d → 195.28d |  |  |
| 197 | Motion Control | 2010-03-17 → 2010-04-09 (+23d) | 2010-03-19 → 2010-04-14 (+26d) |  |  | 221.13d → 176.97d |  |  |
| 198 | Power Control | 2010-03-19 → 2010-04-14 (+26d) | 2010-03-22 → 2010-04-15 (+24d) |  |  | 221.13d → 176.97d |  |  |
| 199 | Pressure Monitoring | 2010-03-22 → 2010-04-15 (+24d) | 2010-03-23 → 2010-04-16 (+24d) |  |  | 221.13d → 176.97d |  |  |
| 200 | Temperature Monitoring and Control | 2010-04-21 → 2010-04-16 (-5d) | 2010-04-23 → 2010-04-20 (-3d) |  |  | 200.63d → 176.97d |  |  |
| 201 | User Interface Requirements | 2010-04-23 → 2010-04-20 (-3d) | 2010-04-29 → 2010-04-26 (-3d) |  |  | 200.63d → 176.97d |  |  |
| 202 | Data Reduction Tools | 2010-04-16 → 2010-04-13 (-3d) | 2010-05-05 → 2010-04-30 (-5d) |  |  | 217.39d → 193.72d |  |  |
| 203 | **Interfaces** | 2010-04-01 → 2010-03-08 (-24d) | 2010-05-18 → 2010-05-14 (-4d) | 32.53d? → 49.15d? |  | 208.66d → 184.08d |  |  |
| 204 | Mechanical Interface Requirements | 2010-04-21 → 2010-03-08 (-44d) | 2010-04-23 → 2010-03-10 (-44d) |  |  | 214.49d → 220.28d |  |  |
| 205 | Electronic Interface Requirements | 2010-04-01 → 2010-04-27 (+26d) | 2010-04-06 → 2010-04-29 (+23d) |  |  | 228.24d → 184.08d |  |  |
| 206 | Software Interface Requirements | 2010-04-29 → 2010-04-26 (-3d) | 2010-05-03 → 2010-04-28 (-5d) |  |  | 208.66d → 184.99d |  |  |
| 207 | Interface Control Document | 2010-05-03 → 2010-04-29 (-4d) | 2010-05-18 → 2010-05-14 (-4d) |  |  | 208.66d → 184.08d |  |  |
| 208 | **Accessories** | 2010-05-05 → 2010-03-22 (-44d) | 2010-05-21 → 2010-04-07 (-44d) |  |  | 191.89d → 197.22d |  |  |
| 209 | **Alignment Tooling** | 2010-05-13 → 2010-03-30 (-44d) | 2010-05-21 → 2010-04-07 (-44d) |  |  | 204.89d → 210.22d |  |  |
| 210 | Initial Specifications | 2010-05-13 → 2010-03-30 (-44d) | 2010-05-14 → 2010-03-31 (-44d) |  |  | 204.89d → 210.22d |  |  |
| 211 | Mechanical Model | 2010-05-17 → 2010-04-01 (-46d) | 2010-05-21 → 2010-04-07 (-44d) |  |  | 204.89d → 210.22d |  |  |
| 212 | **Assembly Tooling** | 2010-05-05 → 2010-03-22 (-44d) | 2010-05-13 → 2010-03-30 (-44d) |  |  | 191.89d → 197.22d |  |  |
| 213 | Initial Specifications | 2010-05-05 → 2010-03-22 (-44d) | 2010-05-06 → 2010-03-23 (-44d) |  |  | 191.89d → 197.22d |  |  |
| 214 | Mechanical Model | 2010-05-06 → 2010-03-23 (-44d) | 2010-05-13 → 2010-03-30 (-44d) |  |  | 191.89d → 197.22d |  |  |

## Version 7 (saved 2010-02-19, file Imager_and_IFS_PD_Phase_v1_2_tracked_Jan10.mpp)

Last finish 2011-01-27 → 2011-01-17 (-10d). Complete tasks 19 → 23.

Changed:

| ID | Task | Start | Finish | Duration | Complete | Total float | Other |
| --- | --- | --- | --- | --- | --- | --- | --- |
| 1 | **Milestones** |  | 2010-05-24 → 2010-06-14 (+21d) | 276.26d? → 291.26d? |  | 177.97d → 155.67d |  |
| 3 | Imager Preliminary Design Review | 2010-05-24 → 2010-06-14 (+21d) | 2010-05-24 → 2010-06-14 (+21d) |  |  | 177.97d → 155.67d |  |
| 4 | IFS System Design Review | 2010-03-26 → 2010-03-17 (-9d) | 2010-03-26 → 2010-03-17 (-9d) |  |  |  |  |
| 5 | **Near-IR Imager and IFS** |  | 2011-01-27 → 2011-01-17 (-10d) | 430.22d? → 422.92d? | 15% → 20% |  |  |
| 6 | **Management** |  |  |  | 10% → 11% | 52.72d → 45.42d |  |
| 7 | **Monthly Reports** |  |  |  | 44% → 50% | 58.22d → 50.92d |  |
| 16 | Monthly Reports 9 | 2010-02-05 A | 2010-02-05 A |  | 0% → 100% | 253.22d → none |  |
| 26 | **Project Meetings** | 2010-01-15 A |  |  | 0% → 9% | 52.72d → 45.42d |  |
| 27 | Project Meeting 1 | 2010-01-15 A | 2010-01-15 A |  | 0% → 100% | 268.72d → none |  |
| 40 | Cost Review | 2010-03-12 → 2010-03-31 (+19d) | 2010-04-27 → 2010-05-14 (+17d) |  |  | 196.96d → 176.15d |  |
| 57 | Preliminary Design Report | 2010-04-27 → 2010-05-18 (+21d) | 2010-05-07 → 2010-05-28 (+21d) |  |  | 176.97d → 154.67d |  |
| 58 | Preliminary Design Review | 2010-05-21 → 2010-06-11 (+21d) | 2010-05-25 → 2010-06-15 (+21d) |  |  | 176.97d → 154.67d |  |
| 59 | **Science** | 2010-01-08 → 2010-01-22 (+14d) | 2010-04-27 → 2010-05-18 (+21d) | 77.76d? → 82.76d? |  | 196.47d → 174.17d |  |
| 63 | **Common Observing Operations Concept Document** | 2010-01-08 → 2010-03-22 (+73d) | 2010-04-27 → 2010-05-18 (+21d) | 77.76d? → 41.76d? |  | 196.47d → 174.17d |  |
| 64 | Initial Draft | 2010-01-08 → 2010-03-22 (+73d) | 2010-02-04 → 2010-04-16 (+71d) |  |  | 315.3d → 196.17d | constraint none → start no earlier than 2010-03-21 |
| 65 | Final Version | 2010-04-12 → 2010-05-03 (+21d) | 2010-04-27 → 2010-05-18 (+21d) |  |  | 176.97d → 154.67d |  |
| 66 | **Instrument Design and Fabrication** |  | 2011-01-27 → 2011-01-17 (-10d) | 420.22d? → 412.92d? | 16% → 21% |  |  |
| 73 | **Shared Facilities** |  | 2010-05-11 → 2010-05-28 (+17d) | 233.93d? → 246.45d? |  | 186.29d → 166.47d |  |
| 74 | **AO System** |  | 2010-05-07 → 2010-05-28 (+21d) | 231.45d? → 246.45d? |  | 188.78d → 166.47d |  |
| 75 | **High Order AO Relay** |  | 2010-05-07 → 2010-05-28 (+21d) | 231.45d? → 246.45d? |  | 188.78d → 166.47d |  |
| 77 | RTC and Control Liason | 2010-04-20 → 2010-05-11 (+21d) | 2010-05-07 → 2010-05-28 (+21d) |  |  | 188.78d → 166.47d |  |
| 81 | **Calibration Faciltiy** | 2010-02-09 → 2010-03-02 (+21d) | 2010-03-23 → 2010-04-13 (+21d) |  |  | 221.97d → 199.67d |  |
| 82 | Requirements Liason | 2010-02-09 → 2010-03-02 (+21d) | 2010-02-23 → 2010-03-16 (+21d) |  |  | 221.97d → 199.67d |  |
| 83 | Design Liason | 2010-02-23 → 2010-03-16 (+21d) | 2010-03-23 → 2010-04-13 (+21d) |  |  | 221.97d → 199.67d |  |
| 87 | **Instrument** |  | 2011-01-27 → 2011-01-17 (-10d) | 412.22d? → 404.92d? | 12% → 18% |  |  |
| 88 | **IFS System Design Phase** |  |  |  | 25% → 42% | 204.88d → 197.58d |  |
| 89 | **IFS Performance Budgets** |  |  |  | 23% → 31% | 204.88d → 197.58d |  |
| 90 | Throughput |  |  |  | 40% → 70% | 229.69d → 222.39d |  |
| 95 | **Trade Studies** |  | 2010-03-31 → 2010-03-22 (-9d) | 100.71d → 93.41d | 30% → 36% |  |  |
| 97 | Wavelength coverage and spatial sampling |  | 2009-12-11 → 2010-01-01 (+21d) |  |  | 0d → 267.5d |  |
| 98 | Optimization of image slicing formats and spectrograph formats |  | 2010-01-21 → 2010-02-04 (+14d) | 23.77d → 13.49d |  | 265.19d → 247.3d |  |
| 99 | Wavefront error allocations | 2010-03-15 → 2010-03-04 (-11d) | 2010-03-25 → 2010-03-15 (-10d) |  |  |  |  |
| 100 | Trade study report | 2010-03-25 → 2010-03-15 (-10d) | 2010-03-31 → 2010-03-22 (-9d) |  |  |  |  |
| 101 | **Conceptual Designs** | 2009-11-30 A → 2009-12-07 A (+7d) | 2010-03-29 → 2010-03-17 (-12d) | 85.22d? → 72.92d? | 23% → 55% |  |  |
| 102 | Development of design options | 2009-11-30 A → 2009-12-07 A (+7d) | 2010-02-02 → 2010-01-21 A (-12d) | 46.07d → 33.77d | 43% → 100% | 0d → none | constraint none → start no earlier than 2009-12-06; resources Sean Adkins [50%]; Instrument Scientist [50%]; OE - Sergey Panteleev [17%]; ME - TBD [50%] → Sean Adkins [50%]; Instrument Scientist [50%]; OE - Sergey Panteleev [19.4%]; ME - TBD [57.4%] |
| 103 | Evaluation of design options | 2010-02-02 → 2010-01-21 A (-12d) | 2010-02-16 → 2010-02-04 (-12d) |  | 0% → 50% |  |  |
| 104 | Calibration and alignment issues | 2010-02-16 → 2010-02-04 (-12d) | 2010-02-23 → 2010-02-12 (-11d) |  |  |  |  |
| 105 | Downselect of conceptual design | 2010-02-23 → 2010-02-12 A (-11d) | 2010-03-02 → 2010-02-19 (-11d) |  | 0% → 50% |  |  |
| 106 | Revised performance budgets | 2010-03-02 → 2010-02-19 (-11d) | 2010-03-08 → 2010-02-25 (-11d) |  |  |  |  |
| 107 | Performance budget report | 2010-03-08 → 2010-02-25 (-11d) | 2010-03-12 → 2010-03-03 (-9d) |  |  |  |  |
| 108 | Performance estimates | 2010-03-02 → 2010-02-19 (-11d) | 2010-03-15 → 2010-03-04 (-11d) |  |  |  |  |
| 109 | System requirements document | 2010-03-15 → 2010-03-04 (-11d) | 2010-03-22 → 2010-03-11 (-11d) |  |  |  |  |
| 110 | System design manual | 2010-03-22 → 2010-03-11 (-11d) | 2010-03-29 → 2010-03-17 (-12d) |  |  |  |  |
| 111 | **System Design Review** | 2010-03-22 → 2010-03-11 (-11d) | 2010-03-29 → 2010-03-18 (-11d) |  |  |  |  |
| 112 | System design report | 2010-03-22 → 2010-03-11 (-11d) | 2010-03-26 → 2010-03-16 (-10d) |  |  |  |  |
| 113 | System design review meeting | 2010-03-26 → 2010-03-16 (-10d) | 2010-03-29 → 2010-03-18 (-11d) |  |  |  |  |
| 114 | **IFS Preliminary Design Phase** | 2010-03-29 → 2010-03-18 (-11d) | 2011-01-27 → 2011-01-17 (-10d) |  |  |  |  |
| 115 | Initial AO system to instrument interface definitions | 2010-03-29 → 2010-03-18 (-11d) | 2010-04-07 → 2010-03-29 (-9d) |  |  |  |  |
| 116 | Alignment and calibration concept | 2010-04-07 → 2010-03-29 (-9d) | 2010-04-19 → 2010-04-08 (-11d) |  |  |  |  |
| 117 | Optical design | 2010-04-19 → 2010-04-08 (-11d) | 2010-08-25 → 2010-08-13 (-12d) |  |  |  |  |
| 118 | Mechanical design | 2010-06-02 → 2010-05-21 (-12d) | 2011-01-13 → 2011-01-03 (-10d) |  |  |  |  |
| 119 | Electronic design | 2010-11-17 → 2010-11-05 (-12d) | 2010-12-29 → 2010-12-17 (-12d) |  |  |  |  |
| 120 | Software design | 2010-11-17 → 2010-11-05 (-12d) | 2010-12-20 → 2010-12-09 (-11d) |  |  |  |  |
| 121 | Preliminary design report | 2011-01-13 → 2011-01-03 (-10d) | 2011-01-25 → 2011-01-14 (-11d) |  |  |  |  |
| 122 | Preliminary design review meeting | 2011-01-25 → 2011-01-14 (-11d) | 2011-01-27 → 2011-01-17 (-10d) |  |  |  |  |
| 123 | **Near-IR Imager and IFS Preliminary Design** |  | 2010-05-14 → 2010-06-04 (+21d) | 228.15d? → 243.15d? | 16% → 25% | 184.08d → 161.77d |  |
| 124 | **Imager Trade Studies** |  |  |  | 44% → 71% | 263.73d → 256.43d |  |
| 126 | Imager Pixel Scale |  |  |  | 50% → 90% | 265.4d → 258.1d |  |
| 128 | **Imager Performance Budgets** |  |  |  | 43% → 48% | 197.07d → 189.77d |  |
| 131 | Imager Companion Sensitivity |  |  |  | 40% → 70% | 265.72d → 258.42d |  |
| 134 | **Optical Design** |  | 2010-02-09 → 2010-03-02 (+21d) | 140.25d? → 155.25d? | 43% → 60% | 245.47d → 199.67d |  |
| 136 | **Optical Modeling** |  | 2010-02-02 → 2010-02-23 (+21d) | 46.25d? → 61.25d? | 23% → 50% | 250.47d → 199.67d |  |
| 137 | Fore Optics |  |  |  | 40% → 90% | 261.72d → 0d |  |
| 138 | Lyot Stop |  |  |  | 30% → 50% |  |  |
| 139 | Coronagraph |  |  |  | 25% → 50% | 27.35d → 0d |  |
| 140 | Imager Camera | 2010-01-11 → 2010-02-01 (+21d) | 2010-01-29 → 2010-02-19 (+21d) |  |  | 28.85d → 0d | constraint start no earlier than 2010-01-11 → start no earlier than 2010-01-31 |
| 141 | IFS Fold Mirror | 2010-02-01 → 2010-02-22 (+21d) | 2010-02-02 → 2010-02-23 (+21d) |  |  | 221.97d → 199.67d |  |
| 142 | Preliminary Design Performance Analysis | 2010-02-02 → 2010-02-23 (+21d) | 2010-02-09 → 2010-03-02 (+21d) |  |  | 221.97d → 199.67d |  |
| 143 | **Dewar** | 2010-01-15 A | 2010-04-15 → 2010-05-06 (+21d) | 64.95d? → 79.95d? | 0% → 5% | 27.35d → 181.97d |  |
| 144 | **Cold Assemblies** | 2010-01-15 A | 2010-04-15 → 2010-05-06 (+21d) | 64.95d? → 79.95d? | 0% → 5% | 27.35d → 181.97d |  |

| ID | Task | Start | Finish | Duration | Complete | Total float |
| --- | --- | --- | --- | --- | --- | --- |
| 145 | **Dewar Internal Structure** | 2010-02-12 → 2010-03-05 (+21d) | 2010-03-11 → 2010-03-31 (+20d) | 20d? → 18.5d? |  | 28.85d → 13.85d |
| 146 | Interface Specification | 2010-02-12 → 2010-03-05 (+21d) | 2010-02-12 → 2010-03-05 (+21d) |  |  | 28.85d → 13.85d |
| 147 | Mechanical Model | 2010-02-15 → 2010-03-08 (+21d) | 2010-02-26 → 2010-03-19 (+21d) |  |  | 28.85d → 13.85d |
| 148 | FEA | 2010-03-02 → 2010-03-22 (+20d) | 2010-03-11 → 2010-03-31 (+20d) |  |  | 27.35d → 13.85d |
| 149 | Thermal Analysis | 2010-03-01 → 2010-03-22 (+21d) | 2010-03-05 → 2010-03-26 (+21d) |  |  | 198d → 175d |
| 150 | **Fore Optics** | 2010-01-15 A |  |  | 0% → 14% | 27.35d → 221.42d |
| 151 | **Input Baffle & Coronagraph** | 2010-01-15 A |  |  | 0% → 17% | 27.35d → 0d |
| 152 | Interface Specification | 2010-01-15 A |  |  | 0% → 75% | 27.35d → 0d |
| 154 | **Re-imager** | 2010-01-18 A |  |  | 0% → 17% | 261.72d → 254.42d |
| 155 | Interface Specification | 2010-01-18 A |  |  | 0% → 75% | 288.39d → 254.42d |
| 157 | **Adjustable Lyot Stop** | 2010-03-01 A |  |  | 0% → 8% | 197.42d → 190.11d |
| 158 | Interface Specification | 2010-03-01 A |  |  | 0% → 50% | 224.08d → 190.11d |
| 160 | **Filter Wheels** | 2010-02-01 → 2010-02-22 A (+21d) | 2010-02-26 → 2010-03-19 (+21d) |  | 0% → 6% | 207.16d → 184.85d |
| 161 | **Mechanism** | 2010-02-01 → 2010-02-22 A (+21d) | 2010-02-26 → 2010-03-19 (+21d) |  | 0% → 7% | 207.16d → 184.85d |
| 162 | Interface Specification | 2010-02-01 → 2010-02-22 A (+21d) | 2010-02-02 → 2010-02-23 (+21d) |  | 0% → 75% | 207.16d → 184.85d |
| 163 | Mechanical Model | 2010-02-04 → 2010-02-25 (+21d) | 2010-02-26 → 2010-03-19 (+21d) |  |  | 207.16d → 184.85d |
| 164 | Filter Specifications | 2010-02-02 → 2010-02-23 (+21d) | 2010-02-04 → 2010-02-25 (+21d) |  |  | 207.16d → 184.85d |
| 165 | **Imager** | 2010-02-01 → 2010-02-22 A (+21d) | 2010-04-15 → 2010-05-06 (+21d) |  | 0% → 3% | 28.85d → 181.97d |
| 166 | **Camera** | 2010-02-01 → 2010-02-22 (+21d) | 2010-02-11 → 2010-03-04 (+21d) |  |  | 28.85d → 13.85d |
| 167 | Interface Specification | 2010-02-01 → 2010-02-22 (+21d) | 2010-02-02 → 2010-02-23 (+21d) |  |  | 28.85d → 13.85d |
| 168 | Mechanical Model | 2010-02-02 → 2010-02-23 (+21d) | 2010-02-11 → 2010-03-04 (+21d) |  |  | 28.85d → 13.85d |
| 169 | **Detector Head** | 2010-02-02 → 2010-02-23 A (+21d) | 2010-04-15 → 2010-05-06 (+21d) |  | 0% → 4% | 176.97d → 181.97d |
| 170 | **Mount** | 2010-02-02 → 2010-02-23 A (+21d) | 2010-02-10 → 2010-03-03 (+21d) |  | 0% → 17% | 176.97d → 154.67d |
| 171 | Interface Specification | 2010-02-02 → 2010-02-23 A (+21d) | 2010-02-03 → 2010-02-24 A (+21d) |  | 0% → 100% | 176.97d → none |
| 172 | Mechanical Model | 2010-02-03 → 2010-02-24 (+21d) | 2010-02-10 → 2010-03-03 (+21d) |  |  | 176.97d → 154.67d |
| 173 | **Focus Mechanism** | 2010-02-10 → 2010-03-03 (+21d) | 2010-04-09 → 2010-04-30 (+21d) |  |  | 176.97d → 154.67d |
| 174 | Interface Specification | 2010-02-10 → 2010-03-03 (+21d) | 2010-03-09 → 2010-03-30 (+21d) |  |  | 176.97d → 154.67d |
| 175 | Mechanical Model | 2010-03-09 → 2010-03-30 (+21d) | 2010-04-09 → 2010-04-30 (+21d) |  |  | 176.97d → 154.67d |
| 176 | **Cooling Interface** | 2010-04-09 → 2010-04-30 (+21d) | 2010-04-15 → 2010-05-06 (+21d) |  |  | 204.28d → 181.97d |
| 177 | Interface Specification | 2010-04-09 → 2010-04-30 (+21d) | 2010-04-12 → 2010-05-03 (+21d) |  |  | 204.28d → 181.97d |
| 178 | Mechanical Model | 2010-04-12 → 2010-05-03 (+21d) | 2010-04-15 → 2010-05-06 (+21d) |  |  | 204.28d → 181.97d |
| 179 | **Warm Assemblies** | 2010-01-25 A | 2010-03-18 → 2010-04-08 (+21d) | 38.5d? → 53.5d? | 0% → 5% | 27.35d → 201.92d |
| 180 | **Dewar Shell** | 2010-01-25 A | 2010-03-18 → 2010-04-08 (+21d) | 38.5d? → 53.5d? | 0% → 7% | 27.35d → 201.92d |
| 181 | Interface Specification | 2010-01-26 A |  |  | 0% → 50% |  |
| 183 | Window Specifications | 2010-01-25 A |  |  | 0% → 50% | 27.35d → 0d |
| 184 | External Connections | 2010-03-16 → 2010-04-06 (+21d) | 2010-03-18 → 2010-04-08 (+21d) |  |  | 224.22d → 201.92d |
| 185 | Vacuum System Requirements | 2010-03-15 → 2010-04-05 (+21d) | 2010-03-16 → 2010-04-06 (+21d) |  |  | 224.22d → 201.92d |
| 186 | Cryogenic System Requirements | 2010-03-08 → 2010-03-29 (+21d) | 2010-03-12 → 2010-04-02 (+21d) |  |  | 224.22d → 201.92d |
| 187 | **Electronics** | 2010-04-09 → 2010-04-30 (+21d) | 2010-04-27 → 2010-05-18 (+21d) |  |  | 178.78d → 156.47d |
| 188 | **Motion Control** | 2010-04-09 → 2010-04-30 (+21d) | 2010-04-21 → 2010-05-12 (+21d) |  |  | 178.78d → 156.47d |
| 189 | Requirements | 2010-04-09 → 2010-04-30 (+21d) | 2010-04-16 → 2010-05-07 (+21d) |  |  | 178.78d → 156.47d |
| 190 | Initial Design | 2010-04-16 → 2010-05-07 (+21d) | 2010-04-21 → 2010-05-12 (+21d) |  |  | 178.78d → 156.47d |
| 191 | Power Control | 2010-04-21 → 2010-05-12 (+21d) | 2010-04-22 → 2010-05-13 (+21d) |  |  | 178.78d → 156.47d |
| 192 | Pressure Monitoring | 2010-04-22 → 2010-05-13 (+21d) | 2010-04-23 → 2010-05-14 (+21d) |  |  | 178.78d → 156.47d |
| 193 | Temperature Monitoring and Control | 2010-04-23 → 2010-05-14 (+21d) | 2010-04-27 → 2010-05-18 (+21d) |  |  | 184.08d → 161.77d |
| 194 | **Software** | 2010-04-09 → 2010-04-30 (+21d) | 2010-04-30 → 2010-05-21 (+21d) |  |  | 176.97d → 154.67d |
| 195 | Detector Control | 2010-04-20 → 2010-05-11 (+21d) | 2010-04-23 → 2010-05-14 (+21d) |  |  | 195.28d → 172.97d |
| 196 | Global Server | 2010-04-23 → 2010-05-14 (+21d) | 2010-04-28 → 2010-05-19 (+21d) |  |  | 195.28d → 172.97d |
| 197 | Motion Control | 2010-04-09 → 2010-04-30 (+21d) | 2010-04-14 → 2010-05-05 (+21d) |  |  | 176.97d → 154.67d |
| 198 | Power Control | 2010-04-14 → 2010-05-05 (+21d) | 2010-04-15 → 2010-05-06 (+21d) |  |  | 176.97d → 154.67d |
| 199 | Pressure Monitoring | 2010-04-15 → 2010-05-06 (+21d) | 2010-04-16 → 2010-05-07 (+21d) |  |  | 176.97d → 154.67d |
| 200 | Temperature Monitoring and Control | 2010-04-16 → 2010-05-07 (+21d) | 2010-04-20 → 2010-05-11 (+21d) |  |  | 176.97d → 154.67d |
| 201 | User Interface Requirements | 2010-04-20 → 2010-05-11 (+21d) | 2010-04-26 → 2010-05-17 (+21d) |  |  | 176.97d → 154.67d |
| 202 | Data Reduction Tools | 2010-04-13 → 2010-05-04 (+21d) | 2010-04-30 → 2010-05-21 (+21d) |  |  | 193.72d → 171.42d |
| 203 | **Interfaces** | 2010-03-08 → 2010-03-29 (+21d) | 2010-05-14 → 2010-06-04 (+21d) |  |  | 184.08d → 161.77d |
| 204 | Mechanical Interface Requirements | 2010-03-08 → 2010-03-29 (+21d) | 2010-03-10 → 2010-03-31 (+21d) |  |  | 220.28d → 197.97d |
| 205 | Electronic Interface Requirements | 2010-04-27 → 2010-05-18 (+21d) | 2010-04-29 → 2010-05-20 (+21d) |  |  | 184.08d → 161.77d |
| 206 | Software Interface Requirements | 2010-04-26 → 2010-05-17 (+21d) | 2010-04-28 → 2010-05-19 (+21d) |  |  | 184.99d → 162.69d |
| 207 | Interface Control Document | 2010-04-29 → 2010-05-20 (+21d) | 2010-05-14 → 2010-06-04 (+21d) |  |  | 184.08d → 161.77d |
| 208 | **Accessories** | 2010-03-22 → 2010-04-12 (+21d) | 2010-04-07 → 2010-04-28 (+21d) |  |  | 197.22d → 174.92d |
| 209 | **Alignment Tooling** | 2010-03-30 → 2010-04-20 (+21d) | 2010-04-07 → 2010-04-28 (+21d) |  |  | 210.22d → 187.92d |
| 210 | Initial Specifications | 2010-03-30 → 2010-04-20 (+21d) | 2010-03-31 → 2010-04-21 (+21d) |  |  | 210.22d → 187.92d |
| 211 | Mechanical Model | 2010-04-01 → 2010-04-22 (+21d) | 2010-04-07 → 2010-04-28 (+21d) |  |  | 210.22d → 187.92d |
| 212 | **Assembly Tooling** | 2010-03-22 → 2010-04-12 (+21d) | 2010-03-30 → 2010-04-20 (+21d) |  |  | 197.22d → 174.92d |
| 213 | Initial Specifications | 2010-03-22 → 2010-04-12 (+21d) | 2010-03-23 → 2010-04-13 (+21d) |  |  | 197.22d → 174.92d |
| 214 | Mechanical Model | 2010-03-23 → 2010-04-13 (+21d) | 2010-03-30 → 2010-04-20 (+21d) |  |  | 197.22d → 174.92d |

## Version 8 (saved 2010-03-23, file Imager_and_IFS_PD_Phase_v1_2_tracked_Feb10.mpp)

Last finish stays 2011-01-17. Complete tasks 23 → 32.

Removed: 62 Meeting 2; 77 RTC and Control Liason

Changed:

| ID | Task | Start | Finish | Duration | Complete | Total float | Predecessors | Other |
| --- | --- | --- | --- | --- | --- | --- | --- | --- |
| 1 | **Milestones** |  |  | 291.26d? → 291d? |  | 155.67d → 155.92d |  |  |
| 5 | **Near-IR Imager and IFS** |  |  |  | 20% → 27% |  |  |  |
| 6 | **Management** |  |  |  | 11% → 18% |  |  |  |
| 7 | **Monthly Reports** |  |  |  | 50% → 56% |  |  |  |
| 17 | Monthly Reports 10 | 2010-03-05 A | 2010-03-05 A |  | 0% → 100% | 225.92d → none |  |  |
| 26 | **Project Meetings** |  |  |  | 9% → 18% |  |  |  |
| 28 | Project Meeting 2 | 2010-02-15 A | 2010-02-15 A |  | 0% → 100% | 240.42d → none |  |  |
| 38 | System Engineering Management Plan | 2010-02-15 → 2010-03-29 A (+42d) | 2010-03-03 → 2010-04-14 (+42d) |  | 0% → 50% | 235.66d → 198.36d |  | constraint start no earlier than 2010-02-14 → start no earlier than 2010-03-29 |
| 40 | Cost Review | 2010-03-31 → 2010-04-28 (+28d) | 2010-05-14 → 2010-06-11 (+28d) |  |  | 176.15d → 156.15d |  |  |
| 41 | **Project Plan Maintenance** |  |  |  | 50% → 67% |  |  |  |
| 45 | Project Plan Maintenance 4 | 2010-03-04 A | 2010-03-04 A |  | 0% → 100% | 260.89d → none |  |  |
| 58 | Preliminary Design Review |  | 2010-06-15 → 2010-06-14 (-1d) |  |  | 154.67d → 154.92d |  |  |
| 59 | **Science** | 2010-01-22 → 2010-03-22 (+59d) | 2010-05-18 → 2010-05-12 (-6d) | 82.76d? → 37.31d? |  | 174.17d → 178.61d |  |  |
| 60 | **Science Team Meetings** | 2010-01-22 → 2010-04-02 (+70d) |  | 51.5d? → 1.5d? |  |  |  |  |
| 61 | Meeting 1 | 2010-01-22 → 2010-04-02 (+70d) | 2010-01-25 → 2010-04-05 (+70d) |  |  | 323.55d → 205.42d | 2FS+9.5mo → 2FS+12mo |  |
| 62 | **Common Observing Operations Concept Document** |  | 2010-05-18 → 2010-05-12 (-6d) | 41.76d? → 37.31d? |  | 174.17d → 178.61d |  |  |
| 64 | Final Version |  | 2010-05-18 → 2010-05-12 (-6d) | 5.51d? → 1.67d? |  | 154.67d → 159.11d | 180, 199FS-2w → 180, 199 |  |
| 65 | **Instrument Design and Fabrication** |  |  |  | 21% → 29% |  |  |  |
| 72 | **Shared Facilities** |  | 2010-05-28 → 2010-05-14 (-14d) | 246.45d? → 237d? | 36% → 44% | 166.47d → 175.92d |  |  |
| 73 | **AO System** |  | 2010-05-28 → 2010-05-14 (-14d) | 246.45d? → 237d? | 33% → 42% | 166.47d → 175.92d |  |  |
| 74 | **High Order AO Relay** |  | 2010-05-28 → 2009-09-14 A (-256d) | 246.45d? → 62d? | 75% → 100% | 166.47d → none |  |  |
| 76 | **ADC** | 2010-01-25 → 2010-03-29 (+63d) | 2010-03-12 → 2010-05-14 (+63d) |  |  | 220.92d → 175.92d |  |  |
| 77 | Requirements Liason | 2010-01-25 → 2010-03-29 (+63d) | 2010-02-19 → 2010-04-23 (+63d) |  |  | 228.22d → 175.92d | 75FS+10w → 75FS+16w | constraint start no earlier than 2010-01-24 → start no earlier than 2010-03-28 |
| 78 | Design Liason | 2010-02-22 → 2010-04-26 (+63d) | 2010-03-12 → 2010-05-14 (+63d) |  |  | 228.22d → 175.92d |  |  |
| 79 | **Calibration Faciltiy** | 2010-03-02 → 2010-03-30 A (+28d) | 2010-04-13 → 2010-05-11 (+28d) |  | 0% → 17% | 199.67d → 179.67d |  |  |
| 80 | Requirements Liason | 2010-03-02 → 2010-03-30 A (+28d) | 2010-03-16 → 2010-04-13 (+28d) |  | 0% → 50% | 199.67d → 179.67d |  |  |
| 81 | Design Liason | 2010-03-16 → 2010-04-13 (+28d) | 2010-04-13 → 2010-05-11 (+28d) |  |  | 199.67d → 179.67d |  |  |
| 85 | **Instrument** |  |  |  | 18% → 26% |  |  |  |
| 86 | **IFS System Design Phase** |  | 2010-04-15 → 2010-05-11 (+26d) | 118.34d? → 136.12d? | 42% → 52% | 197.58d → 179.8d |  |  |
| 87 | **IFS Performance Budgets** |  | 2010-04-15 → 2010-05-11 (+26d) | 118.34d → 136.12d | 31% → 33% | 197.58d → 179.8d |  |  |
| 90 | Wavefront error | 2010-02-22 → 2010-03-22 (+28d) | 2010-03-02 → 2010-03-26 (+24d) | 6.67d → 4.44d |  | 268.53d → 196.21d | 89 → 89FS+4w |  |
| 91 | Spectroscopic performance |  | 2010-04-08 → 2010-05-03 (+25d) |  |  | 197.58d → 179.8d |  |  |
| 92 | Size and mass | 2010-04-08 → 2010-05-03 (+25d) | 2010-04-15 → 2010-05-11 (+26d) |  |  | 253.55d → 179.8d |  |  |
| 93 | **Trade Studies** |  | 2010-03-22 → 2010-03-24 (+2d) | 93.41d → 95.96d | 36% → 45% | 215.85d → 213.3d |  |  |
| 94 | FOV and spatial sampling |  |  |  | 20% → 67% |  |  |  |
| 96 | Optimization of image slicing formats and spectrograph formats |  | 2010-02-04 → 2010-03-24 (+48d) | 13.49d → 21.87d | 40% → 50% | 247.3d → 213.3d |  | resources Sean Adkins [33.3%]; Instrument Scientist [50%]; OE - Sergey Panteleev [33%]; ME - TBD [50%] → Sean Adkins [33.3%]; Instrument Scientist [50%]; OE - Sergey Panteleev [20.3%]; ME - TBD [50%] |
| 99 | **Conceptual Designs** |  | 2010-03-17 → 2010-03-24 (+7d) | 72.92d? → 77.1d? | 55% → 71% | 218d → 213.83d |  |  |
| 101 | Evaluation of design options |  | 2010-02-04 A |  | 50% → 100% | 0d → none |  |  |
| 102 | Calibration and alignment issues | 2010-02-04 A |  |  | 0% → 50% | 0d → 241.58d |  |  |
| 103 | Downselect of conceptual design |  | 2010-02-19 A |  | 50% → 100% | 0d → none |  |  |
| 104 | Revised performance budgets | 2010-02-19 → 2010-03-12 (+21d) | 2010-02-25 → 2010-03-18 (+21d) |  |  | 228.83d → 213.83d | 103 → 103FS+3w |  |
| 105 | Performance budget report | 2010-02-25 → 2010-03-18 (+21d) | 2010-03-03 → 2010-03-24 (+21d) |  |  | 228.83d → 213.83d |  |  |
| 106 | Performance estimates | 2010-02-19 A |  |  | 0% → 50% |  |  |  |
| 121 | **Near-IR Imager and IFS Preliminary Design** |  | 2010-06-04 → 2010-05-26 (-9d) | 243.15d? → 237d? | 25% → 39% | 161.77d → 167.92d |  |  |
| 122 | **Imager Trade Studies** |  | 2010-01-22 → 2010-04-16 (+84d) | 148.5d? → 208.5d? |  | 256.43d → 196.43d |  |  |
| 123 | Imager Wavefront Error | 2009-12-28 → 2010-03-22 (+84d) | 2010-01-22 → 2010-04-16 (+84d) |  |  | 0d → 187.43d | 133FS+80d → 138, 133FS+80d |  |
| 126 | **Imager Performance Budgets** |  | 2010-04-27 → 2010-05-05 (+8d) | 195.15d? → 201.3d? |  | 189.77d → 183.62d |  |  |
| 130 | Imager Wavefront Error |  | 2010-02-09 → 2010-05-04 (+84d) |  |  | 352.18d → 184.43d |  |  |
| 131 | Imager Size and Mass |  | 2010-04-27 → 2010-05-05 (+8d) |  |  | 189.77d → 183.62d |  |  |
| 132 | **Optical Design** |  | 2010-03-02 → 2010-03-30 (+28d) | 155.25d? → 175.25d? | 60% → 72% | 199.67d → 209.67d |  |  |
| 134 | **Optical Modeling** |  | 2010-02-23 → 2010-03-23 (+28d) | 61.25d? → 81.25d? | 50% → 69% | 199.67d → 214.67d |  |  |
| 136 | Lyot Stop |  |  |  | 50% → 90% |  |  |  |
| 138 | Imager Camera | 2010-02-01 A | 2010-02-19 → 2010-03-19 (+28d) | 15d? → 35d? | 0% → 57% |  |  | resources OE - Optical Engineer 2 → OE - Optical Engineer 2 [42.9%] |
| 139 | IFS Fold Mirror | 2010-02-22 A | 2010-02-23 → 2010-03-23 (+28d) |  | 0% → 50% | 199.67d → 0d |  |  |
| 140 | Preliminary Design Performance Analysis | 2010-02-23 → 2010-03-23 (+28d) | 2010-03-02 → 2010-03-30 (+28d) |  |  | 199.67d → 0d |  |  |
| 141 | **Dewar** |  | 2010-05-06 → 2010-05-26 (+20d) | 79.95d? → 93.45d? | 5% → 16% | 181.97d → 168.47d |  |  |
| 142 | **Cold Assemblies** |  | 2010-05-06 → 2010-05-26 (+20d) | 79.95d? → 93.45d? | 5% → 10% | 181.97d → 168.47d |  |  |
| 143 | **Dewar Internal Structure** | 2010-03-05 → 2010-04-02 (+28d) | 2010-03-31 → 2010-04-28 (+28d) |  |  | 13.85d → 0d |  |  |
| 144 | Interface Specification | 2010-03-05 → 2010-04-02 (+28d) | 2010-03-05 → 2010-04-02 (+28d) |  |  | 13.85d → 0d |  |  |
| 145 | Mechanical Model | 2010-03-08 → 2010-04-05 (+28d) | 2010-03-19 → 2010-04-16 (+28d) |  |  | 13.85d → 0d |  |  |
| 146 | FEA | 2010-03-22 → 2010-04-19 (+28d) | 2010-03-31 → 2010-04-28 (+28d) |  |  | 13.85d → 156.15d |  |  |
| 147 | Thermal Analysis | 2010-03-22 → 2010-04-19 (+28d) | 2010-03-26 → 2010-04-23 (+28d) |  |  | 175d → 0d |  |  |
| 148 | **Fore Optics** |  | 2010-03-12 → 2010-03-31 (+19d) | 40.5d? → 53.75d? | 14% → 9% | 221.42d → 208.17d |  |  |
| 149 | **Input Baffle & Coronagraph** |  | 2010-01-25 → 2010-03-30 (+64d) | 6.5d? → 52.5d? |  | 0d → 209.42d |  |  |
| 150 | Interface Specification |  | 2010-01-18 → 2010-03-23 (+64d) |  |  | 0d → 209.42d | 137 → 138 |  |
| 151 | Mechanical Model | 2010-01-18 → 2010-03-23 (+64d) | 2010-01-25 → 2010-03-30 (+64d) |  |  | 0d → 209.42d |  |  |
| 152 | **Re-imager** | 2010-01-18 A → 2010-03-23 (+64d) | 2010-01-26 → 2010-03-31 (+64d) |  | 17% → 0% | 254.42d → 208.17d |  |  |
| 153 | Interface Specification | 2010-01-18 A → 2010-03-23 (+64d) | 2010-01-19 → 2010-03-24 (+64d) |  | 75% → 0% | 254.42d → 208.17d | 135 → 139 |  |
| 154 | Mechanical Model | 2010-01-19 → 2010-03-24 (+64d) | 2010-01-26 → 2010-03-31 (+64d) |  |  | 288.39d → 208.17d |  |  |
| 158 | **Filter Wheels** |  | 2010-03-19 → 2010-04-01 (+13d) | 19.76d? → 28.1d? | 6% → 35% | 184.85d → 207.83d |  |  |

| ID | Task | Start | Finish | Duration | Complete | Total float | Predecessors |
| --- | --- | --- | --- | --- | --- | --- | --- |
| 159 | **Mechanism** |  | 2010-03-19 → 2010-04-01 (+13d) | 19.76d? → 28.1d? | 7% → 34% | 184.85d → 207.83d |  |
| 160 | Interface Specification |  | 2010-02-23 → 2010-03-23 (+28d) |  |  | 184.85d → 214.26d |  |
| 161 | Mechanical Model | 2010-02-25 → 2010-03-09 A (+12d) | 2010-03-19 → 2010-04-01 (+13d) |  | 0% → 30% | 184.85d → 0d |  |
| 162 | Filter Specifications | 2010-02-23 → 2010-03-08 A (+13d) | 2010-02-25 → 2010-03-09 (+12d) |  | 0% → 50% | 184.85d → 0d | 160 → 160SS+2w |
| 163 | **Imager** | 2010-02-22 A → 2010-03-22 (+28d) | 2010-05-06 → 2010-05-26 (+20d) | 53.95d? → 47.45d? | 3% → 0% | 181.97d → 0d |  |
| 164 | **Camera** | 2010-02-22 → 2010-03-22 (+28d) | 2010-03-04 → 2010-04-01 (+28d) |  |  | 13.85d → 0d |  |
| 165 | Interface Specification | 2010-02-22 → 2010-03-22 (+28d) | 2010-02-23 → 2010-03-23 (+28d) |  |  | 13.85d → 0d |  |
| 166 | Mechanical Model | 2010-02-23 → 2010-03-23 (+28d) | 2010-03-04 → 2010-04-01 (+28d) |  |  | 13.85d → 0d |  |
| 167 | **Detector Head** | 2010-02-23 A → 2010-03-22 (+27d) | 2010-05-06 → 2010-05-26 (+20d) | 52.45d? → 47.45d? | 4% → 0% | 181.97d → 168.47d |  |
| 168 | **Mount** | 2010-02-23 A → 2010-03-22 (+27d) | 2010-03-03 → 2010-03-29 (+26d) |  | 17% → 0% | 154.67d → 168.47d |  |
| 169 | Interface Specification | 2010-02-23 A → 2010-03-22 (+27d) | 2010-02-24 A → 2010-03-22 (+26d) |  | 100% → 0% | none → 168.47d | 165 → 138, 165 |
| 170 | Mechanical Model | 2010-02-24 → 2010-03-23 (+27d) | 2010-03-03 → 2010-03-29 (+26d) |  |  | 154.67d → 168.47d |  |
| 171 | **Focus Mechanism** | 2010-03-03 → 2010-03-30 (+27d) | 2010-04-30 → 2010-05-20 (+20d) | 42.45d? → 37.45d? |  | 154.67d → 168.47d |  |
| 172 | Interface Specification | 2010-03-03 → 2010-03-30 (+27d) | 2010-03-30 → 2010-04-23 (+24d) |  |  | 154.67d → 168.47d |  |
| 173 | Mechanical Model | 2010-03-30 → 2010-04-26 (+27d) | 2010-04-30 → 2010-05-20 (+20d) | 10d? → 5d? |  | 154.67d → 168.47d |  |
| 174 | **Cooling Interface** | 2010-04-30 → 2010-05-20 (+20d) | 2010-05-06 → 2010-05-26 (+20d) |  |  | 181.97d → 168.47d |  |
| 175 | Interface Specification | 2010-04-30 → 2010-05-20 (+20d) | 2010-05-03 → 2010-05-21 (+18d) |  |  | 181.97d → 168.47d |  |
| 176 | Mechanical Model | 2010-05-03 → 2010-05-21 (+18d) | 2010-05-06 → 2010-05-26 (+20d) |  |  | 181.97d → 168.47d |  |
| 177 | **Warm Assemblies** |  | 2010-04-08 → 2010-05-06 (+28d) | 53.5d? → 73.5d? | 5% → 35% | 201.92d → 181.92d |  |
| 178 | **Dewar Shell** |  | 2010-04-08 → 2010-05-06 (+28d) | 53.5d? → 73.5d? | 7% → 46% | 201.92d → 181.92d |  |
| 179 | Interface Specification |  | 2010-01-29 A |  | 50% → 100% | 27.35d → none |  |
| 180 | Mechanical Model | 2010-01-29 → 2010-02-19 A (+21d) | 2010-03-02 → 2010-03-15 (+13d) | 22.22d? → 16.67d? | 0% → 30% | 27.35d → 180.21d | 179 → 179FS+3w |
| 181 | Window Specifications |  | 2010-01-26 A |  | 50% → 100% | 0d → none |  |
| 182 | External Connections | 2010-04-06 → 2010-05-04 (+28d) | 2010-04-08 → 2010-05-06 (+28d) |  |  | 201.92d → 181.92d |  |
| 183 | Vacuum System Requirements | 2010-04-05 → 2010-05-03 (+28d) | 2010-04-06 → 2010-05-04 (+28d) |  |  | 201.92d → 181.92d |  |
| 184 | Cryogenic System Requirements | 2010-03-29 → 2010-04-26 (+28d) | 2010-04-02 → 2010-04-30 (+28d) |  |  | 201.92d → 181.92d |  |
| 185 | **Electronics** | 2010-04-30 → 2010-04-01 A (-29d) | 2010-05-18 → 2010-04-08 (-40d) | 11.25d? → 5d? | 0% → 25% | 156.47d → 202.83d |  |
| 186 | **Motion Control** | 2010-04-30 → 2010-04-01 A (-29d) | 2010-05-12 → 2010-04-07 (-35d) | 7.5d? → 4.25d? | 0% → 29% | 156.47d → 183.58d |  |
| 187 | Requirements | 2010-04-30 → 2010-04-01 A (-29d) | 2010-05-07 → 2010-04-02 (-35d) | 5d? → 1.25d? | 0% → 50% | 156.47d → 183.58d | 157, 161, 173 → 161 |
| 188 | Initial Design | 2010-05-07 → 2010-04-02 (-35d) | 2010-05-12 → 2010-04-07 (-35d) | 2.5d? → 3d? |  | 156.47d → 183.58d |  |
| 189 | Power Control | 2010-05-12 → 2010-04-07 (-35d) | 2010-05-13 → 2010-04-07 (-36d) | 1.25d? → 0.25d? |  | 156.47d → 183.58d |  |
| 190 | Pressure Monitoring | 2010-05-13 → 2010-04-07 (-36d) | 2010-05-14 → 2010-04-07 (-37d) | 1.25d? → 0.25d? |  | 156.47d → 183.58d |  |
| 191 | Temperature Monitoring and Control | 2010-05-14 → 2010-04-07 (-37d) | 2010-05-18 → 2010-04-08 (-40d) | 1.25d? → 0.25d? |  | 161.77d → 202.83d |  |
| 192 | **Software** | 2010-04-30 → 2010-04-01 (-29d) | 2010-05-21 → 2010-05-17 (-4d) | 14.55d? → 31.96d? |  | 154.67d → 171.52d |  |
| 193 | Detector Control | 2010-05-11 → 2010-04-28 (-13d) | 2010-05-14 → 2010-05-03 (-11d) |  |  | 172.97d → 182.42d |  |
| 194 | Global Server | 2010-05-14 → 2010-05-03 (-11d) | 2010-05-19 → 2010-05-06 (-13d) |  |  | 172.97d → 182.42d |  |
| 195 | Motion Control | 2010-04-30 → 2010-04-01 (-29d) | 2010-05-05 → 2010-04-05 (-30d) |  |  | 154.67d → 171.52d | 157, 161, 173 → 161 |
| 196 | Power Control | 2010-05-05 → 2010-04-05 (-30d) | 2010-05-06 → 2010-04-06 (-30d) |  |  | 154.67d → 171.52d |  |
| 197 | Pressure Monitoring | 2010-05-06 → 2010-04-06 (-30d) | 2010-05-07 → 2010-04-07 (-30d) |  |  | 154.67d → 171.52d |  |
| 198 | Temperature Monitoring and Control | 2010-05-07 → 2010-04-26 (-11d) | 2010-05-11 → 2010-04-28 (-13d) |  |  | 154.67d → 159.11d |  |
| 199 | User Interface Requirements | 2010-05-11 → 2010-04-28 (-13d) | 2010-05-17 → 2010-05-03 (-14d) |  |  | 154.67d → 159.11d |  |
| 200 | Data Reduction Tools | 2010-05-04 → 2010-04-28 (-6d) | 2010-05-21 → 2010-05-17 (-4d) |  |  | 171.42d → 175.87d |  |
| 201 | **Interfaces** | 2010-03-29 → 2010-04-16 A (+18d) | 2010-06-04 → 2010-05-20 (-15d) | 49.15d? → 24.44d? | 0% → 88% | 161.77d → 172.14d |  |
| 202 | Mechanical Interface Requirements | 2010-03-29 → 2010-04-26 A (+28d) | 2010-03-31 → 2010-04-28 (+28d) |  | 0% → 50% | 197.97d → 188.42d |  |
| 203 | Electronic Interface Requirements | 2010-05-18 → 2010-04-16 A (-32d) | 2010-05-20 → 2010-04-20 A (-30d) |  | 0% → 100% | 161.77d → none |  |
| 204 | Software Interface Requirements | 2010-05-17 → 2010-05-03 A (-14d) | 2010-05-19 → 2010-05-06 A (-13d) |  | 0% → 100% | 162.69d → none |  |
| 205 | Interface Control Document | 2010-05-20 → 2010-05-06 A (-14d) | 2010-06-04 → 2010-05-20 A (-15d) |  | 0% → 100% | 161.77d → none |  |
| 206 | **Accessories** | 2010-04-12 → 2010-05-10 (+28d) | 2010-04-28 → 2010-05-26 (+28d) |  |  | 174.92d → 154.92d |  |
| 207 | **Alignment Tooling** | 2010-04-20 → 2010-05-18 (+28d) | 2010-04-28 → 2010-05-26 (+28d) |  |  | 187.92d → 167.92d |  |
| 208 | Initial Specifications | 2010-04-20 → 2010-05-18 (+28d) | 2010-04-21 → 2010-05-19 (+28d) |  |  | 187.92d → 167.92d |  |
| 209 | Mechanical Model | 2010-04-22 → 2010-05-20 (+28d) | 2010-04-28 → 2010-05-26 (+28d) |  |  | 187.92d → 167.92d |  |
| 210 | **Assembly Tooling** | 2010-04-12 → 2010-05-10 (+28d) | 2010-04-20 → 2010-05-18 (+28d) |  |  | 174.92d → 154.92d |  |
| 211 | Initial Specifications | 2010-04-12 → 2010-05-10 (+28d) | 2010-04-13 → 2010-05-11 (+28d) |  |  | 174.92d → 154.92d |  |
| 212 | Mechanical Model | 2010-04-13 → 2010-05-11 (+28d) | 2010-04-20 → 2010-05-18 (+28d) |  |  | 174.92d → 154.92d |  |

## Version 9 (saved 2010-04-28, file Imager_and_IFS_PD_Phase_v1_2_tracked_Mar10.mpp)

Last finish stays 2011-01-17. Complete tasks 32 → 51.

Changed:

| ID | Task | Start | Finish | Duration | Complete | Total float | Other |
| --- | --- | --- | --- | --- | --- | --- | --- |
| 5 | **Near-IR Imager and IFS** |  |  |  | 27% → 32% |  |  |
| 6 | **Management** |  |  |  | 18% → 19% |  |  |
| 7 | **Monthly Reports** |  |  |  | 56% → 61% |  |  |
| 18 | Monthly Reports 11 | 2010-04-05 A | 2010-04-05 A |  | 0% → 100% | 204.92d → none |  |
| 59 | **Science** | 2010-03-22 → 2010-05-03 (+42d) | 2010-05-12 → 2010-05-28 (+16d) | 37.31d? → 19.75d? |  | 178.61d → 159.95d |  |
| 60 | **Science Team Meetings** | 2010-04-02 → 2010-05-17 (+45d) | 2010-04-05 → 2010-05-18 (+43d) |  |  | 205.42d → 174.42d |  |
| 61 | Meeting 1 | 2010-04-02 → 2010-05-17 (+45d) | 2010-04-05 → 2010-05-18 (+43d) |  |  | 205.42d → 174.42d | constraint none → start no earlier than 2010-05-16 |
| 62 | **Common Observing Operations Concept Document** | 2010-03-22 → 2010-05-03 (+42d) | 2010-05-12 → 2010-05-28 (+16d) | 37.31d? → 19.75d? |  | 178.61d → 159.95d |  |
| 63 | Initial Draft | 2010-03-22 → 2010-05-03 (+42d) | 2010-04-16 → 2010-05-28 (+42d) |  |  | 196.17d → 166.17d | constraint start no earlier than 2010-03-21 → start no earlier than 2010-05-02 |
| 65 | **Instrument Design and Fabrication** |  |  |  | 29% → 35% |  |  |
| 72 | **Shared Facilities** |  |  |  | 44% → 50% |  |  |
| 73 | **AO System** |  |  |  | 42% → 47% |  |  |
| 79 | **Calibration Faciltiy** |  |  |  | 17% → 33% |  |  |
| 80 | Requirements Liason |  | 2010-04-13 A |  | 50% → 100% | 179.67d → none |  |
| 82 | **Nasmyth Enclosure** |  |  |  | 50% → 63% |  |  |
| 83 | Requirements Liason |  |  |  | 50% → 75% |  |  |
| 85 | **Instrument** |  |  |  | 26% → 32% |  |  |
| 86 | **IFS System Design Phase** |  |  |  | 52% → 58% |  |  |
| 99 | **Conceptual Designs** |  |  |  | 71% → 85% |  |  |
| 104 | Revised performance budgets | 2010-03-12 A | 2010-03-18 A |  | 0% → 100% | 213.83d → none |  |
| 106 | Performance estimates |  | 2010-03-04 A |  | 50% → 100% | 0d → none |  |
| 107 | System requirements document | 2010-03-04 A |  |  | 0% → 50% |  |  |
| 108 | System design manual | 2010-03-11 A |  |  | 0% → 50% |  |  |
| 121 | **Near-IR Imager and IFS Preliminary Design** |  |  |  | 39% → 51% |  |  |
| 122 | **Imager Trade Studies** |  |  |  | 71% → 94% | 196.43d → 187.43d |  |
| 123 | Imager Wavefront Error | 2010-03-22 A |  |  | 0% → 75% |  |  |
| 124 | Imager Pixel Scale |  | 2010-01-20 A |  | 90% → 100% | 258.1d → none |  |
| 126 | **Imager Performance Budgets** |  |  |  | 48% → 53% |  |  |
| 127 | Imager Sensitivity |  | 2009-12-03 A |  | 90% → 100% | 5.16d → none |  |
| 128 | Imager Background |  | 2010-01-07 A |  | 90% → 100% | 0d → none |  |
| 129 | Imager Companion Sensitivity |  |  |  | 70% → 90% |  |  |
| 132 | **Optical Design** |  |  |  | 72% → 97% |  |  |
| 134 | **Optical Modeling** |  |  |  | 69% → 99% |  |  |
| 135 | Fore Optics |  | 2010-01-15 A |  | 90% → 100% | 260.92d → none |  |
| 136 | Lyot Stop |  | 2010-01-04 A |  | 90% → 100% | 0d → none |  |
| 137 | Coronagraph |  |  |  | 50% → 90% |  |  |
| 138 | Imager Camera |  | 2010-03-19 A |  | 57% → 100% | 0d → none |  |
| 139 | IFS Fold Mirror |  | 2010-03-23 A |  | 50% → 100% | 0d → none |  |
| 140 | Preliminary Design Performance Analysis | 2010-03-23 A |  |  | 0% → 50% | 0d → 209.67d |  |
| 141 | **Dewar** |  |  |  | 16% → 22% |  |  |
| 142 | **Cold Assemblies** |  |  |  | 10% → 15% |  |  |
| 148 | **Fore Optics** |  |  |  | 9% → 20% |  |  |
| 149 | **Input Baffle & Coronagraph** |  |  |  | 17% → 23% |  |  |
| 150 | Interface Specification |  | 2010-03-23 A |  | 75% → 100% | 209.42d → none |  |
| 152 | **Re-imager** | 2010-03-23 A |  |  | 0% → 23% |  |  |
| 153 | Interface Specification | 2010-03-23 A | 2010-03-24 A |  | 0% → 100% | 208.17d → none |  |
| 155 | **Adjustable Lyot Stop** |  |  |  | 8% → 17% |  |  |
| 156 | Interface Specification |  | 2010-03-02 A |  | 50% → 100% | 221.42d → none |  |
| 158 | **Filter Wheels** |  |  |  | 35% → 40% | 207.83d → 0d |  |
| 159 | **Mechanism** |  |  |  | 34% → 36% | 207.83d → 0d |  |
| 160 | Interface Specification |  | 2010-03-23 A |  | 75% → 100% | 214.26d → none |  |
| 162 | Filter Specifications |  |  |  | 50% → 90% |  |  |
| 163 | **Imager** | 2010-03-22 A |  |  | 0% → 6% | 0d → 168.47d |  |
| 164 | **Camera** | 2010-03-22 A |  |  | 0% → 17% |  |  |
| 165 | Interface Specification | 2010-03-22 A | 2010-03-23 A |  | 0% → 100% | 0d → none |  |
| 177 | **Warm Assemblies** |  |  |  | 35% → 41% |  |  |
| 178 | **Dewar Shell** |  |  |  | 46% → 53% |  |  |
| 180 | Mechanical Model |  |  |  | 30% → 50% |  |  |
| 185 | **Electronics** |  |  |  | 25% → 70% |  |  |
| 186 | **Motion Control** |  |  |  | 29% → 65% | 183.58d → 203.58d |  |
| 188 | Initial Design | 2010-04-02 A |  |  | 0% → 50% | 183.58d → 203.58d |  |
| 189 | Power Control | 2010-04-07 A | 2010-04-07 A |  | 0% → 100% | 183.58d → none |  |
| 190 | Pressure Monitoring | 2010-04-07 A | 2010-04-07 A |  | 0% → 100% | 183.58d → none |  |
| 191 | Temperature Monitoring and Control | 2010-04-07 A | 2010-04-08 A |  | 0% → 100% | 202.83d → none |  |

## Version 10 (saved 2010-06-26, file Imager_and_IFS_PD_Phase_v1_2_tracked_May10.mpp)

Last finish stays 2011-01-17. Complete tasks 51 → 92.

Changed:

| ID | Task | Start | Finish | Complete | Total float |
| --- | --- | --- | --- | --- | --- |
| 5 | **Near-IR Imager and IFS** |  |  | 32% → 51% |  |
| 6 | **Management** |  |  | 19% → 56% |  |
| 7 | **Monthly Reports** |  |  | 61% → 72% |  |
| 19 | Monthly Reports 12 | 2010-05-05 A | 2010-05-05 A | 0% → 100% | 182.92d → none |
| 20 | Monthly Reports 13 | 2010-06-07 A | 2010-06-07 A | 0% → 100% | 159.92d → none |
| 26 | **Project Meetings** |  |  | 18% → 45% |  |
| 29 | Project Meeting 3 | 2010-03-15 A | 2010-03-15 A | 0% → 100% | 220.42d → none |
| 30 | Project Meeting 4 | 2010-04-15 A | 2010-04-15 A | 0% → 100% | 197.42d → none |
| 31 | Project Meeting 5 | 2010-05-17 A | 2010-05-17 A | 0% → 100% | 175.42d → none |
| 38 | System Engineering Management Plan |  | 2010-04-14 A | 50% → 100% | 198.36d → none |
| 40 | Cost Review | 2010-04-28 A | 2010-06-11 A | 0% → 100% | 156.15d → none |
| 41 | **Project Plan Maintenance** |  |  | 67% → 83% |  |
| 46 | Project Plan Maintenance 5 | 2010-06-04 A | 2010-06-04 A | 0% → 100% | 160.92d → none |
| 48 | **Budget Maintenance** |  |  | 25% → 75% |  |
| 51 | Budget Maintenance 3 | 2009-12-04 A | 2009-12-04 A | 0% → 100% | 290.92d → none |
| 52 | Budget Maintenance 4 | 2010-02-04 A | 2010-02-04 A | 0% → 100% | 246.92d → none |
| 53 | Budget Maintenance 6 | 2010-04-05 A | 2010-04-05 A | 0% → 100% | 204.92d → none |
| 54 | Budget Maintenance 7 | 2010-06-04 A | 2010-06-04 A | 0% → 100% | 160.92d → none |
| 57 | Preliminary Design Report | 2010-05-18 A | 2010-05-28 A | 0% → 100% | 154.92d → none |
| 59 | **Science** | 2010-05-03 A |  | 0% → 7% | 159.95d → 166.17d |
| 60 | **Science Team Meetings** | 2010-05-17 A | 2010-05-18 A | 0% → 100% | 174.42d → none |
| 61 | Meeting 1 | 2010-05-17 A | 2010-05-18 A | 0% → 100% | 174.42d → none |
| 65 | **Instrument Design and Fabrication** |  |  | 35% → 51% |  |
| 66 | **AO System to Instrument Interface Definitions** |  |  | 64% → 71% |  |
| 69 | Electronic/Electrical |  | 2009-09-25 A | 75% → 100% | 0d → none |
| 71 | Alignment and Calibration Concept for Instrument on AO System |  |  | 25% → 50% |  |
| 72 | **Shared Facilities** |  | 2010-05-14 A | 50% → 100% | 175.92d → none |
| 73 | **AO System** |  | 2010-05-14 A | 47% → 100% | 175.92d → none |
| 76 | **ADC** | 2010-03-29 A | 2010-05-14 A | 0% → 100% | 175.92d → none |
| 77 | Requirements Liason | 2010-03-29 A | 2010-04-23 A | 0% → 100% | 175.92d → none |
| 78 | Design Liason | 2010-04-26 A | 2010-05-14 A | 0% → 100% | 175.92d → none |
| 79 | **Calibration Faciltiy** |  | 2010-05-11 A | 33% → 100% | 179.67d → none |
| 81 | Design Liason | 2010-04-13 A | 2010-05-11 A | 0% → 100% | 179.67d → none |
| 82 | **Nasmyth Enclosure** |  | 2010-05-11 A | 63% → 100% | 0d → none |
| 83 | Requirements Liason |  | 2010-04-23 A | 75% → 100% | 0d → none |
| 84 | Design Liason |  | 2010-05-11 A | 50% → 100% | 0d → none |
| 85 | **Instrument** |  |  | 32% → 43% |  |
| 86 | **IFS System Design Phase** |  |  | 58% → 90% |  |
| 87 | **IFS Performance Budgets** |  |  | 33% → 67% |  |
| 88 | Throughput |  | 2010-02-04 A | 70% → 100% | 204.61d → none |
| 89 | Background |  | 2010-02-22 A | 40% → 100% | 196.21d → none |
| 90 | Wavefront error | 2010-03-22 A | 2010-03-26 A | 0% → 100% | 196.21d → none |
| 91 | Spectroscopic performance |  |  | 30% → 50% |  |
| 93 | **Trade Studies** |  | 2010-03-24 A | 45% → 100% | 213.3d → none |
| 94 | FOV and spatial sampling |  | 2010-03-09 A | 67% → 100% | 224.84d → none |
| 95 | Wavelength coverage and spatial sampling |  | 2010-01-01 A | 50% → 100% | 260.54d → none |
| 96 | Optimization of image slicing formats and spectrograph formats |  | 2010-03-24 A | 50% → 100% | 213.3d → none |
| 97 | Wavefront error allocations | 2010-03-04 A | 2010-03-15 A | 0% → 100% | 215.85d → none |
| 98 | Trade study report | 2010-03-15 A | 2010-03-22 A | 0% → 100% | 215.85d → none |
| 99 | **Conceptual Designs** |  |  | 85% → 93% |  |
| 105 | Performance budget report | 2010-03-18 A | 2010-03-24 A | 0% → 100% | 213.83d → none |
| 107 | System requirements document |  | 2010-03-11 A | 50% → 100% | 0d → none |
| 109 | **System Design Review** | 2010-03-11 A | 2010-03-18 A | 0% → 100% | 0d → none |
| 110 | System design report | 2010-03-11 A | 2010-03-16 A | 0% → 100% | 0d → none |
| 111 | System design review meeting | 2010-03-16 A | 2010-03-18 A | 0% → 100% | 0d → none |
| 121 | **Near-IR Imager and IFS Preliminary Design** |  |  | 51% → 63% |  |
| 122 | **Imager Trade Studies** |  | 2010-04-16 A | 94% → 100% | 187.43d → none |
| 123 | Imager Wavefront Error |  | 2010-04-16 A | 75% → 100% | 187.43d → none |
| 126 | **Imager Performance Budgets** |  |  | 53% → 87% |  |
| 129 | Imager Companion Sensitivity |  | 2010-01-20 A | 90% → 100% | 258.42d → none |
| 130 | Imager Wavefront Error |  | 2010-05-04 A | 25% → 100% | 184.43d → none |
| 132 | **Optical Design** |  | 2010-03-30 A | 97% → 100% | 209.67d → none |
| 134 | **Optical Modeling** |  | 2010-03-23 A | 99% → 100% | 214.67d → none |
| 137 | Coronagraph |  | 2010-01-14 A | 90% → 100% | 261.92d → none |
| 140 | Preliminary Design Performance Analysis |  | 2010-03-30 A | 50% → 100% | 209.67d → none |
| 141 | **Dewar** |  |  | 22% → 31% |  |
| 142 | **Cold Assemblies** |  |  | 15% → 23% |  |
| 148 | **Fore Optics** |  |  | 20% → 36% |  |
| 149 | **Input Baffle & Coronagraph** |  |  | 23% → 38% |  |
| 151 | Mechanical Model | 2010-03-23 A |  | 0% → 20% |  |

| ID | Task | Start | Finish | Complete | Total float |
| --- | --- | --- | --- | --- | --- |
| 152 | **Re-imager** |  |  | 23% → 38% |  |
| 154 | Mechanical Model | 2010-03-24 A |  | 0% → 20% |  |
| 155 | **Adjustable Lyot Stop** |  |  | 17% → 33% |  |
| 157 | Mechanical Model | 2010-03-03 A |  | 0% → 20% |  |
| 158 | **Filter Wheels** |  |  | 40% → 41% |  |
| 162 | Filter Specifications |  | 2010-03-09 A | 90% → 100% | 0d → none |
| 163 | **Imager** |  |  | 6% → 19% |  |
| 167 | **Detector Head** | 2010-03-22 A |  | 0% → 20% |  |
| 168 | **Mount** | 2010-03-22 A |  | 0% → 17% | 168.47d → 209.92d |
| 169 | Interface Specification | 2010-03-22 A | 2010-03-22 A | 0% → 100% | 168.47d → none |
| 171 | **Focus Mechanism** | 2010-03-30 A |  | 0% → 33% |  |
| 172 | Interface Specification | 2010-03-30 A | 2010-04-23 A | 0% → 100% | 168.47d → none |
| 177 | **Warm Assemblies** |  |  | 41% → 56% |  |
| 178 | **Dewar Shell** |  |  | 53% → 58% |  |
| 182 | External Connections | 2010-05-04 A |  | 0% → 50% |  |
| 183 | Vacuum System Requirements | 2010-05-03 A |  | 0% → 50% | 181.92d → 0d |
| 184 | Cryogenic System Requirements | 2010-04-26 A |  | 0% → 50% | 181.92d → 0d |
| 192 | **Software** | 2010-04-01 A |  | 0% → 50% | 171.52d → 175.87d |
| 193 | Detector Control | 2010-04-28 A |  | 0% → 50% | 182.42d → 0d |
| 194 | Global Server | 2010-05-03 A |  | 0% → 50% |  |
| 195 | Motion Control | 2010-04-01 A |  | 0% → 50% | 171.52d → 0d |
| 196 | Power Control | 2010-04-05 A |  | 0% → 50% | 171.52d → 0d |
| 197 | Pressure Monitoring | 2010-04-06 A |  | 0% → 50% | 171.52d → 12.4d |
| 198 | Temperature Monitoring and Control | 2010-04-26 A |  | 0% → 50% | 159.11d → 0d |
| 199 | User Interface Requirements | 2010-04-28 A |  | 0% → 50% | 159.11d → 0d |
| 200 | Data Reduction Tools | 2010-04-28 A |  | 0% → 50% |  |
| 201 | **Interfaces** |  | 2010-05-20 A | 88% → 100% | 172.14d → none |
| 202 | Mechanical Interface Requirements |  | 2010-04-28 A | 50% → 100% | 188.42d → none |

## Version 11 (saved 2010-07-23, file Imager_and_IFS_PD_Phase_v1_2_tracked_June10.mpp)

Last finish stays 2011-01-17. Complete tasks 92 → 97.

Changed:

| ID | Task | Start | Finish | Duration | Complete | Total float | Predecessors | Other |
| --- | --- | --- | --- | --- | --- | --- | --- | --- |
| 1 | **Milestones** |  | 2010-06-14 → 2010-06-15 A (+1d) | 291d? → 292.5d? | 0% → 100% | 155.92d → none |  |  |
| 3 | Imager Preliminary Design Review | 2010-06-14 → 2010-06-15 A (+1d) | 2010-06-14 → 2010-06-15 A (+1d) | 0d? → 0d | 0% → 100% | 155.92d → none | 58FS-1d → 58 |  |
| 4 | IFS System Design Review | 2010-03-17 → 2010-06-15 A (+90d) | 2010-03-17 → 2010-06-15 A (+90d) |  | 0% → 100% | 218.87d → none | 111FS-1d → 58 |  |
| 5 | **Near-IR Imager and IFS** |  |  |  | 51% → 52% |  |  |  |
| 6 | **Management** |  |  |  | 56% → 58% |  |  |  |
| 7 | **Monthly Reports** |  |  |  | 72% → 78% |  |  |  |
| 21 | Monthly Reports 14 | 2010-07-05 A | 2010-07-05 A |  | 0% → 100% | 139.92d → none |  |  |
| 58 | Preliminary Design Review | 2010-06-11 → 2010-06-14 A (+3d) | 2010-06-14 → 2010-06-15 A (+1d) |  | 0% → 100% | 154.92d → none |  | constraint none → start no earlier than 2010-06-14 |
| 65 | **Instrument Design and Fabrication** |  |  |  | 51% → 52% |  |  |  |
| 85 | **Instrument** |  |  |  | 43% → 44% |  |  |  |
| 86 | **IFS System Design Phase** |  |  |  | 90% → 94% |  |  |  |
| 87 | **IFS Performance Budgets** |  |  |  | 67% → 76% |  |  |  |
| 91 | Spectroscopic performance |  |  |  | 50% → 75% |  |  |  |
| 99 | **Conceptual Designs** |  |  |  | 93% → 96% |  |  |  |
| 108 | System design manual |  | 2010-03-17 A |  | 50% → 100% | 218d → none |  |  |
